# 3GPP_Work Plan

Schedule from MS Project, 2000-01-01 to 2003-08-05, A marks actual dates.

## Calendars

- Standard: Mon-Fri 08:00-12:00, 13:00-17:00; Sat-Sun off.

## Resources

| Resource |
| --- |
| TSG CN |
| WG CN1 |
| WG CN2 |
| WG CN3 |
| WG CN4 |
| WG CN5 |
| TSG T |
| WG T1 |
| WG T2 |
| WG T3 |
| TSG RAN |
| WG RAN1 |
| WG RAN2 |
| WG RAN3 |
| WG RAN4 |
| TSG SA |
| WG SA1 |
| WG SA2 |
| WG SA3 |
| WG SA4 |
| WG SA5 |
| PCG |
| TSG GERAN |
| No |
| CN4 |
| ? |
| WG G2 |
| WG GERAN2 |
| WG GERAN1 |
| WG GERAN4 |
| WG GERAN3 |
| All |
| Generic |
| TSG GERANTSG GERAN |
| MLST |
| WG GERAN1, WG GERAN2 |
| RAN3 |

## Schedule

| ID | WBS | Task | Duration | Start | Finish | Complete | Remaining | Baseline start | Baseline finish | Baseline duration | Total slack | Constraint | Resources | Work | Actual work | Text9 | Text1 | Text4 | Text6 | Text7 | Text8 | Text2 | Text3 | Text5 |
| --- | --- | --- | --- | --- | --- | --- | --- | --- | --- | --- | --- | --- | --- | --- | --- | --- | --- | --- | --- | --- | --- | --- | --- | --- |
| 1 | 1 | VERSION 2001 November 29th | 1d | 2000-01-03 | 2000-01-03 |  |  | 2000-01-03 | 2000-01-03 | 1d | 936d |  |  |  |  | 2044 |  |  |  |  |  |  |  |  |
| 2 | 2 | "CTRL + a" to display all the 3GPP fields | 1d | 2000-01-03 | 2000-01-03 |  |  | 2000-01-03 | 2000-01-03 | 1d | 936d |  |  |  |  | 1462 |  |  |  |  |  |  |  |  |
| 3 | 3 | Content of Rel4 frozen. Rel5 and after not frozen. | 1d | 2000-01-03 | 2000-01-03 |  |  | 2000-01-03 | 2000-01-03 | 1d | 936d |  |  |  |  | 2058 |  |  |  |  |  |  |  |  |
| 6 | 4 | **Evolutions of the transport in the UTRAN** | 445d | 2000-07-17 A | 2002-03-29 | 52% | 213.26d | 2000-07-17 | 2002-03-29 | 445d | 352d |  | TSG RAN | 13960h | 6186.74h |  | ETRAN | Francois Courau | NA | TSG | Carolyn |  |  |  |
| 7 | 4.1 | IP transport in the UTRAN | 370d | 2000-07-17 A | 2001-12-14 | 68% | 118.4d | 2000-07-17 | 2001-12-14 | 370d | 427d | finish no earlier than 2001-12-14 | WG RAN3 | 2960h | 2012.8h | 625 | ETRAN-IPtrans | Nicolas Drevon, Alcatel | Rel5 | TSG |  | BaAS |  |  |
| 8 | 4.2 | QoS optimisation for AAL2 connections over Iub and Iur interfaces | 160d | 2000-08-21 A | 2001-03-30 A | 100% |  | 2000-08-21 | 2001-03-30 | 160d |  | finish no earlier than 2001-03-30 | WG RAN3 | 1280h | 1280h | 12 | ETRAN-QoSAAL2 | T. Yoshimura, Japan Telecom | Rel4 | TSG |  | BaAS |  |  |
| 9 | 4.3 | Transport bearer modification procedure on Iub, Iur, and Iu | 130d | 2000-10-02 A | 2001-03-30 A | 100% |  | 2000-10-02 | 2001-03-30 | 130d |  | finish no earlier than 2001-03-30 | WG RAN3 | 1040h | 1040h | 1995 | ETRAN-MigrMod | T. Yoshimura, Japan Telecom | Rel4 | TSG |  |  |  |  |
| 10 | 4.4 | **Evolution of transport in UTRAN and GERAN** | 130d | 2001-09-24 | 2002-03-22 |  |  | 2001-09-24 | 2002-03-22 | 130d | 357d |  | WG RAN3 | 3040h |  | 2257 | ETRANG |  | Rel5 | TSG |  |  |  |  |
| 11 | 4.4.1 | Addition of transport mechanisms other than ATM for Iu - Identification of alternative transports | 130d | 2001-09-24 | 2002-03-22 |  |  | 2001-09-24 | 2002-03-22 | 130d | 357d | start no earlier than 2001-09-24 | WG RAN3 | 1040h |  | 2258 | ETRANG |  |  | TSG |  |  |  |  |
| 12 | 4.4.2 | Addition of transport mechanisms other than ATM for Iu - Specification of those alternatives transports | 120d | 2001-10-01 | 2002-03-15 |  |  | 2001-10-01 | 2002-03-15 | 120d | 362d | finish no earlier than 2002-03-15 | WG RAN3 | 960h |  | 2259 | ETRANG |  |  | TSG |  |  |  |  |
| 13 | 4.5 | **Conformance Test Aspects** | 130d | 2001-10-01 | 2002-03-29 |  |  | 2001-10-01 | 2002-03-29 | 130d | 352d |  | WG T1 | 2080h |  | 1834 |  |  |  |  |  |  |  |  |
| 14 | 4.5.1 | Testing RAB support enhancements | 130d | 2001-10-01 | 2002-03-29 |  |  | 2001-10-01 | 2002-03-29 | 130d | 352d | start no earlier than 2001-10-01 | WG T1 | 1040h |  | 2208 | CT-RABS? |  |  |  |  |  | 34.108, 34. 121, 34.122, 34.123 pts 1,2, 34.123 pt 3 |  |
| 15 | 5 | **Evolutions of the transport in the CN** | 410d | 2000-05-29 A | 2001-12-21 | 77% | 92.63d | 2000-05-29 | 2001-12-21 | 410d | 422d |  | WG CN4 | 11168h | 8488.63h |  | CNTRSP |  | NA |  | Kimmo | BaAS |  |  |
| 16 | 5.1 | **IP Transport of CN protocols (e.g., CAP, MAP)** | 77d | 2000-12-07 A | 2001-03-23 A | 100% |  | 2000-12-07 | 2001-03-23 | 77d |  |  | WG CN4 | 2808h | 2808h | 859 | SS7IP |  | Rel4 |  |  | BaAS |  |  |
| 17 | 5.1.1 | **Stage 3** | 77d | 2000-12-07 A | 2001-03-23 A | 100% |  | 2000-12-07 | 2001-03-23 | 77d |  |  | WG CN4 | 2192h | 2192h | 1679 | SS7IP |  |  |  |  |  |  |  |
| 18 | 5.1.1.1 | CAP | 77d | 2000-12-07 A | 2001-03-23 A | 100% |  | 2000-12-07 | 2001-03-23 | 77d |  | finish no earlier than 2001-03-23 | WG CN2 | 616h | 616h | 2018 | SS7IP |  |  | WG |  |  |  |  |
| 19 | 5.1.1.2 | MAP | 77d | 2000-12-07 A | 2001-03-23 A | 100% |  | 2000-12-07 | 2001-03-23 | 77d |  | finish no earlier than 2001-03-23 | WG CN4 | 616h | 616h | 2019 | SS7IP |  |  |  |  |  |  |  |
| 20 | 5.1.1.3 | BSSAP+ | 43d | 2001-01-15 A | 2001-03-14 A | 100% |  | 2001-01-15 | 2001-03-14 | 43d |  | finish no earlier than 2001-03-14 | WG CN1 | 344h | 344h | 2253 | SS7IP-BSSAP+ |  |  | WG |  | Loc |  |  |
| 21 | 5.2 | FS on Usage of SUA | 205d | 2001-03-12 A | 2001-12-21 | 32% | 139.4d | 2001-03-12 | 2001-12-21 | 205d | 422d | finish no earlier than 2001-12-21 | WG CN4 | 1640h | 524.8h | 2455 | SS7IP |  | Rel5 |  |  |  |  |  |
| 22 | 5.3 | **FS on Transport and control separation in the PS CN domain** | 215d | 2000-05-29 A | 2001-03-23 A | 100% |  | 2000-05-29 | 2001-03-23 | 215d |  |  | WG SA2 | 3440h | 3440h | 1513 |  | Juan-Antonio Ibanez, Ericsson Deutschland | Rel4 | TSG |  | BaAS |  | Juan-Antonio.Ibanez@eed.ericsson.se |
| 23 | 5.3.1 | Architectural impacts | 215d | 2000-05-29 A | 2001-03-23 A | 100% |  | 2000-05-29 | 2001-03-23 | 215d |  | finish no earlier than 2001-03-23 | WG SA2 | 1720h | 1720h | 1615 |  |  |  | WG |  | BaAS |  |  |
| 24 | 6 | **High Speed Downlink Packet Access** | 245d | 2001-04-02 A | 2002-03-08 | 39% | 149.48d | 2001-04-02 | 2001-12-28 | 195d | 367d |  | WG RAN2 | 8512h | 3318.74h | 2476 | HSDPA | Ravi Kuchibhotla, Motorola | Rel5 | TSG | Hans |  |  |  |
| 25 | 6.1 | Physical Layer | 192d | 2001-04-05 A | 2001-12-28 | 55% | 86.4d | 2001-04-05 | 2001-12-28 | 192d | 417d | finish no earlier than 2001-12-28 | WG RAN1 | 1536h | 844.8h | 2477 | HSDPA-Phys | Amitava Ghosh, Motorola |  | TSG |  |  |  |  |
| 26 | 6.2 | Layer 2 and 3 aspects | 192d | 2001-04-05 A | 2001-12-28 | 66% | 65.28d | 2001-04-05 | 2001-12-28 | 192d | 417d | finish no earlier than 2001-12-28 | WG RAN2 | 1536h | 1013.76h | 2478 | HSDPA-L23 | Ravi Kuchibhotla, Motorola |  | TSG |  |  |  |  |
| 27 | 6.3 | Iub/Iur protocol aspects | 195d | 2001-04-02 A | 2001-12-28 | 20% | 156d | 2001-04-02 | 2001-12-28 | 195d | 417d | finish no earlier than 2001-12-28 | WG RAN3 | 1560h | 312h | 2479 | HSDPA-IubIur | Mike Diesen, Motorola |  | TSG |  |  |  |  |
| 28 | 6.4 | RF Radio Transmission/ Reception, System Performance Requirements and Conformance Testing | 240d | 2001-04-09 A | 2002-03-08 | 20% | 192d | 2001-04-09 | 2001-12-28 | 190d | 367d | finish no earlier than 2002-03-08 | WG RAN4 | 1920h | 384h | 2480 | HSDPA-RF | Howard Benn, Motorola |  | TSG |  |  |  |  |

Notes:
- 15: WI formulation assigned to N4
- 16: AS: corrected to Rel4 as stated at SA#10
- 21: update WID
- 22: Rel4 added

| ID | WBS | Task | Duration | Start | Finish | Complete | Remaining | Baseline start | Baseline finish | Baseline duration | Total slack | Constraint | Resources | Work | Actual work | Text1 | Text6 | Text7 | Text8 | Text2 | Text4 | Text9 |
| --- | --- | --- | --- | --- | --- | --- | --- | --- | --- | --- | --- | --- | --- | --- | --- | --- | --- | --- | --- | --- | --- | --- |
| 29 | 7 | **Improvements of Radio Interface** | 937d | 2000-01-03 A | 2003-08-05 | 46% | 510.54d | 2000-06-19 | 2003-03-28 | 725d | 0d |  | TSG RAN | 82852.8h | 37200.3h | RInImp | NA | TSG | Shinobu |  |  |  |
| 30 | 7.1 | Improvement of inter-frequency and inter-system measurement | 260d | 2001-01-01 A | 2001-12-28 | 40% | 156d | 2001-01-01 | 2001-12-28 | 260d | 417d | finish no earlier than 2001-12-28 | WG RAN1 | 2080h | 832h | RInImp-IfIsM | Rel5 | TSG |  | BaAS | tbd by RAN WG1 | 1470 |
| 31 | 7.2 | **Base station classification** | 410d | 2000-08-14 A | 2002-03-08 | 83% | 70.36d | 2000-08-14 | 2002-03-28 | 424d | 367d |  | WG RAN4 | 11368h | 9417.11h | RInImp-BSClass | Rel5 | TSG |  | BaAS | A. Toskala, Nokia | 1471 |
| 32 | 7.2.1 | FDD Base station classification | 410d | 2000-08-14 A | 2002-03-08 | 72% | 114.8d | 2000-08-14 | 2002-03-28 | 424d | 367d | finish no earlier than 2002-03-08 | WG RAN4 | 3280h | 2361.6h | RInImp-BSClass-FDD |  | TSG |  | BaAs | A. Toskala, Nokia | 1476 |
| 33 | 7.2.2 | TDD Base station classification | 410d | 2000-08-14 A | 2002-03-08 | 95% | 20.5d | 2000-08-14 | 2001-06-29 | 230d | 367d | finish no earlier than 2002-03-08 | WG RAN4 | 3280h | 3116h | RInImp-BSClass-TDD |  | TSG |  | BaAs | A. Toskala, Nokia | 1477 |
| 34 | 7.2.3 | Base Station Classification for 1.28 Mcps TDD option | 191d | 2001-06-15 A | 2002-03-08 | 80% | 38.2d | 2001-06-15 | 2001-12-11 | 128d | 367d | finish no earlier than 2002-03-08 | WG RAN4 | 1528h | 1222.4h | RInImp-BSClass-LCRTDD |  | TSG |  |  | Meik Kottkamp, Siemens |  |
| 35 | 7.3 | Hybrid ARQ II/III | 355d | 2000-08-21 A | 2001-12-28 | 82% | 63.9d | 2000-08-21 | 2001-12-28 | 355d | 417d | finish no earlier than 2001-12-28 | WG RAN2 | 2840h | 2328.8h | RInImp-HARQ | Rel5 | TSG |  |  | A. Sitte, Siemens | 1217 |
| 36 | 7.4 | Improved usage of downlink resource in FDD for CCTrCHs of dedicated type | 580d | 2000-10-09 | 2002-12-27 |  |  | 2000-10-09 | 2001-12-28 | 320d | 157d | finish no earlier than 2002-12-27 | WG RAN2 | 4640h |  | RInImp-CCTrCH |  | TSG |  | BaAS | N. Pereira, C. Mihailescu, Nortel Networks | 1218 |
| 37 | 7.5 | Terminal Power Saving features | 696.6d | 2000-06-19 | 2003-02-18 |  |  | 2000-06-19 | 2003-02-18 | 696.6d | 120.4d | finish no earlier than 2003-02-18 | WG RAN2 | 5572.8h |  | RInImp-TPS |  | TSG |  | BaAS | M. Park, Samsung | 1507 |
| 38 | 7.6 | UTRA repeater specification (master) | 183d | 2000-07-10 A | 2001-03-21 A | 100% |  | 2000-07-10 | 2001-03-21 | 183d |  | finish no earlier than 2001-03-21 | WG RAN4 | 1464h | 1464h | RInImp-REP | Rel4 | TSG |  |  | T. Kummetz, Mikom; Alf Ahlström, Allgon | 1509 |
| 39 | 7.7 | DSCH power control improvement in soft handover | 140d | 2000-09-11 A | 2001-03-23 A | 100% |  | 2000-09-11 | 2001-03-23 | 140d |  | finish no earlier than 2001-03-23 | WG RAN1 | 1120h | 1120h | RInImp-DSCHsho | Rel4 | TSG |  |  | A. Toskala, Nokia | 1994 |
| 40 | 7.8 | UMTS 1800 | 320d | 2000-09-25 A | 2001-12-14 A | 100% |  | 2000-09-25 | 2001-09-21 | 260d |  | finish no earlier than 2001-12-14 | WG RAN4 | 2560h | 2560h | RInImp-UMTS18 | Rel indep | TSG |  |  | H. Benn, Motorola | 1996 |
| 41 | 7.9 | UMTS 1900 | 195d | 2001-03-19 A | 2001-12-14 A | 100% |  | 2001-03-19 | 2001-09-21 | 135d |  | finish no earlier than 2001-12-14 | WG RAN4 | 1560h | 1560h | RInImp-UMTS19 | Rel indep | TSG | Cesar |  | Howard Benn, Motorola | 2467 |
| 42 | 7.10 | Multiple Input Multiple Output antennas (MIMO) | 253d | 2001-03-16 A | 2002-03-05 | 20% | 202.4d | 2001-03-16 | 2002-03-05 | 253d | 370d | finish no earlier than 2002-03-05 | WG RAN1 | 2024h | 404.8h | RInImp-MIMO | Rel6 | TSG |  |  | Howard Huang, Lucent | 2468 |
| 43 | 7.11 | Enhancement on the DSCH hard split mode | 193d | 2001-03-16 A | 2001-12-11 | 55% | 86.85d | 2001-03-16 | 2001-12-11 | 193d | 430d | finish no earlier than 2001-12-11 | WG RAN1 | 1544h | 849.2h | RInImp-DSCHhsp | Rel5 | TSG |  |  | Jaeyoel KIM, Samsung | 2469 |
| 44 | 7.12 | FS on Fast Cell Selection (FCS) for HS-DSCH | 193d | 2001-03-16 A | 2001-12-11 | 10% | 173.7d | 2001-03-16 | 2001-12-11 | 193d | 430d | finish no earlier than 2001-12-11 | WG RAN1 | 1544h | 154.4h | RInImp-FCS | Rel5 | TSG |  |  | Robert Love, Motorola | 2471 |
| 45 | 7.13 | FS on Radio link performance enhancements | 355d | 2000-08-14 A | 2001-12-21 | 48% | 185d | 2000-08-14 | 2001-12-21 | 355d | 422d | finish no earlier than 2001-12-21 | WG RAN1 | 2840h | 1360h | RInImp-Rlperf | Rel5 | TSG |  |  | tbd by RAN WG1 | 1506 |
| 46 | 7.14 | FS on High Speed downlink packet access | 155d | 2000-08-21 A | 2001-03-23 A | 100% |  | 2000-08-21 | 2001-03-23 | 155d |  | finish no earlier than 2001-03-23 | WG RAN2 | 1240h | 1240h | RInImp-HSDPA |  | TSG |  |  | A. Ghosh, Motorola | 1219 |
| 47 | 7.15 | FS on USTS | 355d | 2000-08-14 A | 2001-12-21 | 80% | 71d | 2000-08-14 | 2001-12-21 | 355d | 422d | finish no earlier than 2001-12-21 | WG RAN1 | 2840h | 2272h | RInImp-USTS | Rel5 | TSG |  | BaAS | D. Kim, SK Telecom | 1221 |
| 48 | 7.16 | FS on improved common DL channel for Cell-FACH state | 340d | 2000-09-11 A | 2001-12-28 | 66% | 115.6d | 2000-09-11 | 2001-12-28 | 340d | 417d | finish no earlier than 2001-12-28 | WG RAN2 | 2720h | 1795.2h | RInImp-DLCFACH |  | TSG |  |  | J. Kwak, GBT | 1510 |
| 49 | 7.17 | FS on UE antenna efficency test method performance requirements | 255d | 2000-09-25 A | 2001-09-14 A | 100% |  | 2000-09-25 | 2001-06-29 | 200d |  | finish no earlier than 2001-09-14 | WG RAN4 | 2040h | 2040h | RInImp-UEAnTM | Rel5 | TSG |  |  | O. Edvardsson, Allgon | 1997 |
| 50 | 7.18 | FS on the re-introduction of the downlink SIR measurement | 200d | 2001-03-12 A | 2001-12-14 A | 100% |  | 2001-03-12 | 2001-09-21 | 140d |  | finish no earlier than 2001-12-14 | WG RAN4 | 1600h | 1600h | RInImp-SIR | Rel5 | TSG | Cesar |  | Torgny Palenius, Ericsson | 24002 |
| 51 | 7.19 | FS on UTRA WideBand Distribution Systems | 330d | 2001-03-12 A | 2002-06-14 | 75% | 82.5d | 2001-03-12 | 2001-09-21 | 140d | 297d | finish no earlier than 2002-06-14 | WG RAN4 | 2640h | 1980h | RInImp-WDS | Rel5 | TSG |  |  | Andrea Casini, Tekmar Sistemi |  |
| 52 | 7.20 | FS on mitigating the effect of CPICH interference at the UE | 195d | 2001-03-19 A | 2001-12-14 | 80% | 39d | 2001-03-19 | 2001-09-21 | 135d | 427d | finish no earlier than 2001-12-14 | WG RAN4 | 1560h | 1248h | RInImp-CPICH_Intf | Rel5 | TSG | Cesar |  | Shimon Moshavi, Intel | 24001 |
| 53 | 7.21 | TO BE COMPLETED: FS on considering deployment of UTRA in additional and diverse spectrum arrangement | 1d | 2000-01-03 | 2000-01-03 |  |  |  |  |  | 936d |  |  |  |  |  |  |  |  |  |  |  |

Notes:
- 35: Work on this task is performed as part of High Speed Downlink Packet Access feature
- 36: Ttime line changed after decision in RAN#13
- 37: This is a building block without particular end date
- 48: Date moved to December 2001 by decision in RAN#13

| ID | WBS | Task | Type | Duration | Start | Finish | Complete | Remaining | Baseline start | Baseline finish | Baseline duration | Total slack | Free slack | Constraint | Resources | Work | Actual work | Text9 | Text1 | Text3 | Text7 | Text6 | Text8 | Text2 | Text4 |
| --- | --- | --- | --- | --- | --- | --- | --- | --- | --- | --- | --- | --- | --- | --- | --- | --- | --- | --- | --- | --- | --- | --- | --- | --- | --- |
| 54 | 7.22 | **Conformance Test Spec. improvements in Radio Interface** |  | 477d | 2001-10-08 | 2003-08-05 |  |  | 2001-03-19 | 2003-03-28 | 530d | 0d |  |  | WG T1 | 20520h |  |  |  |  |  |  |  |  |  |
| 55 | 7.22.1 | Testing improvement of inter-frequency and inter-system measurement |  | 140d | 2001-10-08 | 2002-04-19 |  |  | 2001-03-19 | 2001-09-28 | 140d | 337d |  | start no earlier than 2001-10-08 | WG T1 | 1120h |  | 2210 |  |  |  |  |  |  |  |
| 56 | 7.22.2 | Testing Hybrid ARQ II/III |  | 140d | 2001-10-08 | 2002-04-19 |  |  | 2001-03-19 | 2001-09-28 | 140d | 337d |  | start no earlier than 2001-10-08 | WG T1 | 1120h |  | 2211 |  |  |  |  |  |  |  |
| 57 | 7.22.3 | Testing Improved usage of downlink resource in FDD for CCTrCHs of dedicated type |  | 140d | 2001-10-08 | 2002-04-19 |  |  | 2001-03-19 | 2001-09-28 | 140d | 337d |  | start no earlier than 2001-10-08 | WG T1 | 1120h |  | 2212 |  |  |  |  |  |  |  |
| 58 | 7.22.4 | Testing Terminal Power saving features |  | 140d | 2001-10-08 | 2002-04-19 |  |  | 2001-03-19 | 2001-09-28 | 140d | 337d |  | start no earlier than 2001-10-08 | WG T1 | 1120h |  | 2213 |  |  |  |  |  |  |  |
| 59 | 7.22.5 | Testing DSCH power control improvement in soft handover |  | 140d | 2001-10-08 | 2002-04-19 |  |  | 2001-03-19 | 2001-09-28 | 140d | 337d |  | start no earlier than 2001-10-08 | WG T1 | 1120h |  | 2214 |  |  |  |  |  |  |  |
| 60 | 7.22.6 | Testing UMTS 1800 |  | 217d | 2001-10-08 | 2002-08-06 |  |  | 2001-05-31 | 2002-03-29 | 217d | 260d |  | start no earlier than 2001-10-08 | WG T1 | 1736h |  | 2215 | RInImp-UMTS18-19 | 34.108, 34,121, 34.122, 34.123-1 | TSG |  |  |  |  |
| 61 | 7.22.7 | Testing UMTS 1900 |  | 217d | 2001-10-08 | 2002-08-06 |  |  | 2001-05-31 | 2002-03-29 | 217d | 260d |  | start no earlier than 2001-10-08 | WG T1 | 1736h |  | 2215 | RInImp-UMTS18-19 | 34.108, 34,121, 34.122, 34.123-1 | TSG |  |  |  |  |
| 62 | 7.22.8 | Testing UMTS 1800 - TTCN |  | 477d | 2001-10-08 | 2003-08-05 |  |  | 2001-05-31 | 2003-03-28 | 477d | 0d |  | start no earlier than 2001-10-08 | WG T1 | 3816h |  |  | RInImp-UMTS18-19 | 34.123-3 | TSG |  |  |  |  |
| 63 | 7.22.9 | Testing UMTS 1900 - TTCN |  | 477d | 2001-10-08 | 2003-08-05 |  |  | 2001-05-31 | 2003-03-28 | 477d | 0d |  | start no earlier than 2001-10-08 | WG T1 | 3816h |  |  | RInImp-UMTS18-19 | 34.123-3 | TSG |  |  |  |  |
| 64 | 8 | **RAN improvements** |  | 790d | 2000-01-03 A | 2003-01-10 | 28% | 570.4d | 2000-08-14 | 2002-06-28 | 490d | 147d |  |  | TSG RAN | 37160h | 9951.5h |  | RANimp |  | TSG | NA | Hans |  |  |
| 65 | 8.1 | **RRM optimization for Iur and Iub** |  | 196d | 2001-03-16 A | 2001-12-14 | 17% | 162.69d | 2001-03-16 | 2001-12-14 | 196d | 427d |  |  | WG RAN3 | 5752h | 1511.44h | 656 | RANimp-RRMopt |  | TSG | Rel5 |  | BaAS | Gert-Jan van Lieshout, Ericsson |
| 66 | 8.1.1 | Iur common transport channel efficiency optimisation |  | 196d | 2001-03-16 A | 2001-12-14 | 20% | 156.8d | 2001-03-16 | 2001-12-14 | 196d | 427d |  | finish no earlier than 2001-12-14 | WG RAN3 | 1568h | 313.6h |  | RANimp-RRMopt-ctc |  | TSG |  |  |  | Shahrokh Amirijoo, Ericsson |
| 67 | 8.1.2 | Iur neighbouring cell reporting efficiency optimisation |  | 196d | 2001-03-16 A | 2001-12-14 | 20% | 156.8d | 2001-03-16 | 2001-12-14 | 196d | 427d |  | finish no earlier than 2001-12-14 | WG RAN3 | 1568h | 313.6h |  | RANimp-RRMopt-ncr |  | TSG |  |  |  | Shahrokh Amirijoo, Ericsson |
| 68 | 8.1.3 | Introduction of direct transport bearers between SRNC and Node-B |  | 131d | 2001-06-15 A | 2001-12-14 | 8% | 120.52d | 2001-06-15 | 2001-12-14 | 131d | 427d |  | finish no earlier than 2001-12-14 | WG RAN3 | 1048h | 83.84h |  | RAN-imp-RRMopt-DTB |  | TSG |  |  |  | Risto Sepponen, Ericsson |
| 69 | 8.2 | RL Timing Adjustment |  | 194d | 2001-03-16 A | 2001-12-12 | 68% | 63d | 2001-03-16 | 2001-12-12 | 194d | 429d |  | finish no earlier than 2001-12-12 | WG RAN3 | 1552h | 1048h | 22003 | RANimp-RLTA |  | TSG | Rel5 |  |  | Elena Voltolina, Ericsson |
| 70 | 8.3 | Separation of resource reservation and radio link activation |  | 194d | 2001-03-16 A | 2001-12-12 | 65% | 68d | 2001-03-16 | 2001-12-12 | 194d | 429d |  | finish no earlier than 2001-12-12 | WG RAN3 | 1552h | 1008h | 22004 | RANimp-SepRR |  | TSG | Rel5 |  |  | Gert-Jan van Lieshout, Ericsson |
| 71 | 8.4 | Improvement of Radio Resource Management across RNS and RNS/PSS |  | 194d | 2001-03-16 A | 2001-12-12 | 65% | 68d | 2001-03-16 | 2001-12-12 | 194d | 429d |  | finish no earlier than 2001-12-12 | WG RAN3 | 1552h | 1008h | 22001 | RANimp-ImpRRM |  | TSG | Rel5 |  |  | Antti Toskala, Nokia |
| 72 | 8.5 | Re-arrangements of Iub transport bearers |  | 194d | 2001-03-16 A | 2001-12-12 | 25% | 145.5d | 2001-03-16 | 2001-12-12 | 194d | 429d |  | finish no earlier than 2001-12-12 | WG RAN3 | 1552h | 388h | 22002 | RANimp-TTPS |  | TSG | Rel5 |  |  | Antti Toskala, Nokia |
| 73 | 8.6 | SRNS Relocation Procedure Enhancement |  | 131d | 2001-06-15 A | 2001-12-14 | 8% | 120.52d | 2001-06-15 | 2001-12-14 | 131d | 427d |  | finish no earlier than 2001-12-14 | WG RAN3 | 1048h | 83.84h |  | RANimp-SRNS |  | TSG | Rel5 |  |  | Olivier Guyot, Nokia |
| 74 | 8.7 | Node B synchronisation for TDD |  | 160d | 2000-08-14 A | 2001-03-23 A | 100% |  | 2000-08-14 | 2001-03-23 | 160d |  |  | finish no earlier than 2001-03-23 | WG RAN1 | 1280h | 1280h | 655 | RANimp-NBsync |  | TSG | Rel4 |  | BaAS | S. Oestreich, Siemens |
| 75 | 8.8 | RAB support enhancement - except Robust Header Compression (ROHC) |  | 355d | 2000-08-21 A | 2001-12-28 | 2% | 347.9d | 2000-08-21 | 2001-03-23 | 155d | 417d |  | finish no earlier than 2001-12-28 | WG RAN2 | 2840h | 56.8h | 624 | RANimp-RABSE | This is a building block without particular end date | TSG |  |  | BaAS | M. Israelsson, A. Krishnarajah, Ericsson |
| 76 | 8.9 | RAB support enhancement - Robust Header Compression (ROHC) |  | 155d | 2000-08-21 A | 2001-03-23 A | 100% |  | 2000-08-21 | 2001-03-23 | 155d |  |  | finish no earlier than 2001-03-23 | WG RAN2 | 1240h | 1240h | 2206 | RANimp-RABSE |  | TSG | Rel4 |  |  | M. Israelsson, A. Krishnarajah, Ericsson |
| 77 | 8.10 | Header compression removal/stripping in the RAN |  | 218d | 2000-08-21 | 2001-06-20 |  |  | 2000-08-21 | 2001-06-20 | 218d | 554d |  | finish no earlier than 2001-06-20 | TSG RAN | 1744h |  | 1680 |  |  |  | Rel5 |  |  |  |
| 78 | 8.11 | Unequal error protection in PS domain in the RAN |  | 218d | 2000-08-21 | 2001-06-20 |  |  | 2000-08-21 | 2001-06-20 | 218d | 554d |  | finish no earlier than 2001-06-20 | TSG RAN | 1744h |  | 1686 |  |  |  | Rel5 |  |  |  |
| 79 | 8.12 | Beamforming (to be completed) |  | 1d | 2000-01-03 | 2000-01-03 |  |  |  |  |  | 936d |  |  |  |  |  |  |  |  | TSG |  |  |  |  |
| 80 | 8.13 | Node B Synchronisation for 1.28 Mcps TDD |  | 193d | 2001-03-16 A | 2001-12-11 | 60% | 77.2d | 2001-03-16 | 2001-12-11 | 193d | 430d |  | finish no earlier than 2001-12-11 | WG RAN1 | 1544h | 926.4h | 2472 | RANimp-NBSLCR |  | TSG | Rel5 |  |  | Jinling HU, CWTS/CATT |
| 81 | 8.14 | Start Testing | milestone | 0d | 2001-10-01 | 2001-10-01 |  |  | 2001-03-19 | 2001-03-19 | 0d | 147d | 0d | start no earlier than 2001-10-01 | MLST |  |  | 1912 |  |  |  |  |  |  |  |

Notes:
- 55: start/finish dates set
- 56: start/finish dates set
- 57: start/finish dates set
- 58: start/finish dates set
- 59: start/finish dates set
- 60: finish date set
- 61: finish date set
- 62: finish date set
- 63: finish date set
- 75: 29 Nov 2000: split into ROHC and non-ROHC part; 5 Mar 2001: splitting off of ROHC for Rel-4 agreed by R2
- 76: 29 Nov 2000: split into ROHC and non-ROHC part; 5 Mar 2001: splitting off of ROHC for Rel-4 agreed by R2
- 77: from AHR00-0031, contact RAN
- 78: from AHR00-0031, contact RAN

| ID | WBS | Task | Duration | Start | Finish | Predecessors | Complete | Remaining | Baseline start | Baseline finish | Baseline duration | Total slack | Constraint | Resources | Work | Actual work | Text3 | Text9 | Text7 | Text1 | Text4 | Text6 | Text8 | Text2 |
| --- | --- | --- | --- | --- | --- | --- | --- | --- | --- | --- | --- | --- | --- | --- | --- | --- | --- | --- | --- | --- | --- | --- | --- | --- |
| 82 | 8.15 | **Conformance Test Aspects - RAN Improvements** | 335d | 2001-10-01 | 2003-01-10 | 81 |  |  | 2001-03-19 | 2002-06-28 | 335d | 147d |  | WG T1 | 8720h |  | 0% | 2102 |  |  |  |  |  |  |
| 83 | 8.15.1 | Testing Smart antenna | 140d | 2001-10-01 | 2002-04-12 |  |  |  | 2001-03-19 | 2001-09-28 | 140d | 342d | start no earlier than 2001-09-24 | WG T1 | 1120h |  |  | 2220 |  |  |  |  |  |  |
| 84 | 8.15.2 | Testing Node B synchronisation for TDD | 140d | 2001-10-01 | 2002-04-12 |  |  |  | 2001-03-19 | 2001-09-28 | 140d | 342d | finish no earlier than 2001-09-28 | WG T1 | 1120h |  |  | 2221 |  |  |  |  |  |  |
| 85 | 8.15.3 | Testing Radio access bearer support enhancments | 140d | 2001-10-01 | 2002-04-12 |  |  |  | 2001-03-19 | 2001-09-28 | 140d | 342d | finish no earlier than 2001-09-28 | WG T1 | 1120h |  |  | 2222 |  |  |  |  |  |  |
| 86 | 8.15.4 | Testing RAB support enhancements-Robust Header Compression | 335d | 2001-10-01 | 2003-01-10 |  |  |  | 2001-03-19 | 2002-06-28 | 335d | 147d | finish no earlier than 2002-06-28 | WG T1 | 2680h |  |  | 2461 | TSG |  |  |  |  |  |
| 87 | 9 | **Provisioning of IP-based multimedia services** | 780d | 2000-01-03 A | 2002-12-27 |  | 16% | 652.13d | 2000-02-21 | 2002-10-21 | 696d | 157d |  | WG SA1 | 185613h | 28833.2h |  | 1273 | TSG | IMS | Mark Cataldo, Motorola | NA | MichaelC/Alain |  |
| 88 | 9.1 | **Call control and roaming to support IMS in UMTS** | 580d | 2000-01-03 A | 2002-03-22 |  | 18% | 473.78d | 2000-02-21 | 2002-03-08 | 535d | 357d |  | WG SA2 | 69030.6h | 12686.4h |  | 1274 | TSG | IMS-CCR | Liz Daniel, Lucent | Rel5 |  |  |
| 89 | 9.1.1 | Stage 1 | 215d | 2000-02-21 A | 2000-12-15 A |  | 100% |  | 2000-02-21 | 2000-12-15 | 215d |  | finish no earlier than 2000-09-21 | WG SA1 | 1720h | 1720h | 22.228 | 1633 |  | IMS-CCR | Mark Cataldo, Motorola |  |  | CCaR |
| 90 | 9.1.2 | Stage 2 (Architecture and Main flows) | 246d | 2000-04-14 A | 2001-03-23 A |  | 100% |  | 2000-04-14 | 2001-03-23 | 246d |  | finish no earlier than 2001-03-23 | WG SA2 | 1968h | 1968h | 23.228 | 1514 | TSG | IMS-CCR | Liz Daniel, Lucent |  |  | CCaR |
| 91 | 9.1.3 | **SIP Call Control protocol for the IMS** | 385d | 2000-10-02 A | 2002-03-22 |  | 10% | 346.97d | 2000-10-02 | 2001-12-14 | 315d | 357d |  | WG CN1 | 45536h | 4498.26h | TS 24.228, TS 24.229, TS 23.218 | 2233 | TSG | IMS-CCR | Keith Drage, Lucent |  |  |  |
| 92 | 9.1.3.1 | IMS signalling flows | 385d | 2000-10-02 A | 2002-03-22 |  | 65% | 134.75d | 2000-10-02 | 2001-12-12 | 313d | 357d | finish no earlier than 2002-03-22 | WG CN1 | 3080h | 2002h | TS 24.228 | 1998 | TSG | IMS-CCR |  |  |  | CCaR |
| 93 | 9.1.3.2 | IMS stage 3 | 385d | 2000-10-02 A | 2002-03-22 |  | 40% | 231d | 2000-10-02 | 2001-12-12 | 313d | 357d | finish no earlier than 2002-03-22 | WG CN1 | 3080h | 1232h | TS 24.229 | 1278 | TSG | IMS-CCR |  |  |  | CCaR |
| 94 | 9.1.3.3 | IMS Session Handling; stage 2 | 385d | 2000-10-02 A | 2002-03-22 |  | 31% | 265d | 2000-10-02 | 2001-12-12 | 313d | 357d | start no earlier than 2000-10-02 | WG CN1 | 3080h | 960h | TS 23.218 | 2255 | TSG | IMS-CCR |  |  |  |  |
| 95 | 9.1.3.4 | IETF: draft-ietf-sip-rfc2543bis (Session Initiation Protocol) | 346d | 2000-11-24 | 2002-03-22 |  |  |  | 2000-11-24 | 2001-12-14 | 276d | 357d | finish no earlier than 2002-03-22 | WG CN1 | 2768h |  |  |  |  |  |  |  |  |  |
| 96 | 9.1.3.5 | IETF: draft-sip-manyfolks-resource (Without COMET)(Integration of resource management and SIP) | 346d | 2000-11-24 | 2002-03-22 |  |  |  | 2000-11-24 | 2001-11-15 | 255d | 357d | finish no earlier than 2002-03-22 | WG CN1 | 2768h |  |  |  |  |  |  |  |  |  |
| 97 | 9.1.3.6 | IETF: draft-ietf-sip-100rel (Reliability of Provisional Response in SIP) | 346d | 2000-11-24 | 2002-03-22 |  |  |  | 2000-11-24 | 2001-11-15 | 255d | 357d | finish no earlier than 2002-03-22 | WG CN1 | 2768h |  |  |  |  |  |  |  |  |  |
| 98 | 9.1.3.7 | IETF: draft-ietf-sip-privacy (SIP extensions for caller identity and privacy) | 346d | 2000-11-24 | 2002-03-22 |  |  |  | 2000-11-24 | 2001-12-12 | 274d | 357d | finish no earlier than 2002-03-22 | WG CN1 | 2768h |  |  |  |  |  |  |  |  |  |
| 99 | 9.1.3.8 | IETF: draft-ietf-sip-call-auth (SIP extensions for media authorization) | 346d | 2000-11-24 | 2002-03-22 |  |  |  | 2000-11-24 | 2001-12-12 | 274d | 357d | finish no earlier than 2002-03-22 | WG CN1 | 2768h |  |  |  |  |  |  |  |  |  |
| 100 | 9.1.3.9 | IETF: draft-ietf-sip-events (specific event notification) | 346d | 2000-11-24 | 2002-03-22 |  |  |  |  |  |  | 357d | finish no earlier than 2002-03-22 | WG CN1 | 2768h |  |  |  |  |  |  |  |  |  |
| 101 | 9.1.3.10 | IETF: draft-ietf-sip-refer (refer method) | 346d | 2000-11-24 | 2002-03-22 |  |  |  |  |  |  | 357d | finish no earlier than 2002-03-22 | WG CN1 | 2768h |  |  |  |  |  |  |  |  |  |
| 102 | 9.1.3.11 | IETF: draft-ietf-sip-dhcp (DHCP options for SIP servers) | 346d | 2000-11-24 | 2002-03-22 |  |  |  |  |  |  | 357d | finish no earlier than 2002-03-22 | WG CN1 | 2768h |  |  |  |  |  |  |  |  |  |
| 103 | 9.1.3.12 | IETF: draft-biggs-sip-replaces (SIP replaces header) | 346d | 2000-11-24 | 2002-03-22 |  |  |  |  |  |  | 357d | finish no earlier than 2002-03-22 | WG CN1 | 2768h |  |  |  |  |  |  |  |  |  |
| 104 | 9.1.3.13 | IETF: draft-ietf-avt-rtp-amr (AMR and AMR WB RTP and SDP) | 346d | 2000-11-24 | 2002-03-22 |  |  |  |  |  |  | 357d | finish no earlier than 2002-03-22 | WG CN1 | 2768h |  |  |  |  |  |  |  |  |  |
| 105 | 9.1.3.14 | IETF: draft-ietf-mmusic-sdp-new (IPv6 support within SDP) | 346d | 2000-11-24 | 2002-03-22 |  |  |  |  |  |  | 357d | finish no earlier than 2002-03-22 | WG CN1 | 2768h |  |  |  |  |  |  |  |  |  |
| 106 | 9.1.3.15 | IETF: draft-ietf-sip-serverfeatures (SIP supported header) | 346d | 2000-11-24 | 2002-03-22 |  |  |  |  |  |  | 357d | finish no earlier than 2002-03-22 | WG CN1 | 2768h |  |  |  |  |  |  |  |  |  |
| 107 | 9.1.4 | SIP SS and relationship to Mg, Mw and Cx | 580d | 2000-01-03 | 2002-03-22 |  |  |  | 2001-01-01 | 2001-12-28 | 260d | 357d |  | WG CN4 | 4640h |  |  | 1280 |  | IMS-CCR |  |  |  | CCaR |

Notes:
- 83: duration set to 6 months (was 0)
- 84: duration set to 6 months (was 0)
- 85: duration set to 6 months (was 0)
- 87: S1 WI proposed S1-000290 / TR22.976, WI Rapporteur, Mark Cataldo, Motorola / Text5: mcatald1@email.mot.com
- 89: Issues include e.g.: Roaming requirements, Requirements on supplementary services, Interworking requirements / Text5: 17.-21.7., S1#9, Completion of CR's against 22 series [dates taken from 22.976]
- 90: Issues include e.g.: Mobile IP, RAB selection principles, Optimized VoIP bearer mechanisms, SIP multimedia protocol / Text5: R00 stage 2 at least 80 % complete in TSGS #8 21.-23.6.2000 [WI dates need revision. To be revised by TSG#8]
- 91: TSGN_10 approved the change:CN1 - SA2 SIP joint meeting spotted one more place for improvement: work tasks with ID 1998 and 1278 are actually subtasks under of single CN1 WT. One WI has been approved for the CN1 WT with title "SIP Call Control protocol... / Text5: drage@lucent.com
- 92: TS 24.228...
- 93: TS 24.229...
- 94: TS 23.218...
- 95: Inserted by Per 5/5-01 to identify N1s dependency on IETF draft schedule. / The finnish date equals IETFs planned document submission. / The % complete is of no relevance for this WT. / IESG review planned end of October -01.
- 96: Inserted by Per 5/5-01 to identify N1s dependency on IETF draft schedule. / The finnish date equals IETFs planned document submission. / The % complete is of no relevance for this WT. / COMET is dependant on RFC 2543bis completion. / IESG review planned 15th September.
- 97: Inserted by Per 5/5-01 to identify N1s dependency on IETF draft schedule. / The finnish date equals IETFs planned document submission. / The % complete is of no relevance for this WT. / IESG review planned end of October -01.
- 98: Inserted by Per 5/5-01 to identify N1s dependency on IETF draft schedule. / The finnish date equals IETFs planned document submission. NB: UNDEFINED / The % complete is of no relevance for this WT. / IESG to plan this on the calendar, but 3GPP to define service requirements first.
- 99: Inserted by Per 5/5-01 to identify N1s dependency on IETF draft schedule. / The finnish date equals IETFs planned document submission. NB: UNDEFINED / The % complete is of no relevance for this WT. / Draft was ready for last call 4/01,- IESG reviews this for the schedule in its next meeting.
- 103: 10/9-01 Per: This draft is not yet in the calendar (Ileana input)
- 105: 10/9-01 Per: This draft is not yet scheduled (Ileana input)
- 106: 10/9-01 Per: This draft was agreed in CN#13 as a dependency, and no schedule is known.

| ID | WBS | Task | Duration | Start | Finish | Complete | Remaining | Baseline start | Baseline finish | Baseline duration | Total slack | Constraint | Resources | Work | Actual work | Text1 | Text2 | Text9 | Text3 | Text5 | Text7 | Text6 |
| --- | --- | --- | --- | --- | --- | --- | --- | --- | --- | --- | --- | --- | --- | --- | --- | --- | --- | --- | --- | --- | --- | --- |
| 108 | 9.1.5 | **Addressing** | 380d | 2000-10-09 A | 2002-03-22 | 49% | 193.91d | 2000-10-09 | 2001-08-31 | 235d | 357d |  | WG SA2 | 7744h | 3792.32h | IMS-CCR | CCaR | 1290 |  |  |  |  |
| 109 | 9.1.5.1 | Architectural issues | 235d | 2000-10-09 A | 2001-08-31 A | 100% |  | 2000-10-09 | 2001-08-31 | 235d |  | finish no earlier than 2001-03-16 | WG SA2 | 1880h | 1880h | IMS-CCR | CCaR | 1291 |  |  |  |  |
| 110 | 9.1.5.2 | Impact on HSS | 353d | 2000-11-15 A | 2002-03-22 | 15% | 300.05d | 2000-11-15 | 2001-06-29 | 163d | 357d | finish no earlier than 2002-03-22 | WG CN4 | 2824h | 423.6h | IMS-CCR | CCaR | 1292 |  |  |  |  |
| 111 | 9.1.6 | Service Examples | 179d | 2001-04-17 A | 2001-12-21 | 20% | 143.2d | 2001-04-17 | 2001-12-21 | 179d | 422d | finish no earlier than 2001-12-21 | WG SA1 | 1432h | 286.4h | IMS-Sex |  |  | 22.928 | mcatald1@email.mot.com | TSG |  |
| 112 | 9.1.7 | IMS Framework Report | 179d | 2001-04-17 A | 2001-12-21 | 15% | 152.15d | 2001-04-17 | 2001-12-21 | 179d | 422d | finish no earlier than 2001-12-21 | WG SA1 | 1432h | 214.8h | IMS-FrWk |  |  | 22.941 | rwohlert@tri.sbc.com | TSG |  |
| 113 | 9.2 | **Access Security for IMS** | 270d | 2001-06-25 A | 2002-07-05 | 11% | 240.5d | 2000-09-04 | 2002-03-14 | 399d | 282d |  | WG SA3 | 6920h | 755.97h | IMS-ASEC |  | 1298 |  | krister.boman@emw.ericsson.se | TSG | Rel5 |
| 114 | 9.2.1 | SA3 task | 270d | 2001-06-25 A | 2002-07-05 | 24% | 205d |  |  |  | 282d | start no earlier than 2001-06-25 | WG SA3 | 2160h | 520h |  |  |  |  |  |  |  |
| 115 | 9.2.2 | IMS impacts on UICC | 185d | 2001-10-08 | 2002-06-21 |  |  |  |  |  | 292d | finish no earlier than 2002-06-21 | WG T3 | 1480h |  |  |  |  |  |  |  |  |
| 116 | 9.2.3 | SIP extensions for Integrity protection | 140d | 2001-12-17 | 2002-06-28 |  |  |  |  |  | 287d | start no earlier than 2001-12-17 | WG CN1 | 1120h |  |  |  |  |  |  |  |  |
| 117 | 9.3 | Security Aspects of Requirement for Network Configuration Independence | 130d | 2001-07-02 A | 2001-12-28 | 4% | 124.7d | 2001-07-02 | 2001-09-12 | 53d | 417d | finish no earlier than 2001-09-12 | WG SA3 | 1040h | 42.4h | SEC1-NCI |  |  |  | hugh.shieh@attws.com | TSG | Rel5 |
| 118 | 9.4 | Lawful interception | 183d | 2000-07-10 A | 2001-03-21 | 22% | 142d | 2000-09-04 | 2001-03-29 | 149d | 619d |  | WG SA3 | 1464h | 328h | IMS-LI | CCaR | 1299 |  | berthold.wilhelm@regtp.de | TSG |  |
| 119 | 9.5 | (copy) GERAN support of IMS | 235d | 2001-08-13 A | 2002-07-05 | 9% | 215d |  |  |  | 282d | start no earlier than 2001-08-13 | TSG GERAN | 1880h | 160h |  |  |  |  |  |  |  |
| 120 | 9.6 | Charging Management for IMS | 335d | 2000-12-01 A | 2002-03-14 | 25% | 251.25d | 2000-12-01 | 2002-03-14 | 335d | 363d | finish no earlier than 2002-03-14 | WG SA5 | 2680h | 670h | OAM-CH/IP | BCaM | 2242 | 32.2xy (Charging) | Karl-Heinz.Nenner@T-MOBIL.DE | TSG | Rel5 |
| 121 | 9.7 | (copy) Charging and OAM&P | 260d | 2000-12-25 A | 2001-12-21 | 25% | 195d | 2000-12-25 | 2001-12-21 | 260d | 422d | finish no earlier than 2001-12-21 | WG SA5 | 2080h | 520h | IMS-OAM | CCaR | 1303 | 32-series | Albert.Yuhan@voicestream.com; Michael.Truss@MOTOROLA.COM | TSG |  |
| 122 | 9.8 | (Copy) AMR-WB | 215d | 2000-09-04 A | 2001-06-29 | 95% | 10.75d | 2000-09-04 | 2001-06-29 | 215d | 547d | finish no earlier than 2001-06-29 | WG SA4 | 1720h | 1634h |  |  | 1598 |  |  |  |  |
| 123 | 9.9 | (copy) End-to-end QoS | 330d | 2000-12-25 A | 2002-03-29 | 38% | 205d |  |  |  | 352d | start no earlier than 2000-12-25 | WG SA2 | 2640h | 1000h |  |  |  |  |  |  |  |
| 124 | 9.10 | **Interworking between IMS and IP networks** | 400d | 2000-08-28 A | 2002-03-08 | 30% | 280d | 2000-08-28 | 2002-03-08 | 400d | 367d |  | WG CN3 | 6400h | 1920h | IMS-CCR-IWIP | BaAS | 2048 | 23.821, 29.061 and new TR29.162 | nigel.holland@bt.com | TSG |  |
| 125 | 9.10.1 | Impact on MM/CC/SM | 400d | 2000-08-28 A | 2002-03-08 | 30% | 280d | 2001-03-19 | 2001-12-21 | 200d | 367d | finish no earlier than 2002-03-08 | WG CN1 | 3200h | 960h | IMS-CCR-IWMM | CCaR | 1296 |  | drage@lucent.com |  |  |
| 126 | 9.11 | Interworking between IMS and CS networks | 397d | 2000-08-28 A | 2002-03-08 | 80% | 79.4d | 2000-07-24 | 2002-10-21 | 586d | 367d | finish no earlier than 2002-03-08 | WG CN4; WG CN3 | 4712h | 3640h | IMS-CCR-IWCS | CCaR | 1305 | 29.163, 29.061, 24.228 | dave.sanders@vf.vodafone.co.uk | TSG |  |
| 127 | 9.12 | SIP SS and realtionship to Mg, Mw, Cx | 265d | 2001-04-02 A | 2002-04-05 | 21% | 210d |  |  |  | 347d | start no earlier than 2001-04-02 | WG CN4 | 2120h | 440h |  |  |  |  |  |  |  |
| 128 | 9.13 | **Multimedia codecs and protocols for conversational PS services** | 438d | 2000-07-26 A | 2002-03-29 | 28% | 317.39d | 2000-07-26 | 2001-12-21 | 368d | 352d |  | WG SA4 | 8472h | 2332.87h | IMS-CODEC |  | 2036 | 26.235 |  | TSG |  |
| 129 | 9.13.1 | Codecs | 171d | 2000-07-26 A | 2001-03-21 A | 100% |  | 2000-07-26 | 2001-03-21 | 171d |  | finish no earlier than 2001-03-21 | WG SA4 | 1368h | 1368h |  |  | 2039 |  |  | TSG |  |
| 130 | 9.13.2 | performance characterisation of codec | 320d | 2000-10-02 | 2001-12-21 |  |  | 2000-10-02 | 2001-12-21 | 320d | 422d | finish no earlier than 2001-12-21 | WG SA4 | 2560h |  |  |  | 2040 |  |  | TSG |  |
| 131 | 9.13.3 | recommendation for QoS parameter values for various media types | 130d | 2001-10-01 | 2002-03-29 |  |  | 2000-10-02 | 2001-12-21 | 320d | 352d | start no earlier than 2001-10-01 | WG SA4 | 1040h |  |  |  | 2038 |  |  | TSG |  |

Notes:
- 111: Text4: Mark Cataldo, Motorola
- 112: Text4: Randolph Wohlert, SBC Technology Resources, Inc.
- 113: end March 2001 from tdoc AHR00-0031. 14/09/00: End date modified to 29 June 2001 (was 03/01). TR created 08/00; TR approval 12/00; TS draft 03/01 (distribution to other groups); TS approval 06/01. S3#17: Title corrected. S3#18: Timescales updated / Text4: Krister Boman, Ericsson
- 117: S3#18: Created in response to S2 request on Network Hiding / Text4: Hugh Shieh, AT&T Wireless Services
- 118: end March 2001 from tdoc AHR00-0031 / Text4: Berthold Wilhelm, Reg TP
- 120: az: WID appr.SA#10. / Text4: Karl-Heinz NENNER (T-Mobil)
- 121: az: WID appr.SA#13. / Text4: Albert YUHAN (VoiceStream Wireless), Michael TRUSS (Motorola)
- 124: [DAB - 01/12/01] - End date pushed back beyond March updated rapporteur details % complete to 30 / Text4: Nigel Holland, BT
- 125: Per 30/5: What is the status and new requirements for CN1? / Text4: Keith Drage, Lucent
- 126: [DAB - 01/12/01] - End date pushed back beyond March updated rapporteur details % complete to 80 / Text4: David Sanders, Vodafone
- 128: Text4: B. Aronson, Toshiba, and P. Ojala, Nokia

| ID | WBS | Task | Type | Duration | Start | Finish | Predecessors | Complete | Remaining | Baseline start | Baseline finish | Baseline duration | Total slack | Free slack | Constraint | Resources | Work | Actual work | Text1 | Text9 | Text2 | Text3 | Text4 | Text5 | Text7 |
| --- | --- | --- | --- | --- | --- | --- | --- | --- | --- | --- | --- | --- | --- | --- | --- | --- | --- | --- | --- | --- | --- | --- | --- | --- | --- |
| 132 | 9.14 | **SIP message compression** |  | 135d | 2001-09-24 A | 2002-03-29 |  | 16% | 113.37d |  |  |  | 352d |  |  | WG SA2 | 2328h | 373.07h |  |  |  |  |  |  |  |
| 133 | 9.14.1 | Stage 2 |  | 25d | 2001-09-24 A | 2001-10-26 A |  | 100% |  |  |  |  |  |  | finish no earlier than 2001-10-26 | WG SA2 | 200h | 200h |  |  |  |  |  |  |  |
| 134 | 9.14.2 | Compression signalling |  | 131d | 2001-09-28 | 2002-03-29 |  |  |  |  |  |  | 352d |  | finish no earlier than 2002-03-29 | WG CN1 | 1048h |  |  |  |  |  |  |  |  |
| 135 | 9.15 | IMS Local services |  | 325d | 2001-01-01 A | 2002-03-29 |  | 48% | 169d |  |  |  | 352d |  | finish no earlier than 2002-03-29 | WG SA2 | 2600h | 1248h |  |  |  |  |  |  |  |
| 136 | 9.16 | **Stage 3 description of IMS interfaces** |  | 511d | 2000-04-14 A | 2002-03-29 |  | 6% | 478.26d |  |  |  | 352d |  |  | TSG CN | 26111.6h | 272.46h |  |  |  |  |  |  |  |
| 137 | 9.16.1 | Cx interface (HSS to CSCF) |  | 483d | 2000-04-14 A | 2002-02-19 |  | 39% | 294.63d | 2000-04-14 | 2002-02-19 | 483d | 380d |  | finish no earlier than 2002-02-19 | WG CN4 | 2367.57h | 10.54h | IMS-CCR | 1286 |  |  |  |  |  |
| 138 | 9.16.2 | MC interface (IM-MGW to MGCF) enhancements |  | 273d | 2001-03-14 | 2002-03-29 |  |  |  |  |  |  | 352d |  | finish no earlier than 2002-03-29 | WG CN4 | 2184h |  |  |  |  |  |  |  |  |
| 139 | 9.16.3 | Mw interface (CSCF to P-CSCF) |  | 273d | 2001-03-14 | 2002-03-29 |  |  |  |  |  |  | 352d |  | start no earlier than 2001-03-14 | WG CN1 | 2184h |  |  |  |  |  |  |  |  |
| 140 | 9.16.4 | Mm interface (CSCF to external IP multimedia network) |  | 273d | 2001-03-14 | 2002-03-29 |  |  |  |  |  |  | 352d |  | start no earlier than 2001-03-14 | WG CN1 | 2184h |  |  |  |  |  |  |  |  |
| 141 | 9.16.5 | Mg interface (CSCF to MGCF - interworking with CS) |  | 273d | 2001-03-14 | 2002-03-29 |  |  |  |  |  |  | 352d |  | start no earlier than 2001-03-14 | WG CN4 | 2184h |  |  |  |  |  |  |  |  |
| 142 | 9.16.6 | Mr interface (CSCF to MRF) |  | 273d | 2001-03-14 | 2002-03-29 |  |  |  |  |  |  | 352d |  | start no earlier than 2001-03-14 | WG CN1 | 2184h |  |  |  |  |  |  |  |  |
| 143 | 9.16.7 | Dx interface (I-CSCF to SLF) |  | 273d | 2001-03-14 | 2002-03-29 |  |  |  |  |  |  | 352d |  | start no earlier than 2001-03-14 | WG CN4 | 2184h |  |  |  |  |  |  |  |  |
| 144 | 9.16.8 | ISC (IMS Service Control) Interface |  | 273d | 2001-03-14 | 2002-03-29 |  |  |  |  |  |  | 352d |  | start no earlier than 2001-03-14 | WG CN1 | 2184h |  |  |  |  |  |  |  |  |
| 145 | 9.16.9 | Sh interface (HSS to AS) |  | 273d | 2001-03-14 | 2002-03-29 |  |  |  |  |  |  | 352d |  | start no earlier than 2001-03-14 | WG CN4 | 2184h |  |  |  |  |  |  |  |  |
| 146 | 9.16.10 | Gm interface (UE to CSCF) |  | 273d | 2001-03-14 | 2002-03-29 |  |  |  |  |  |  | 352d |  | start no earlier than 2001-03-14 | WG CN1 | 2184h |  |  |  |  |  |  |  |  |
| 147 | 9.17 | Support of VHE/OSA by entities and protocols of the IMS (e.g. CSCF) |  | 136d | 2001-09-21 A | 2002-03-29 |  | 4% | 130.56d | 2000-08-14 | 2001-03-23 | 160d | 352d |  | finish no earlier than 2002-03-29 | WG CN5 | 1088h | 43.52h | IMS-ONOSA | 1310 | CCaR | 29.198, 29.998 | Ard-Jan MOERDIJK (Ericsson L.M.) | Ard.Jan.Moerdijk@eln.ericsson.se | TSG |
| 148 | 9.18 | **Support of CAMEL by the IMS** |  | 353d | 2000-11-15 | 2002-03-22 |  |  |  | 2001-03-14 | 2001-12-24 | 204d | 357d |  |  | WG CN2 | 7608h |  | IMS-CAMEL | 1310 | CCaR |  |  |  |  |
| 149 | 9.18.1 | General issues |  | 245d | 2001-04-16 | 2002-03-22 |  |  |  |  |  |  | 357d |  | start no earlier than 2001-04-16 | WG CN2 | 1960h |  |  |  |  |  |  |  |  |
| 150 | 9.18.2 | SDM issues for CAMEL control of IMS |  | 353d | 2000-11-15 | 2002-03-22 |  |  |  |  |  |  | 357d |  | finish no earlier than 2002-03-22 | WG CN4 | 2824h |  |  |  |  |  |  |  |  |
| 151 | 9.19 | Pre-pay/real-time charging in IMS |  | 196d | 2001-06-15 | 2002-03-15 |  |  |  | 2001-06-15 | 2002-03-15 | 196d | 362d |  | finish no earlier than 2002-03-15 | WG SA1 | 1568h |  |  |  |  |  |  |  |  |
| 152 | 9.20 | **Charging** |  | 205d | 2001-08-06 A | 2002-05-17 |  | 20% | 165d |  |  |  | 317d |  |  | WG SA5 | 3280h | 640h |  |  |  |  |  |  |  |
| 153 | 9.20.1 | Charging Implications of IMS architecture |  | 75d | 2001-08-06 A | 2001-11-16 |  | 53% | 35d |  |  |  | 317d | 0d | start no earlier than 2001-08-06 | WG SA2 | 600h | 320h |  |  |  |  |  |  |  |
| 154 | 9.20.2 | Charging management for IMS |  | 130d | 2001-11-19 | 2002-05-17 | 153 |  |  |  |  |  | 317d |  |  | WG SA5 | 1040h |  |  |  |  |  |  |  |  |
| 155 | 9.21 | **Other IETF depencies** |  | 346d | 2000-11-24 | 2002-03-22 |  |  |  |  |  |  | 357d |  |  | TSG CN | 22144h |  |  |  |  |  |  |  |  |
| 156 | 9.21.1 | IETF: draft-ietf-sip-session-timer |  | 346d | 2000-11-24 | 2002-03-22 |  |  |  |  |  |  | 357d |  | finish no earlier than 2002-03-22 | TSG CN | 2768h |  |  |  |  |  |  |  |  |
| 157 | 9.21.2 | IETF: draft-agrawal-sip-h323-interwrkng-reqs |  | 346d | 2000-11-24 | 2002-03-22 |  |  |  |  |  |  | 357d |  | finish no earlier than 2002-03-22 | TSG CN | 2768h |  |  |  |  |  |  |  |  |
| 158 | 9.21.3 | IETF: draft-ietf-sip-callerprefs |  | 346d | 2000-11-24 | 2002-03-22 |  |  |  |  |  |  | 357d |  | finish no earlier than 2002-03-22 | TSG CN | 2768h |  |  |  |  |  |  |  |  |
| 159 | 9.21.4 | IETF: draft-ietf-sip-state |  | 346d | 2000-11-24 | 2002-03-22 |  |  |  |  |  |  | 357d |  | finish no earlier than 2002-03-22 | TSG CN | 2768h |  |  |  |  |  |  |  |  |
| 160 | 9.21.5 | IETF: draft-ietf-aaa-diameter |  | 346d | 2000-11-24 | 2002-03-22 |  |  |  |  |  |  | 357d |  | finish no earlier than 2002-03-22 | TSG CN | 2768h |  |  |  |  |  |  |  |  |
| 161 | 9.21.6 | IETF: draft-ietf-sip-isup |  | 346d | 2000-11-24 | 2002-03-22 |  |  |  |  |  |  | 357d |  | finish no earlier than 2002-03-22 | TSG CN | 2768h |  |  |  |  |  |  |  |  |
| 162 | 9.21.7 | IETF: draft-ietf-sip-isup-header |  | 346d | 2000-11-24 | 2002-03-22 |  |  |  |  |  |  | 357d |  | finish no earlier than 2002-03-22 | TSG CN | 2768h |  |  |  |  |  |  |  |  |
| 163 | 9.22 | Start Testing | milestone | 0d | 2002-03-18 | 2002-03-18 |  |  |  | 2001-12-14 | 2001-12-14 | 0d | 157d | 0d | start no earlier than 2002-03-18 | MLST |  |  |  | 1913 |  |  |  |  |  |
| 164 | 9.23 | Conformance Test Aspects - Provisioning of IMS |  | 205d | 2002-03-18 | 2002-12-27 | 163 |  |  | 2001-12-14 | 2002-05-16 | 110d | 157d |  |  | WG T1 | 1640h |  | IMS-TEST | 1844 |  |  |  |  |  |

Notes:
- 147: az: Created post-CN#13
- 148: Introduced by A. Sultan to reflect actual studies of S2
- 155: Was introduced at SA#13 by Ileana Leuca (exact position in the WP and related WG have to be defined)

| ID | WBS | Task | Type | Duration | Start | Finish | Predecessors | Complete | Remaining | Baseline start | Baseline finish | Baseline duration | Total slack | Free slack | Constraint | Resources | Work | Actual work | Text1 | Text3 | Text4 | Text5 | Text6 | Text7 | Text8 | Text2 | Text9 |
| --- | --- | --- | --- | --- | --- | --- | --- | --- | --- | --- | --- | --- | --- | --- | --- | --- | --- | --- | --- | --- | --- | --- | --- | --- | --- | --- | --- |
| 165 | 10 | **Extended Transparent End-to-End PS Streaming Service** |  | 202d | 2001-06-18 A | 2002-03-26 |  | 8% | 185.72d | 2001-06-18 | 2002-03-26 | 202d | 355d |  |  | WG SA4 | 3776h | 304.29h | PSS-E | 26.233, 26.234 | O. Franceschi, Ericsson | olle.franceschi@nrj.ericsson.se | Rel5 | TSG | Paolo |  |  |
| 166 | 10.1 | Stage 1 |  | 71d | 2001-06-21 A | 2001-09-27 |  | 31% | 49d | 2001-06-21 | 2001-09-27 | 71d | 483d |  | finish no earlier than 2001-09-27 | WG SA1 | 568h | 176h |  |  |  |  |  | TSG |  |  |  |
| 167 | 10.2 | Stage 2 |  | 202d | 2001-06-18 | 2002-03-26 |  |  |  | 2001-06-18 | 2002-03-26 | 202d | 355d |  | start no earlier than 2001-06-18 | WG SA4 | 1616h |  |  |  |  |  |  | TSG |  |  |  |
| 168 | 11 | **Emergency call enhancements** |  | 500d | 2000-05-01 A | 2002-03-29 |  | 18% | 409.44d | 2000-05-01 | 2002-04-02 | 502d | 352d |  |  | WG CN1 | 21640h | 3548.83h | EMC1 |  | Mr Rouzbeh, Ericsson | EUSFARO@am1.ericsson.se | NA | WG | Per | CCaR | 1652 |
| 169 | 11.1 | **For IP & PS based calls** |  | 410d | 2000-08-14 A | 2002-03-08 |  | 14% | 350.95d | 2000-08-14 | 2002-04-02 | 427d | 367d |  |  | WG CN1 | 14112h | 2032.38h | EMC1-PS |  | Mr Rouzbeh, Ericsson | EUSFARO@am1.ericsson.se | Rel5 | TSG |  | CCaR | 1653 |
| 170 | 11.1.1 | Service Requirements for IP-based emergency calls |  | 205d | 2000-09-18 A | 2001-06-29 |  | 44% | 115d | 2000-09-18 | 2001-06-29 | 205d | 547d |  | start no earlier than 2000-09-18 | WG SA1 | 1640h | 720h | EMC1-PS | 22.976 |  |  |  |  |  | CCaR | 1314 |
| 171 | 11.1.2 | SIP emergency calls and packet emergency calls signalling flowsl |  | 364d | 2000-10-17 | 2002-03-08 |  |  |  | 2000-10-17 | 2001-12-28 | 314d | 367d |  | finish no earlier than 2002-03-08 | WG CN1 | 2912h |  | EMC1-PS | TS 24.228 | Mr Rouzbeh, Ericsson | EUSFARO@am1.ericsson.se |  |  |  | CCaR | 1315 |
| 172 | 11.1.3 | Stage 2 for emergency calls and packet emergency calls in general |  | 175d | 2000-10-02 A | 2001-06-01 |  | 60% | 70d | 2000-10-02 | 2001-06-01 | 175d | 367d | 0d | finish no earlier than 2001-06-01 | WG SA2 | 1400h | 840h | EMC1-PS |  |  |  |  |  |  | CCaR | 1316 |
| 173 | 11.1.4 | Distinction of emergency call types to different emergency services |  | 200d | 2001-06-04 | 2002-03-08 | 172 |  |  | 2001-06-04 | 2002-04-02 | 217d | 367d |  | finish no earlier than 2002-03-08 | WG CN1 | 1600h |  | EMC1-PS |  |  |  |  |  |  | CCaR | 1317 |
| 174 | 11.1.5 | Stage 3 for emergency calls and packet emergency calls in general |  | 410d | 2000-08-14 | 2002-03-08 |  |  |  | 2000-08-14 | 2001-12-28 | 360d | 367d |  | finish no earlier than 2002-03-08 | WG CN1 | 3280h |  | EMC1-PS | TS 24.229 | Rouzbeh Farhoumand, Ericsson | rouzbeh.farhoumand@ericsson.com |  |  |  | CCaR | 1646 |
| 175 | 11.2 | **For CS based calls** |  | 107d | 2000-05-01 A | 2000-09-26 A |  | 100% |  | 2000-05-01 | 2000-09-26 | 107d |  |  |  | WG CN1 | 792h | 792h | EMC1-CS |  | Mr Rouzbeh, Ericsson | EUSFARO@am1.ericsson.se | Rel4 | TSG |  | CCaR | 1654 |
| 176 | 11.2.1 | Distinction in CS domain of emergency call types to different emergency services |  | 40d | 2000-05-01 A | 2000-06-23 A |  | 100% |  | 2000-05-01 | 2000-06-23 | 40d |  |  | finish no earlier than 2000-06-23 | WG SA1 | 320h | 320h | EMC1-CS |  |  |  |  |  |  | CCaR | 1320 |
| 177 | 11.2.2 | Distinction in CS domain of emergency calls to different emergency types |  | 22d | 2000-08-28 A | 2000-09-26 A |  | 100% |  | 2000-08-28 | 2000-09-26 | 22d |  |  | finish no earlier than 2000-09-22 | WG CN1 | 176h | 176h | EMC1-CS |  |  |  |  |  |  |  | 1999 |
| 178 | 11.3 | **Conformance Test Aspects - Emergency call enhancements** |  | 339d | 2000-12-12 | 2002-03-29 |  |  |  | 2000-12-12 | 2002-03-29 | 339d | 352d |  |  | WG T1 | 2736h |  |  |  |  |  |  |  |  |  | 2224 |
| 179 | 11.3.1 | Testing Stage 3 for emergency calls and packet emergency calls in general |  | 1d | 2000-12-12 | 2000-12-12 |  |  |  | 2000-12-12 | 2000-12-12 | 1d | 690d |  | finish no earlier than 2000-12-12 | WG T1 | 8h |  |  |  |  |  |  |  |  |  | 2225 |
| 180 | 11.3.2 | Testing CS based emergency calls |  | 1d | 2001-12-28 | 2001-12-28 |  |  |  | 2001-12-28 | 2001-12-28 | 1d | 417d |  | finish no earlier than 2001-12-28 | WG T1 | 8h |  | EMC1-CS | 34.123-1 |  |  |  | TSG |  |  | 2226 |
| 181 | 11.3.3 | Testing CS based emergency calls - TTCN |  | 1d | 2002-03-29 | 2002-03-29 |  |  |  | 2002-03-29 | 2002-03-29 | 1d | 352d |  | finish no earlier than 2002-03-29 | WG T1 | 8h |  | EMC1-CS | 34.123-3 |  |  |  |  |  |  |  |
| 182 | 12 | **Global Text Telephony** |  | 378d | 2000-06-28 A | 2001-12-07 |  | 82% | 67.78d | 2000-06-28 | 2001-12-07 | 378d | 432d |  |  | WG SA2 | 8472h | 7147.97h | GTT |  | Gunnar Hellström, Ericsson | gunnar.hellstrom@omnitor.se | Rel5 | TSG | Alain |  |  |
| 183 | 12.1 | Stage 1 |  | 188d | 2000-06-28 A | 2001-03-16 A |  | 100% |  | 2000-06-28 | 2001-03-16 | 188d |  |  | finish no earlier than 2000-12-22 | WG SA1 | 1504h | 1504h | GTT | 22.976, 22.226 |  |  |  | TSG |  |  | 1634 |
| 184 | 12.2 | Stage 2 |  | 205d | 2000-09-11 A | 2001-06-22 A |  | 100% |  | 2000-09-11 | 2001-06-22 | 205d |  |  |  | WG SA2 | 1640h | 1640h | GTT | 23.226 |  |  |  | TSG |  |  |  |
| 185 | 12.3 | **Specification of Cellular Text telephone Modem** |  | 136d | 2000-09-11 A | 2001-03-19 A |  | 100% |  | 2000-09-11 | 2001-03-19 | 136d |  |  |  | WG SA4 | 2704h | 2704h | GTT-CTM |  |  |  |  |  |  |  | 2234 |
| 186 | 12.3.1 | General description and C-code |  | 66d | 2000-09-11 A | 2000-12-11 A |  | 100% |  | 2000-09-11 | 2000-12-11 | 66d |  |  | finish no earlier than 2000-12-11 | WG SA4 | 528h | 528h | GTT-CTM | 26.226, 26.230 |  |  |  |  |  |  | 2238 |
| 187 | 12.3.2 | Minimum Performance requirements |  | 136d | 2000-09-11 A | 2001-03-19 A |  | 100% |  | 2000-09-11 | 2001-03-19 | 136d |  |  | finish no earlier than 2001-03-19 | WG SA4 | 1088h | 1088h | GTT-CTM | 26.231 |  |  |  |  |  |  | 2237 |
| 188 | 12.4 | Start Testing | milestone | 0d | 2001-06-11 | 2001-06-11 |  |  |  | 2001-06-11 | 2001-06-11 | 0d | 562d |  | finish no earlier than 2001-06-11 | MLST |  |  | GTT |  |  |  |  |  |  |  |  |
| 189 | 12.5 | Conformance Test Aspects - Global Text telephony |  | 130d | 2001-06-11 | 2001-12-07 |  |  |  | 2001-06-11 | 2001-12-07 | 130d | 432d |  | start no earlier than 2001-06-11 | WG T1 | 1040h |  | GTT | 34.125 |  |  |  |  |  |  |  |

Notes:
- 166: 2nd resp SA4
- 167: 2nd resp SA2
- 171: no new spec will be presented, will be covered in CN1 spec24.228
- 172: covered by TS 23.228
- 174: Potentially sub contracted to IETF / covered by TS 24.229
- 175: WI approved in TSG_10 / CN1#15: ID 2101 REMOVE-Emergency call recalling capability enhancement, no contributions
- 177: Calls to different emergency services such as ambulance, fire brigade, police, etc. can be routed to respective different emergency centres. / NP-000447 is the stage 3 changes for CS call control protocol.
- 182: SP-000162 agreed WI. Rapporteur / Gunnar Hellström, Ericsson Radio Systems AB, / email: gunnar.hellstrom@omnitor.se tel: +46 708 204 288
- 189: Bearer services, new spec document?

| ID | WBS | Task | Duration | Start | Finish | Predecessors | Complete | Remaining | Baseline start | Baseline finish | Baseline duration | Total slack | Free slack | Constraint | Resources | Work | Actual work | Text1 | Text4 | Text6 | Text7 | Text8 | Text9 | Text3 | Text2 | Text5 |
| --- | --- | --- | --- | --- | --- | --- | --- | --- | --- | --- | --- | --- | --- | --- | --- | --- | --- | --- | --- | --- | --- | --- | --- | --- | --- | --- |
| 190 | 13 | **VHE enhancements** | 517d | 2000-10-05 A | 2002-09-27 |  | 30% | 362.74d | 2000-08-07 | 2002-11-08 | 590d | 222d |  |  | WG SA1 | 11616h | 3374.07h | VHE1 | Jumoke Ogunbekun, Fujitsu Europe | NA | TSG | Alain | 1367 |  |  |  |
| 191 | 13.1 | Global Stage 1 for VHE Enhancements | 75d | 2000-10-05 A | 2001-01-17 A |  | 100% |  | 2000-10-05 | 2001-01-17 | 75d |  |  | start no earlier than 2000-10-05 | WG SA1 | 600h | 600h | VHE1 |  |  | TSG |  | 11001 | 22.121 |  |  |
| 192 | 13.2 | **Extensions to OSA to support VHE** | 195d | 2001-07-02 A | 2002-03-29 |  | 38% | 120.69d | 2001-04-02 | 2002-02-05 | 222d | 352d |  |  | WG SA2 | 2640h | 1006.08h | VHE1-TLKT1 |  | Rel5 | WG |  | 2104 |  |  |  |
| 193 | 13.2.1 | Overall Stage 2 | 80d | 2001-09-24 A | 2002-01-11 |  | 31% | 55.2d | 2001-04-02 | 2001-06-29 | 65d | 407d |  | finish no earlier than 2002-01-11 | WG SA2 | 640h | 198.4h | VHE1-TLKT1 |  |  | WG |  | 2106 |  | CCaR |  |
| 194 | 13.2.2 | Detailed Stage2 and Stage 3 | 195d | 2001-07-02 A | 2002-03-29 |  | 41% | 115d | 2001-07-02 | 2002-02-05 | 157d | 352d |  | start no earlier than 2001-07-02 | WG CN5 | 1560h | 640h | VHE1-TLKT1 |  |  | WG |  | 2107 |  | CCaR |  |
| 195 | 13.3 | **Detailed definition of the VHE user profile** | 266d | 2001-09-21 A | 2002-09-27 |  | 19% | 216.69d | 2000-08-07 | 2002-11-08 | 590d | 222d |  |  | WG SA2 | 3984h | 738.61h | VHE1-USERP |  | Rel6 | WG |  | 1368 |  | CCaR |  |
| 196 | 13.3.1 | Stage 2 | 220d | 2001-11-26 | 2002-09-27 |  |  |  | 2000-08-07 | 2001-07-06 | 240d | 222d |  | finish no earlier than 2002-09-27 | WG SA2 | 1760h |  | VHE1-USERP |  |  | WG |  | 1404 |  | CCaR |  |
| 197 | 13.3.2 | Enhanced Subscription Management & User Profile | 136d | 2001-09-21 A | 2002-03-29 |  | 49% | 70d | 2002-01-21 | 2002-11-08 | 210d | 352d |  | finish no earlier than 2002-03-29 | WG SA5 | 1088h | 528h | VHE1-USERP | Geoffrey CARYER (BT) | Rel5 | TSG |  | 2123 |  | Ser | Geoff.Caryer@BTINTERNET.COM |
| 198 | 13.4 | (copy) OSA Stage 3 | 136d | 2001-09-21 A | 2002-03-29 |  | 4% | 130.56d |  |  |  | 352d |  | finish no earlier than 2002-03-29 | WG CN5 | 1088h | 43.52h | OSA1 | Ard-Jan MOERDIJK (Ericsson L.M.) | Rel5 | WG |  |  | 29.198, 29.998 |  | Ard.Jan.Moerdijk@eln.ericsson.se |
| 199 | 14 | **OSA enhancements** | 458d | 2000-06-28 A | 2002-03-29 |  | 31% | 316.19d | 2000-06-28 | 2001-12-21 | 388d | 352d |  |  | WG SA1 | 40744h | 12279h | OSA1 | Jörg Swetina, SIEMENS AG | NA | TSG | Adrian Z | 1637 | 22.127, 23.127, 29.198-x, 29.998-x |  |  |
| 200 | 14.1 | General Stage 2 for Rel4 | 171d | 2000-08-03 A | 2001-03-29 A |  | 100% |  | 2000-08-03 | 2001-03-29 | 171d |  |  | finish no earlier than 2001-03-29 | WG SA2 | 1368h | 1368h | OSA1 | Christophe GOURRAUD, Ericsson Canada |  | TSG |  | 2120 | 23.127 |  |  |
| 201 | 14.2 | **Interactions OSA - e-commerce** | 405d | 2000-09-11 A | 2002-03-29 |  | 42% | 235.69d | 2000-09-11 | 2001-03-30 | 145d | 352d |  |  | WG SA2 | 2880h | 1879.04h | OSA1-ECOM |  | Rel5 | TSG |  | 1424 |  |  |  |
| 202 | 14.2.1 | Stage 1 | 79d | 2000-09-11 A | 2000-12-28 A |  | 100% |  | 2000-09-11 | 2000-12-28 | 79d |  |  | finish no earlier than 2000-12-28 | WG SA1 | 632h | 632h | OSA1-ECOM | Jörg Swetina, SIEMENS AG |  | TSG |  | 1425 | 22.127 |  |  |
| 203 | 14.2.2 | Stages 2 and 3 | 136d | 2001-09-21 A | 2002-03-29 | 202 | 8% | 125.12d | 2000-12-29 | 2001-03-30 | 66d | 352d |  | finish no earlier than 2001-03-30 | WG CN5 | 1088h | 87.04h | OSA1-ECOM | Ard-Jan MOERDIJK (Ericsson L.M.) |  | TSG |  | 1529 | 29.198, 29.998 |  | Ard.Jan.Moerdijk@eln.ericsson.se |
| 204 | 14.3 | **OSA APIs for MuMa CC** | 449d | 2000-07-11 A | 2002-03-29 |  | 21% | 356.85d | 2000-07-11 | 2001-04-06 | 194d | 352d |  |  | WG SA2 | 5616h | 1152.58h | OSA1-CSCF |  | Rel5 | TSG |  | 1429 |  |  |  |
| 205 | 14.3.1 | Stage 1 | 166d | 2000-07-11 A | 2001-02-27 |  | 31% | 114.9d | 2000-07-11 | 2001-02-27 | 166d | 635d |  | finish no earlier than 2000-12-27 | WG SA1 | 1328h | 408.8h | OSA1-CSCF | Manfred Leitgeb, SIEMENS AG |  | TSG | Michael Clayton | 1430 | 22.127 | Ser | Manfred.leitgeb@siemens.at |
| 206 | 14.3.2 | Stages 2 and 3 | 136d | 2001-09-21 A | 2002-03-29 |  | 8% | 125.12d | 2000-09-25 | 2001-04-06 | 140d | 352d |  | finish no earlier than 2001-04-06 | WG CN5 | 1088h | 87.04h | OSA1-CSCF | Ard-Jan MOERDIJK (Ericsson L.M.) |  | TSG |  | 1530 | 29.198, 29.998 |  | Ard.Jan.Moerdijk@eln.ericsson.se |
| 207 | 14.4 | **OSA security** | 458d | 2000-06-28 A | 2002-03-29 |  | 29% | 326.46d | 2000-06-28 | 2001-09-03 | 309d | 352d |  |  | WG SA3 | 10328h | 2966.23h | OSA1-SEC | Colin Blanchard, BT | Rel5 | TSG |  | 1419 |  | Ser | colin.blanchard@bt.com |
| 208 | 14.4.1 | Stage 1 | 300d | 2000-07-11 A | 2001-09-03 |  | 8% | 276d | 2000-07-11 | 2001-09-03 | 300d | 501d |  | finish no earlier than 2000-12-27 | WG SA1 | 2400h | 192h | OSA1-SEC | Manfred Leitgeb, SIEMENS AG |  | TSG | Michael Clayton | 2121 | 22.127 |  | Manfred.leitgeb@siemens.at |
| 209 | 14.4.2 | Stage 2 | 53d | 2000-06-28 A | 2000-09-08 |  | 80% | 10.6d | 2000-06-28 | 2000-09-08 | 53d | 626.44d | 0d | finish no earlier than 2000-09-08 | WG SA2 | 424h | 339.2h | OSA1-SEC | Christophe GOURRAUD, Ericsson Canada |  | TSG |  | 1420 | 23.127 | Ser |  |
| 210 | 14.4.3 | Stage 3 | 210d | 2000-10-23 A | 2001-08-10 | 209 | 60% | 84d | 2000-10-23 | 2001-08-10 | 210d | 517d |  | finish no earlier than 2001-08-10 | WG SA3 | 1680h | 1008h | OSA1-SEC |  |  | TSG |  | 1421 | ??? | Ser |  |
| 211 | 14.4.4 | security related SCF(s) definition | 136d | 2001-09-21 A | 2002-03-29 | 209 | 4% | 130.56d | 2001-01-08 | 2001-04-12 | 69d | 352d |  | finish no earlier than 2001-04-12 | WG CN5 | 1088h | 43.52h | OSA1-SEC | Ard-Jan MOERDIJK (Ericsson L.M.) |  | TSG |  | 1422 | 29.198, 29.998 | Ser | Ard.Jan.Moerdijk@eln.ericsson.se |
| 212 | 14.4.5 | (possibly) changes required from supporting platforms, e.g. gsmSCF, HLR | 69d | 2000-09-11 A | 2000-12-14 | 209 | 60% | 27.6d | 2000-09-11 | 2000-12-14 | 69d | 688d |  | finish no earlier than 2000-12-14 | WG SA3 | 552h | 331.2h | OSA1-SEC |  |  | TSG |  | 1423 | ??? | Ser |  |
| 213 | 14.4.6 | impact on terminal | 65d | 2001-04-02 | 2001-06-29 |  |  |  | 2001-04-02 | 2001-06-29 | 65d | 547d |  | start no earlier than 2001-04-02 | WG T2 | 520h |  | OSA1-SEC |  |  | TSG |  | 1621 | ??? | Ser |  |

Notes:
- 194: SCFs for user profile access/management by OSA applications
- 197: az: WID appr.SA#10.
- 198: az: CN#13 - Link to new WID
- 199: az: deleted comment
- 201: az: CN#13 - changed to Rel5
- 203: az: Created post-CN#13
- 204: For Rel5 even if completed by March
- 206: az: Created post-CN#13
- 207: Christophe to contact BT and Ericsonn in S3 and S1
- 210: S3#15, Sep , Decision if implementation is to be standardised and how much re-use can be made. S3#17: No progress in S3 - seems to be behind schedule
- 211: az: Created post-CN#13

| ID | WBS | Task | Duration | Start | Finish | Predecessors | Complete | Remaining | Baseline start | Baseline finish | Baseline duration | Total slack | Constraint | Resources | Work | Actual work | Text1 | Text2 | Text6 | Text7 | Text9 | Text3 | Text4 | Text5 | Text8 |
| --- | --- | --- | --- | --- | --- | --- | --- | --- | --- | --- | --- | --- | --- | --- | --- | --- | --- | --- | --- | --- | --- | --- | --- | --- | --- |
| 214 | 14.5 | **Retrieval of Terminal capabilities** | 395d | 2000-09-25 A | 2002-03-29 |  | 45% | 215.9d | 2000-09-25 | 2001-11-30 | 310d | 352d |  | WG SA2 | 5256h | 2383.17h | OSA1-TC | Ser | Rel5 | TSG | 1433 |  |  |  |  |
| 215 | 14.5.1 | Stage 1 | 78d | 2000-09-25 A | 2001-01-10 A |  | 100% |  | 2000-09-25 | 2001-01-10 | 78d |  | finish no earlier than 2001-01-10 | WG SA1 | 624h | 624h | OSA1-TC | Ser |  | TSG | 1434 | 22.127 | Jörg Swetina, SIEMENS AG |  |  |
| 216 | 14.5.2 | Stages 2 and 3 | 136d | 2001-09-21 A | 2002-03-29 | 215 | 8% | 125.12d | 2001-01-11 | 2001-04-17 | 69d | 352d | finish no earlier than 2001-04-17 | WG CN5 | 1088h | 87.04h | OSA1-TC | Ser |  | TSG | 1436 | 29.198, 29.998 | Ard-Jan MOERDIJK (Ericsson L.M.) | Ard.Jan.Moerdijk@eln.ericsson.se |  |
| 217 | 14.5.3 | Provisionning of the terminal capabilities | 175d | 2001-04-02 A | 2001-11-30 |  | 50% | 87.5d | 2001-04-02 | 2001-11-30 | 175d | 437d | finish no earlier than 2001-11-30 | WG T2 | 1400h | 700h | OSA1-TC |  |  | TSG | 2122 | 23.057 |  |  |  |
| 218 | 14.6 | **LCS - OSA interfaces** | 405d | 2000-09-11 A | 2002-03-29 |  | 35% | 261.77d | 2000-09-11 | 2001-03-30 | 145d | 352d |  | WG SA1 | 4856h | 1145.92h | OSA1-LCSI | Ser | Rel5 | TSG | 1786 |  | Jörg Swetina, SIEMENS AG |  |  |
| 219 | 14.6.1 | Stage 1 | 65d | 2000-09-11 A | 2000-12-08 A |  | 100% |  | 2000-09-11 | 2000-12-08 | 65d |  | finish no earlier than 2000-12-08 | WG SA1 | 520h | 520h | OSA1-LCSI | Ser |  | TSG | 1787 | 22.127 | Jörg Swetina, SIEMENS AG |  |  |
| 220 | 14.6.2 | Stage 2 | 1d | 2000-12-11 A | 2000-12-11 A | 219 | 100% |  | 2000-12-11 | 2000-12-11 | 1d |  | finish no earlier than 2000-12-11 | WG SA2 | 8h | 8h | OSA1-LCSI |  |  | TSG | 2124 | 23.127 | Christophe GOURRAUD, Ericsson Canada |  |  |
| 221 | 14.6.3 | Stage 3 | 136d | 2001-09-21 A | 2002-03-29 | 220 | 4% | 130.56d | 2001-01-15 | 2001-03-30 | 55d | 352d | finish no earlier than 2001-03-30 | WG CN5 | 1088h | 43.52h | OSA1-LCSI | Ser |  | TSG | 1788 | 29.198, 29.998 | Ard-Jan MOERDIJK (Ericsson L.M.) | Ard.Jan.Moerdijk@eln.ericsson.se |  |
| 222 | 14.7 | **Interaction with Rel-5 features** | 131d | 2001-05-11 | 2001-11-09 |  |  |  | 2001-05-11 | 2001-11-09 | 131d | 452d |  | WG SA1 | 4192h |  |  |  | Rel5 | TSG |  |  |  |  |  |
| 223 | 14.7.1 | Access to Presence information | 131d | 2001-05-11 | 2001-11-09 |  |  |  | 2001-05-11 | 2001-11-09 | 131d | 452d | finish no earlier than 2001-11-09 | WG SA1 | 1048h |  | OSA1-PI |  |  | TSG |  |  |  |  |  |
| 224 | 14.7.2 | Access to User Profile | 131d | 2001-05-11 | 2001-11-09 |  |  |  | 2001-05-11 | 2001-11-09 | 131d | 452d | finish no earlier than 2001-11-09 | WG SA1 | 1048h |  | OSA1-UP |  |  | TSG |  |  |  |  |  |
| 225 | 14.7.3 | Policy Management | 131d | 2001-05-11 | 2001-11-09 |  |  |  | 2001-05-11 | 2001-11-09 | 131d | 452d | finish no earlier than 2001-11-09 | WG SA1 | 1048h |  | OSA1-PM |  |  | TSG |  |  |  |  |  |
| 226 | 14.8 | **OSA Stage 3** | 136d | 2001-09-21 A | 2002-03-29 |  | 10% | 122.4d | 2001-05-24 | 2001-12-21 | 152d | 352d |  | WG CN5 | 2176h | 169.6h | OSA1 |  | Rel5 | TSG |  | 29.198, 29.998 | Ard-Jan MOERDIJK (Ericsson L.M.) | Ard.Jan.Moerdijk@eln.ericsson.se | Adrian Z |
| 227 | 14.8.1 | OSA evolution - Stages 2 and 3 | 136d | 2001-09-21 A | 2002-03-29 |  | 10% | 122.4d |  |  |  | 352d | finish no earlier than 2002-03-29 | WG CN5 | 1088h | 108.8h | OSA1 |  | Rel5 | TSG |  | 29.198, 29.998 | Ard-Jan MOERDIJK (Ericsson L.M.) | Ard.Jan.Moerdijk@eln.ericsson.se |  |
| 228 | 14.9 | General Stage 2 for Rel5 | 51d | 2001-10-12 A | 2001-12-31 |  | 20% | 41d | 2000-12-25 | 2001-03-30 | 70d | 416d | finish no earlier than 2001-12-31 | WG SA2 | 408h | 80h |  |  |  |  | 2116 |  |  |  |  |
| 229 | 15 | **CAMEL phase 4** | 570d | 2000-01-03 A | 2002-03-08 |  | 57% | 243.1d | 2000-01-03 | 2001-12-21 | 515d | 367d |  | WG SA1 | 39144h | 20318.2h | CAMEL4 |  | Rel5 | WG | 1638 |  | Keijo Palviainen, Nokia | keijo.palviainen@nokia.com | Andijana |
| 230 | 15.1 | Service requirements | 310d | 2000-04-17 A | 2001-06-22 |  | 79% | 65.1d | 2000-04-17 | 2001-06-22 | 310d | 552d | finish no earlier than 2001-06-22 | WG SA1 | 2480h | 1959.2h | CAMEL4 | Ser |  | WG | 1461 |  |  |  |  |
| 231 | 15.2 | Charging notification to the CSE | 570d | 2000-01-03 A | 2002-03-08 |  | 20% | 456d | 2000-01-03 | 2001-12-20 | 514d | 367d | finish no earlier than 2002-03-08 | WG CN2 | 4560h | 912h | CAMEL4-CNCNE | Ser |  | WG | 2011 |  |  |  |  |
| 232 | 15.3 | Call Party Handling | 435d | 2000-07-10 A | 2002-03-08 |  | 71% | 126.15d | 2000-07-10 | 2001-12-20 | 379d | 367d | finish no earlier than 2002-03-08 | WG CN2 | 3480h | 2470.8h | CAMEL4-CPH | Ser |  | WG | 2012 |  |  |  |  |
| 233 | 15.4 | Mid call procedure for MO and MT calls | 430d | 2000-07-17 A | 2002-03-08 |  | 60% | 172d | 2000-07-17 | 2001-12-20 | 374d | 367d | finish no earlier than 2002-03-08 | WG CN2 | 3440h | 2064h | CAMEL4-MCP | Ser |  | WG | 2013 |  |  |  |  |
| 234 | 15.5 | Interactions with Optimal Routing | 430d | 2000-07-17 A | 2002-03-08 |  | 95% | 21.5d | 2000-07-17 | 2001-12-20 | 374d | 367d | finish no earlier than 2002-03-08 | WG CN2 | 3440h | 3268h | CAMEL4-IOR | Ser |  | WG | 2014 |  |  |  |  |
| 235 | 15.6 | Inclusion of flexible tone injection | 430d | 2000-07-17 A | 2002-03-08 |  | 95% | 21.5d | 2000-07-17 | 2001-12-20 | 374d | 367d | finish no earlier than 2002-03-08 | WG CN2 | 3440h | 3268h | CAMEL4-IFTI | Ser |  | WG | 2015 |  |  |  |  |
| 236 | 15.7 | CSE control over MT SMS | 430d | 2000-07-17 A | 2002-03-08 |  | 71% | 124.7d | 2000-07-17 | 2001-12-20 | 374d | 367d | finish no earlier than 2002-03-08 | WG CN2 | 3440h | 2442.4h | CAMEL4-CCSMS | Ser |  | WG | 2016 |  |  |  |  |
| 237 | 15.8 | Notification of GPRS mobility management to CSE | 266d | 2001-03-02 A | 2002-03-08 |  | 48% | 138.32d | 2001-03-02 | 2001-12-20 | 210d | 367d | finish no earlier than 2002-03-08 | WG CN2 | 2128h | 1021.44h | CAMEL4-NMM |  |  | WG | 2460 |  |  |  |  |
| 238 | 15.9 | Enhancement of dialled services | 266d | 2001-03-02 A | 2002-03-08 |  | 10% | 239.4d | 2001-03-02 | 2001-12-20 | 210d | 367d | finish no earlier than 2002-03-08 | WG CN2 | 2128h | 212.8h | CAMEL4-EDS |  |  | WG | 2459 |  |  |  |  |
| 239 | 15.10 | Provision of location information of called subscriber | 266d | 2001-03-02 A | 2002-03-08 |  | 95% | 13.3d | 2001-03-02 | 2001-12-20 | 210d | 367d | finish no earlier than 2002-03-08 | WG CN2 | 2128h | 2021.6h | CAMEL4-LOCB |  |  | WG | 2458 |  |  |  |  |
| 240 | 15.11 | Inclusion of ODB data in the CSE_HLR interface | 175d | 2001-07-09 A | 2002-03-08 |  | 20% | 140d | 2001-07-09 | 2001-12-21 | 120d | 367d | finish no earlier than 2002-03-08 | WG CN2 | 1400h | 280h | CAMEL4-ODB |  |  | WG |  |  |  |  |  |
| 241 | 15.12 | Location information during an ongoing call (Handover DP) | 215d | 2001-05-14 A | 2002-03-08 |  | 15% | 182.75d | 2001-05-14 | 2001-12-21 | 160d | 367d | finish no earlier than 2002-03-08 | WG CN2 | 1720h | 258h | CAMEL4-HODP |  |  | WG |  |  |  |  |  |
| 242 | 15.13 | GPRS Any Time Interrogation | 175d | 2001-07-09 | 2002-03-08 |  |  |  | 2001-07-09 | 2001-12-21 | 120d | 367d | finish no earlier than 2002-03-08 | WG CN2 | 1400h |  | CAMEL4-ATI |  |  | WG |  |  |  |  |  |

Notes:
- 216: az: Created post-CN#13
- 217: According to T2 SWG1 chair this is automatically supported by the MExE support of UAProf therefore 100% complete
- 218: az: CN#13 - changed to Rel5
- 220: az 24/05/01: Rel4 completion 90->100%.
- 221: az: Created post-CN#13
- 226: az: CN#13 - Link to new WID
- 227: az: Created post-CN#13
- 229: Respo should be Andrij
- 240: Added on May 29, 2001

| ID | WBS | Task | Type | Duration | Start | Finish | Predecessors | Complete | Remaining | Baseline start | Baseline finish | Baseline duration | Total slack | Constraint | Resources | Work | Actual work | Text1 | Text2 | Text6 | Text7 | Text8 | Text9 | Text3 | Text4 | Text5 |
| --- | --- | --- | --- | --- | --- | --- | --- | --- | --- | --- | --- | --- | --- | --- | --- | --- | --- | --- | --- | --- | --- | --- | --- | --- | --- | --- |
| 243 | 16 | **MExE enhancements Rel-5** |  | 347d | 2001-02-21 A | 2002-06-20 |  | 15% | 296.3d | 2001-02-21 | 2002-06-20 | 347d | 293d |  | WG T2 | 5960h | 870.79h | MEXE5 | Ter | Rel5 | TSG | Friedhelm | 2464 |  |  |  |
| 244 | 16.1 | MExE Rel-5 Security Analyisis |  | 347d | 2001-02-21 A | 2002-06-20 |  | 5% | 329.65d | 2001-02-21 | 2002-06-20 | 347d | 293d | finish no earlier than 2002-06-20 | WG T2 | 2776h | 138.8h | MEXE5-SEC | Ter |  | TSG |  | 2465 | 33.102, 22.057, 23.057 | Andrew Myers, BT | andrew.meyers@bt.com |
| 245 | 16.2 | MExE Rel-5 Improvements and Investigations |  | 51d | 2001-03-26 A | 2001-12-17 |  | 80% | 10.2d | 2001-03-26 | 2001-12-17 | 51d | 426d | finish no earlier than 2001-12-17 | WG T2 | 408h | 326.4h | MEXE5-ENHANC | Ter |  | TSG |  | 2466 | 22.057, 23.057 | Mark CATALDO, Motorola | mcatald1@MOTOROLA.COM |
| 246 | 17 | **Wideband Telephony Service - AMR** |  | 650d | 2000-01-01 A | 2002-06-28 |  | 33% | 435.95d | 2000-01-01 | 2002-06-28 | 650d | 287d |  | WG SA4 | 76936h | 21213.8h | AMRWB |  | Rel5 | TSG | Paolo | 1625 |  | Imre Varga, Siemens AG | Imre.Varga@mch.siemens.de |
| 247 | 17.1 | **Specification** |  | 580d | 2000-01-01 A | 2002-03-22 |  | 34% | 380.67d | 2000-01-01 | 2001-06-11 | 376d | 357d |  | WG SA4 | 20136h | 7965.03h | AMRWB | Cod |  |  |  | 62 |  |  |  |
| 248 | 17.1.1 | Stage 1 |  | 125d | 2001-10-01 | 2002-03-22 |  |  |  |  |  |  | 357d | start no earlier than 2001-10-01 | WG SA1 | 1000h |  |  |  |  |  |  |  |  |  |  |
| 249 | 17.1.2 | Stage 2 |  | 125d | 2001-10-01 | 2002-03-22 |  |  |  |  |  |  | 357d | finish no earlier than 2002-03-22 | WG SA4 | 1000h |  |  |  |  |  |  |  |  |  |  |
| 250 | 17.1.3 | Design Constraints |  | 26d | 2000-01-03 A | 2000-02-07 A |  | 100% |  | 2000-01-03 | 2000-02-07 | 26d |  |  | WG SA4 | 208h | 208h | AMRWB | Cod |  |  |  | 1459 |  |  |  |
| 251 | 17.1.4 | General Description |  | 51d | 2000-02-07 A | 2000-04-17 A | 250 | 100% |  | 2000-02-07 | 2000-04-17 | 51d |  | start no earlier than 2000-09-25 | WG SA4 | 408h | 408h | AMRWB | Cod |  |  |  | 1460 |  |  |  |
| 252 | 17.1.5 | Feasibility Study |  | 26d | 2000-04-28 A | 2000-06-02 A | 251 | 100% |  | 2000-04-28 | 2000-06-02 | 26d |  | finish no earlier than 2000-06-02 | WG SA4 | 208h | 208h | AMRWB | Cod |  | TSG |  | 1626 | TR 26.901 |  |  |
| 253 | 17.1.6 | **Codec issues** |  | 574d | 2000-01-03 A | 2002-03-14 |  | 36% | 369.06d | 2000-02-01 | 2001-03-23 | 299d | 363d |  | WG SA4 | 10448h | 4378.4h | AMRWB | Cod |  |  |  | 67 |  |  |  |
| 254 | 17.1.6.1 | Codec qualification |  | 86d | 2000-02-01 A | 2000-05-30 A |  | 100% |  | 2000-02-01 | 2000-05-30 | 86d |  | finish no earlier than 2000-05-31 | WG SA4 | 688h | 688h | AMRWB | Cod |  | TSG |  | 1627 |  |  |  |
| 255 | 17.1.6.2 | Codec selection tests |  | 102d | 2000-06-01 A | 2000-10-20 A | 254 | 100% |  | 2000-06-01 | 2000-10-20 | 102d |  | finish no earlier than 2000-10-20 | WG SA4 | 816h | 816h | AMRWB | Cod |  |  |  | 74 |  |  | CRs |
| 256 | 17.1.6.3 | Codec selection |  | 5d | 2000-10-23 A | 2000-10-27 A | 255 | 100% |  | 2000-10-23 | 2000-10-27 | 5d |  | finish no earlier than 2000-10-27 | WG SA4 | 40h | 40h | AMRWB | Cod |  |  |  | 891 |  |  | CRs |
| 257 | 17.1.6.4 | TFO AMR-WB |  | 1d | 2002-03-14 A | 2002-03-14 |  | 30% | 0.7d |  |  |  | 363d | finish no earlier than 2002-03-14 | WG SA4 | 8h | 2.4h | AMRWB TFO |  |  |  |  |  |  |  |  |
| 258 | 17.1.6.5 | Other codec issues (verif., caracterisation) |  | 380d | 2000-09-29 A | 2002-03-14 |  | 60% | 152d | 2000-09-29 | 2001-03-23 | 126d | 363d | finish no earlier than 2002-03-14 | WG SA4 | 3040h | 1824h | AMRWB | Cod |  |  |  | 890 |  |  | CRs |
| 259 | 17.1.6.6 | AMR-WB and narrrowband interworking |  | 121d | 2001-09-27 | 2002-03-14 |  |  |  |  |  |  | 363d | finish no earlier than 2002-03-14 | WG SA4 | 968h |  | AMRWB IWG |  |  |  |  |  |  |  |  |
| 260 | 17.1.6.7 | Interworking with fixed broadband networks |  | 121d | 2001-09-27 | 2002-03-14 |  |  |  |  |  |  | 363d | finish no earlier than 2002-03-14 | WG SA4 | 968h |  | AMRWB IWG |  |  |  |  |  |  |  |  |
| 261 | 17.1.6.8 | Tones and announcements |  | 121d | 2001-09-27 | 2002-03-14 |  |  |  |  |  |  | 363d | finish no earlier than 2002-03-14 | WG SA4 | 968h |  | AMRWB |  |  |  |  |  |  |  |  |
| 262 | 17.1.6.9 | WB Conferencing and WB Voice Group calls |  | 1d | 2000-01-03 | 2000-01-03 |  |  |  |  |  |  | 936d | finish no earlier than 2000-01-03 | WG SA1 | 8h |  | AMRWB |  |  |  |  |  |  |  |  |
| 263 | 17.1.6.10 | Billing, accounting and call detail record aspects |  | 121d | 2001-09-27 | 2002-03-14 |  |  |  |  |  |  | 363d | finish no earlier than 2002-03-14 | WG SA5 | 968h |  | AMRWB |  |  |  |  |  |  |  |  |
| 264 | 17.1.6.11 | Legal interception |  | 121d | 2001-09-27 | 2002-03-14 |  |  |  |  |  |  | 363d | finish no earlier than 2002-03-14 | WG SA3 | 968h |  | AMRWB LIN |  |  |  |  |  |  |  |  |
| 265 | 17.1.7 | Introduction of AMR-WB speech service |  | 1d | 2000-01-03 | 2000-01-03 |  |  |  |  |  |  | 936d |  | WG CN4 | 8h |  |  |  |  |  |  |  |  |  |  |
| 266 | 17.1.8 | Start Testing | milestone | 0d | 2000-12-11 | 2000-12-11 |  |  |  | 2000-12-11 | 2000-12-11 | 0d | 692d | finish no earlier than 2000-12-11 | MLST |  |  | AMRWB |  |  |  |  | 1989 |  |  |  |
| 267 | 17.1.9 | Conformance tests (CRs to 34 series) |  | 131d | 2000-12-11 | 2001-06-11 |  |  |  | 2000-12-11 | 2001-06-11 | 131d | 561d | finish no earlier than 2001-06-11 | WG SA1 | 1048h |  | AMRWB | Cod |  |  |  | 1855 |  |  |  |

Notes:
- 252: S4,TD SP-000024: TR 26.901 v.4.0.0
- 258: ANSI C-Code , Test Sequences, Speech Transcoding Functions, Error Concealment of lost frames, Source Controlled Bit-Rate Operation, Voice Activity Detector, Frame Structure
- 267: Responsibility to be changed to SA4

| ID | WBS | Task | Duration | Start | Finish | Predecessors | Complete | Remaining | Baseline start | Baseline finish | Baseline duration | Total slack | Constraint | Resources | Work | Actual work | Text1 | Text2 | Text9 | Text3 | Text7 | Text4 | Text5 | Text8 | Text6 |
| --- | --- | --- | --- | --- | --- | --- | --- | --- | --- | --- | --- | --- | --- | --- | --- | --- | --- | --- | --- | --- | --- | --- | --- | --- | --- |
| 268 | 17.1.10 | **Terminal Acoustic Characteristics** | 73d | 2000-01-01 A | 2000-04-12 A |  | 100% |  | 2000-01-01 | 2000-04-12 | 73d |  |  | WG SA4 | 1168h | 1168h | AMRWB | Cod | 76 |  |  |  |  |  |  |
| 269 | 17.1.10.1 | Definition | 21d | 2000-01-01 A | 2000-01-31 A |  | 100% |  | 2000-01-01 | 2000-01-31 | 21d |  | finish no earlier than 2000-01-28 | WG SA4 | 168h | 168h | AMRWB | Cod | 1628 | 26.131 | TSG |  |  |  |  |
| 270 | 17.1.10.2 | Test specification | 52d | 2000-02-01 A | 2000-04-12 A | 269 | 100% |  | 2000-02-01 | 2000-04-12 | 52d |  | finish no earlier than 2000-03-13 | WG SA4 | 416h | 416h | AMRWB | Cod | 1629 | 26.132 | TSG |  |  |  |  |
| 271 | 17.2 | Floating-point ANSI-C code for the AMR-WB speech codec | 123d | 2001-09-25 | 2002-03-14 |  |  |  |  |  |  | 363d | finish no earlier than 2002-03-14 | WG SA4 | 984h |  | AMRWB-FP |  |  |  | TSG | J. Vainio (Nokia) | janne.m.vainio@nokia.com |  |  |
| 272 | 17.3 | **Implementation** | 650d | 2000-01-03 A | 2002-06-28 |  | 33% | 433.15d | 2000-01-03 | 2002-06-28 | 650d | 287d |  | WG SA4 | 50616h | 11536.4h | AMRWB | Cod | 889 |  |  |  |  |  |  |
| 273 | 17.3.1 | **In UTRAN** | 121d | 2001-09-27 | 2002-03-14 |  |  |  | 2000-10-03 | 2001-03-30 | 129d | 363d |  | TSG RAN | 3872h |  | AMRWB | Cod | 893 |  |  |  |  |  |  |
| 274 | 17.3.1.1 | Codec selection and GSM-UTRAN interworking | 121d | 2001-09-27 | 2002-03-14 |  |  |  |  |  |  | 363d | finish no earlier than 2002-03-14 | TSG RAN | 968h |  | AMRWB |  |  |  |  |  |  |  |  |
| 275 | 17.3.1.2 | Radio Access Bearer optimisation | 121d | 2001-09-27 | 2002-03-14 |  |  |  |  |  |  | 363d | finish no earlier than 2002-03-14 | TSG RAN | 968h |  | AMRWB |  |  |  |  |  |  |  |  |
| 276 | 17.3.1.3 | Radio Access Bearer renegotiation (impact at least on 23.018) | 121d | 2001-09-27 | 2002-03-14 |  |  |  |  |  |  | 363d | finish no earlier than 2002-03-14 | TSG RAN | 968h |  | AMRWB |  |  |  |  |  |  |  |  |
| 277 | 17.3.2 | **Support of AMR-WB in GERAN** | 650d | 2000-01-03 A | 2002-06-28 |  | 38% | 401.15d | 2000-01-03 | 2002-06-28 | 650d | 287d |  | TSG GERAN | 40048h | 9537.6h | GAMRWB | Cod | 80 |  | TSG |  |  | Paolo |  |
| 278 | 17.3.2.1 | GMSK and 8PSK WB FR / HR support - Channel coding in 45.003 | 390d | 2000-01-03 A | 2001-06-29 A |  | 100% |  | 2000-01-03 | 2001-06-29 | 390d |  | finish no earlier than 2001-06-29 | TSG GERAN | 3120h | 3120h | GAMRWB |  | 2265 |  | TSG |  |  |  |  |
| 279 | 17.3.2.2 | GMSK and 8PSK WB FR / HR support - Signalling for the A interface | 390d | 2000-01-03 A | 2001-06-29 A |  | 100% |  | 2000-01-03 | 2001-06-29 | 390d |  | finish no earlier than 2001-06-29 | TSG GERAN | 3120h | 3120h | GAMRWB |  | 2266 |  | TSG |  |  |  |  |
| 280 | 17.3.2.3 | GMSK and 8PSK WB FR / HR support - Signalling for Iu | 390d | 2000-01-03 A | 2001-06-29 A |  | 100% |  | 2000-01-03 | 2001-06-29 | 390d |  | finish no earlier than 2001-06-29 | TSG GERAN | 3120h | 3120h | GAMRWB |  | 2267 |  | TSG |  |  |  |  |
| 281 | 17.3.2.4 | Receiver performace in TS 45.005 | 585d | 2000-01-03 | 2002-03-29 |  |  |  | 2000-01-03 | 2002-03-29 | 585d | 352d | finish no earlier than 2002-03-29 | TSG GERAN | 4680h |  | GAMRWB |  | 2268 |  | TSG |  |  |  |  |
| 282 | 17.3.2.5 | Adaptation of subscriber data in HLR/VLR | 1d | 2002-03-29 | 2002-03-29 |  |  |  |  |  |  | 352d | finish no earlier than 2002-03-29 | TSG GERAN | 8h |  | GAMRWB |  |  |  |  |  |  |  |  |
| 283 | 17.3.2.6 | **GERAN MS conformance test for AMR-WB** | 650d | 2000-01-03 | 2002-06-28 |  |  |  | 2000-01-03 | 2002-06-28 | 650d | 287d |  | TSG GERAN | 10400h |  | GAMRWB |  | 2269 |  | TSG |  |  | Paolo |  |
| 284 | 17.3.2.6.1 | MS test | 650d | 2000-01-03 | 2002-06-28 |  |  |  | 2000-01-03 | 2002-06-28 | 650d | 287d | finish no earlier than 2002-06-28 | TSG GERAN | 5200h |  | GAMRWB |  | 2270 |  | TSG |  |  |  |  |
| 285 | 17.3.2.7 | **GERAN BTS conformance test for AMR-WB** | 650d | 2000-01-03 | 2002-06-28 |  |  |  | 2000-01-03 | 2002-06-28 | 650d | 287d |  | TSG GERAN | 10400h |  | GAMRWB |  | 2271 |  | TSG |  |  | Paolo |  |
| 286 | 17.3.2.7.1 | BTS test | 650d | 2000-01-03 | 2002-06-28 |  |  |  | 2000-01-03 | 2002-06-28 | 650d | 287d | finish no earlier than 2002-06-28 | TSG GERAN | 5200h |  | GAMRWB |  | 2272 |  | TSG |  |  |  |  |
| 287 | 17.3.3 | N1 Aspects | 66d | 2001-09-21 A | 2001-12-21 |  | 50% | 33d | 2000-11-20 | 2001-09-27 | 224d | 422d | finish no earlier than 2001-12-21 | WG CN1 | 528h | 264h | AMRWB |  | 1656 |  | TSG |  |  |  |  |
| 288 | 17.3.4 | N4 work | 121d | 2001-09-21 | 2002-03-08 |  |  |  | 2000-11-20 | 2001-09-27 | 224d | 367d | finish no earlier than 2002-03-08 | WG CN4 | 968h |  | AMRWB |  | 1656 |  | TSG |  |  |  |  |
| 289 | 18 | **Terminal interfaces** | 644d | 2000-01-03 A | 2002-06-20 |  | 54% | 299.4d | 2000-01-03 | 2002-06-20 | 644d | 293d |  | WG T2 | 29187.6h | 11175.2h | TI | Ter | 1826 |  |  |  |  | Friedhelm | NA |
| 290 | 18.1 | **AT commands enhancements** | 313d | 2000-01-03 A | 2001-03-14 |  | 71% | 91.85d | 2000-01-03 | 2001-03-14 | 313d | 624d |  | WG T2 | 6048h | 4273.19h | TI-ATC | Ter | 1827 | 27.007 |  |  |  |  | Rel4 |
| 291 | 18.1.1 | Specification of AT commands for new services | 313d | 2000-01-03 A | 2001-03-14 A |  | 100% |  | 2000-01-03 | 2001-03-14 | 313d |  | finish no earlier than 2001-03-14 | WG T2 | 2504h | 2504h |  | Ter | 1828 | 27.007 |  |  |  |  |  |
| 292 | 18.1.2 | UE Conformance test spec. AT command | 130d | 2000-07-03 | 2000-12-29 |  |  |  | 2000-07-03 | 2000-12-29 | 130d | 677d | finish no earlier than 2000-12-29 | WG T1 | 1040h |  | TI-ATC |  | 1858 | 34.125 |  |  |  |  |  |

Notes:
- 273: Ian Doig: Contact RAN or delete it
- 287: Some of N1 tasks: Indication of supported codecs by the MS, Bearer cap negociation, codec indication to MS... / One common set of codec negotiation procedures will be specified as in ID1657.
- 291: goal not completely achieved because of missing input
- 292: New specification document?

| ID | WBS | Task | Type | Duration | Start | Finish | Complete | Remaining | Baseline start | Baseline finish | Baseline duration | Total slack | Constraint | Resources | Work | Actual work | Text1 | Text2 | Text6 | Text9 | Text3 | Text4 | Text5 | Text7 | Text8 |
| --- | --- | --- | --- | --- | --- | --- | --- | --- | --- | --- | --- | --- | --- | --- | --- | --- | --- | --- | --- | --- | --- | --- | --- | --- | --- |
| 293 | 18.2 | **Wide Area Data Synchronisation** |  | 644d | 2000-01-03 A | 2002-06-20 | 45% | 351.57d | 2000-01-03 | 2002-06-20 | 644d | 293d |  | WG T2 | 13727.2h | 4247.2h | TI-WADS | Ter | NA | 1829 |  |  |  |  |  |
| 294 | 18.2.1 | Continues evolution of Synchronisation protocol |  | 313d | 2000-01-03 A | 2001-03-14 A | 100% |  | 2000-01-03 | 2001-03-14 | 313d |  | finish no earlier than 2001-03-14 | WG T2 | 2504h | 2504h | TI-SYNC-EVOL | Ter | Rel4 | 1830 | 27.903, 27.103 |  |  |  |  |
| 295 | 18.2.2 | vObjects and Other Constructs for Use in Data Synchronisation |  | 548d | 2000-05-16 A | 2002-06-20 | 25% | 411d | 2000-05-16 | 2002-06-20 | 548d | 293d | finish no earlier than 2002-06-20 | WG T2 | 4384h | 1096h | TI-SYNC-VOBJ | Ter | Rel5 | 1831 | 27.104 | Rob Lockhart, Motorola | rob.lockhart@MOTOROLA.COM | TSG |  |
| 296 | 18.2.3 | Start Testing | milestone | 0d | 2001-03-14 | 2001-03-14 |  |  | 2001-03-14 | 2001-03-14 | 0d | 624d | start no earlier than 2001-03-14 | MLST |  |  | AMRWB |  |  | 2251 |  |  |  |  |  |
| 297 | 18.2.4 | UE Conformance test spec. Wide area data sync |  | 130d | 2000-12-18 | 2001-06-15 |  |  | 2000-12-18 | 2001-06-15 | 130d | 557d | finish no earlier than 2001-06-15 | WG T1 | 1040h |  | TI-WADS |  |  | 1860 | 34.125 |  |  |  |  |
| 298 | 18.3 | Terminal local model |  | 218d | 2000-05-16 A | 2001-03-15 A | 100% |  | 2000-05-16 | 2001-03-15 | 218d |  | finish no earlier than 2001-03-15 | WG T2 | 1744h | 1744h | TLM | Ter | Rel4 | 1832 | 23.227 | Olga Tomé, Ericsson | Olga.Tome@ECS.ERICSSON.SE | TSG |  |
| 299 | 18.4 | Terminal local model enhancements |  | 223d | 2001-05-14 A | 2002-03-20 | 10% | 200.7d | 2001-05-14 | 2002-03-20 | 223d | 359d | finish no earlier than 2002-03-20 | WG T2 | 1784h | 178.4h | TLM5 | Ter | Rel5 | 1832 | 23.227 | Olga Tomé, Ericsson | Olga.Tome@ECS.ERICSSON.SE | TSG |  |
| 300 | 19 | **Location Services enhancements** |  | 585d | 2000-04-03 A | 2002-06-28 | 60% | 231.9d | 2000-04-03 | 2002-06-28 | 585d | 287d |  | WG SA2 | 104082h | 52131.8h | LCS1 |  | NA | 1536 |  | Jan Kall, Nokia |  | TSG | Alain |
| 301 | 19.1 | CBS interactions |  | 455d | 2000-04-03 A | 2001-12-28 | 53% | 216d | 2000-04-03 | 2001-12-28 | 455d | 417d |  | WG T2 | 3640h | 1912h | LCS1-CBS | Loc | Rel4 | 2229 | 23.041 |  |  |  |  |
| 302 | 19.2 | LCS support in the CS domain |  | 180d | 2000-05-15 A | 2001-01-19 A | 100% |  | 2000-05-15 | 2001-01-19 | 180d |  | finish no earlier than 2001-01-19 | WG SA2 | 1440h | 1440h | LCS1-CS | Loc | Rel4 | 523 |  |  |  |  |  |
| 303 | 19.3 | **LCS support in the PS domain** |  | 435d | 2000-05-01 A | 2001-12-28 | 92% | 36.05d | 2000-05-01 | 2001-12-28 | 435d | 417d |  | WG SA2 | 14164.8h | 9769.26h | LCS1-PS |  | Rel4 | 525 |  |  |  |  |  |
| 304 | 19.3.1 | Stage 1 |  | 40d | 2000-07-03 A | 2000-08-25 A | 100% |  | 2000-07-03 | 2000-08-25 | 40d |  | start no earlier than 2000-07-03 | WG SA1 | 320h | 320h | LCS1-PS | Loc |  | 1642 | 22.071 | Randolph Wohlert, Pacific Bell Wireless | rwohlert@tri.sbc.com |  |  |
| 305 | 19.3.2 | Stage 2 |  | 190d | 2000-05-01 A | 2001-01-19 A | 100% |  | 2000-05-01 | 2001-01-19 | 190d |  | finish no earlier than 2001-01-19 | WG SA2 | 1520h | 1520h | LCS1-PS |  |  | 1181 | 23.271 |  |  |  |  |
| 306 | 19.3.3 | **Stage 3** |  | 355d | 2000-08-21 A | 2001-12-28 | 89% | 39.44d | 2000-08-21 | 2001-12-28 | 355d | 417d |  | WG CN1 | 8240h | 7324.44h | LCS1-PS | Loc |  | 1180 |  |  |  |  |  |
| 307 | 19.3.3.1 | Layer 3 LCS signaling UE (MS) -SGSN (UMTS PS and and GSM-GPRS) |  | 355d | 2000-08-21 A | 2001-12-28 | 79% | 75d | 2000-08-21 | 2001-12-28 | 355d | 417d | finish no earlier than 2000-12-13 | WG CN1 | 2840h | 2240h | LCS1-PS | Loc |  | 526 |  | Janne Muhonen / Nokia |  |  |  |
| 308 | 19.3.3.2 | MAP impacts of LCS |  | 160d | 2000-08-21 A | 2001-03-30 A | 100% |  | 2000-08-21 | 2001-03-30 | 160d |  | finish no earlier than 2001-03-30 | WG CN4 | 1280h | 1280h | LCS1-PS | Loc |  | 2462 |  |  |  |  |  |
| 309 | 19.3.3.3 | GTP signaling for LCS |  | 160d | 2000-08-21 A | 2001-03-30 A | 100% |  | 2000-08-21 | 2001-03-30 | 160d |  | finish no earlier than 2001-03-30 | WG CN4 | 1280h | 1280h | LCS1-PS | Loc |  | 527 |  |  |  |  |  |
| 310 | 19.4 | **UE positioning** |  | 520d | 2000-04-03 A | 2002-03-29 | 55% | 231.87d | 2000-04-03 | 2001-12-28 | 455d | 352d |  | TSG RAN | 17615.2h | 9429.41h | LCS1-UEpos |  | NA | 1600 |  |  |  | TSG |  |
| 311 | 19.4.1 | Iub/Iur interfaces for methods Rel 99 |  | 233.9d | 2000-04-03 A | 2001-03-30 A | 100% |  | 2000-04-03 | 2001-03-30 | 233.9d |  | finish no earlier than 2001-03-30 | WG RAN3 | 1871.2h | 1871.2h | LCS1-UEpos-IubIur |  | Rel4 | 1601 |  | Yun-Chao Hu, Ericsson |  | TSG |  |
| 312 | 19.4.2 | UE positioning enhancements - IPDL for TDD |  | 150d | 2000-08-28 A | 2001-03-23 A | 100% |  | 2000-08-28 | 2001-03-23 | 150d |  | finish no earlier than 2001-03-23 | WG RAN2 | 1200h | 1200h | LCS1-UEpos-enh |  | Rel4 | 1602 |  | M. Beckmann, Siemens |  | TSG |  |
| 313 | 19.4.3 | UE positioning enhancements - other methods |  | 350d | 2000-08-28 A | 2001-12-28 | 24% | 266d | 2000-08-28 | 2001-12-28 | 350d | 417d | finish no earlier than 2001-12-28 | WG RAN2 | 2800h | 672h | LCS1-UEpos-enh |  | Rel5 | 2457 |  | M. Beckmann, Siemens |  | TSG |  |
| 314 | 19.4.4 | UE positioning enhancements for 1.28 Mcps TDD |  | 255d | 2001-04-09 A | 2002-03-29 | 49% | 130.05d | 2001-04-09 | 2001-12-28 | 190d | 352d | finish no earlier than 2002-03-29 | WG RAN2 | 2040h | 999.6h |  |  | Rel5 | 2474 |  | Xiaohua Mei, CATT |  | TSG |  |
| 315 | 19.4.5 | Open SMLC-SRNC Interface within the UTRAN to support UTRAN Rel'4 positioning |  | 190d | 2001-04-09 A | 2001-12-28 | 66% | 64.6d | 2001-04-09 | 2001-12-28 | 190d | 417d | finish no earlier than 2001-12-28 | WG RAN2 | 1520h | 1003.2h | LCS-Rel4Pos |  | Rel5 | 2475 |  | Antti Toskala, Nokia |  | TSG |  |
| 316 | 19.4.6 | **Open SMLC-SRNC Interface within the UTRAN to support A-GPS Positioning** |  | 195d | 2001-01-15 A | 2001-10-12 | 49% | 100d | 2001-01-15 | 2002-01-11 | 260d | 472d |  | WG RAN2 | 3120h | 1520h | LCS-INTF |  | Rel5 | 2125 |  | Kirk Burroughs, Qualcomm |  | TSG |  |
| 317 | 19.4.6.1 | Stage 2 |  | 195d | 2001-01-15 A | 2001-10-12 | 49% | 100d | 2001-01-15 | 2001-10-12 | 195d | 472d | start no earlier than 2001-01-15 | WG SA2 | 1560h | 760h |  |  |  | 2127 |  | Kirk Burroughs, Qualcomm |  | WG |  |
| 318 | 19.4.7 | (Copy) UTRA repeater specification |  | 183d | 2000-07-10 A | 2001-03-21 | 27% | 133.59d | 2000-07-10 | 2001-03-21 | 183d | 619d | finish no earlier than 2001-03-21 | WG RAN4 | 1464h | 395.28h |  |  |  | 1603 |  | T. Kummetz, Mikom; M. Nilsson, Allgon |  | TSG |  |

Notes:
- 293: AS: Rel5 changed to Rel4 according to SA#10 decision, milestone on testing added
- 295: FR: moved from Rel4 to Rel5 at T2#12
- 296: AS: line added to show the milestone in the summary task
- 297: New specification document?
- 302: Only MAP impact foreseen so far. To be further split if needed.
- 304: To be also considered: External LCS client identity, and Privacy options when PDP-context and when no PDP-context is established
- 305: AS: 23.271 completed at SA#10
- 308: Missing work task
- 311: 27/11: WG corrected; rapporteur corrected
- 312: 5 Mar 2001: splitting off of IPDL for TDD for Rel-4 agreed by R2
- 313: 5 Mar 2001: splitting off of IPDL for TDD for Rel-4 agreed by R2
- 316: Change of responsible group

| ID | WBS | Task | Duration | Start | Finish | Complete | Remaining | Baseline start | Baseline finish | Baseline duration | Total slack | Constraint | Resources | Work | Actual work | Text1 | Text2 | Text6 | Text9 | Text3 | Text4 | Text5 | Text7 | Text8 |
| --- | --- | --- | --- | --- | --- | --- | --- | --- | --- | --- | --- | --- | --- | --- | --- | --- | --- | --- | --- | --- | --- | --- | --- | --- |
| 319 | 19.5 | **Event based and Periodic LCS** | 285d | 2000-05-22 A | 2001-06-22 | 56% | 124.4d | 2000-05-22 | 2001-06-22 | 285d | 552d |  | WG SA1 | 4560h | 2569.6h | LCS1-EBP | Loc | Rel5 | 1171 |  |  |  |  |  |
| 320 | 19.5.1 | Stage 1 | 130d | 2000-05-22 A | 2000-11-17 A | 100% |  | 2000-05-22 | 2000-11-17 | 130d |  | finish no earlier than 2000-07-21 | WG SA1 | 1040h | 1040h | LCS1-EBP | Loc |  | 1641 | 22.071 | Randolph Wohlert, Pacific Bell Wireless | rwohlert@tri.sbc.com |  |  |
| 321 | 19.5.2 | Stage 2 specification | 60d | 2000-11-06 A | 2001-01-26 | 51% | 29.4d | 2000-11-06 | 2001-01-26 | 60d | 657d | finish no earlier than 2001-01-26 | WG SA2 | 480h | 244.8h | LCS1-EBP | Loc |  | 1538 |  |  |  |  |  |
| 322 | 19.5.3 | Impact on MAP | 95d | 2001-02-12 | 2001-06-22 |  |  | 2001-02-12 | 2001-06-22 | 95d | 552d | start no earlier than 2001-02-12 | WG CN4 | 760h |  | LCS1-EBP | Loc |  | 1179 |  |  |  |  |  |
| 323 | 19.6 | **Location Services for GERAN in A/Gb Mode** | 370d | 2000-04-03 A | 2001-08-31 | 79% | 75.97d | 2000-04-03 | 2001-08-31 | 370d | 502d |  | TSG GERAN | 15360h | 11892.7h | LCS-GERAN |  | Rel5 | 2436 |  |  |  | TSG | Paolo |
| 324 | 19.6.1 | GERAN LCS Stage 2 (first release) | 320.67d | 2000-04-03 A | 2001-06-25 | 92% | 24.67d | 2000-04-03 | 2001-06-25 | 320.67d | 551.33d | finish no earlier than 2001-08-31 | TSG GERAN; WG GERAN1, WG GERAN2; WG SA2 | 2960h | 2368h | LCS-GERAN |  |  | 2437 |  |  |  | TSG |  |
| 325 | 19.6.2 | Gb interface support for LCS | 370d | 2000-04-03 A | 2001-08-31 A | 100% |  | 2000-04-03 | 2001-08-31 | 370d |  | finish no earlier than 2001-08-31 | TSG GERAN | 2960h | 2960h | LCS-GERAN |  |  | 2438 |  |  |  | TSG |  |
| 326 | 19.6.3 | RLC/MAC protocol support for LCS | 305d | 2000-04-03 | 2001-06-01 |  |  | 2000-04-03 | 2001-06-01 | 305d | 567d | start no earlier than 2000-04-03 | TSG GERAN | 2440h |  | LCS-GERAN |  |  | 2439 |  |  |  | TSG |  |
| 327 | 19.6.4 | L3 protocol support for LCS | 305d | 2000-04-03 A | 2001-06-01 A | 100% |  | 2000-04-03 | 2001-06-01 | 305d |  | finish no earlier than 2001-06-01 | TSG GERAN | 2440h | 2440h | LCS-GERAN |  |  | 2440 |  |  |  | TSG |  |
| 328 | 19.6.5 | Stage 3 specifications | 305d | 2000-04-03 A | 2001-06-01 A | 100% |  | 2000-04-03 | 2001-06-01 | 305d |  | finish no earlier than 2001-06-01 | TSG GERAN | 2440h | 2440h | LCS-GERAN |  |  | 2441 |  |  |  | TSG |  |
| 329 | 19.7 | **Location Services for GERAN in Iu Mode** | 585d | 2000-04-03 A | 2002-06-28 | 70% | 173.95d | 2000-04-03 | 2002-06-28 | 585d | 287d |  | TSG GERAN | 20880h | 8487.54h | LCS-GERAN |  | Rel5 | 2442 |  |  |  | TSG | Paolo |
| 330 | 19.7.1 | GERAN LCS Stage 2 (second release) | 225.5d | 2000-04-03 A | 2001-02-12 | 96% | 8.87d | 2000-04-03 | 2001-02-12 | 225.5d | 646.5d | finish no earlier than 2001-04-02 | TSG GERAN; WG GERAN1, WG GERAN2; WG RAN2; WG RAN3; WG SA2 | 2088h | 1733.04h | LCS-GERAN |  |  | 2443 |  |  |  | TSG |  |
| 331 | 19.7.2 | Iu-ps interface support for LCS | 225.5d | 2000-04-03 A | 2001-02-12 | 96% | 8.87d | 2000-04-03 | 2001-02-12 | 225.5d | 646.5d | finish no earlier than 2001-04-02 | TSG GERAN; WG GERAN1, WG GERAN2; WG RAN2; WG RAN3; WG SA2 | 2088h | 1733.04h | LCS-GERAN |  |  | 2444 |  |  |  | TSG |  |
| 332 | 19.7.3 | Iu-cs interface support for LCS | 225.5d | 2000-04-03 A | 2001-02-12 | 96% | 8.87d | 2000-04-03 | 2001-02-12 | 225.5d | 646.5d | finish no earlier than 2001-04-02 | TSG GERAN; WG GERAN1, WG GERAN2; WG RAN2; WG RAN3; WG SA2 | 2088h | 1733.04h | LCS-GERAN |  |  | 2445 |  |  |  | TSG |  |
| 333 | 19.7.4 | Iur-g interface support for LCS | 75d | 2001-08-20 | 2001-11-30 |  |  | 2001-08-20 | 2001-11-30 | 75d | 437d | start no earlier than 2001-08-20 | TSG GERAN; WG GERAN1, WG GERAN2; WG RAN2; WG RAN3; WG SA2 | 3000h |  | LCS-GERAN |  |  | 2446 |  |  |  | TSG |  |
| 334 | 19.7.5 | RRC protocol support for LCS | 75d | 2001-08-20 | 2001-11-30 |  |  | 2001-08-20 | 2001-11-30 | 75d | 437d | start no earlier than 2001-08-20 | TSG GERAN; WG GERAN1, WG GERAN2; WG RAN2; WG RAN3; WG SA2 | 3000h |  | LCS-GERAN |  |  | 2447 |  |  |  | TSG |  |
| 335 | 19.7.6 | Additional impacts on Broadcast of LCS data on packet channels | 75d | 2001-08-20 | 2001-11-30 |  |  | 2001-08-20 | 2001-11-30 | 75d | 437d | start no earlier than 2001-08-20 | TSG GERAN; WG GERAN1, WG GERAN2; WG RAN2; WG RAN3; WG SA2 | 3000h |  | LCS-GERAN |  |  | 2448 |  |  |  | TSG |  |
| 336 | 19.7.7 | Stage 3 specifications | 23.4d | 2002-05-28 | 2002-06-28 |  |  | 2002-05-28 | 2002-06-28 | 23.4d | 287d | finish no earlier than 2002-06-28 | TSG GERAN; WG GERAN1, WG GERAN2; WG RAN2; WG RAN3; WG SA2 | 936h |  | LCS-GERAN |  |  | 2449 |  |  |  | TSG |  |
| 337 | 19.8 | Enhanced support for user privacy and subscriber data handling | 145d | 2001-06-04 A | 2001-12-21 | 21% | 115d | 2001-06-04 | 2001-12-21 | 145d | 422d | start no earlier than 2001-06-04 | WG SA2 | 1160h | 240h |  |  | Rel5 |  |  |  |  | WG |  |
| 338 | 19.9 | LCS interoperation stage 2 aspects | 180d | 2000-05-15 A | 2001-01-19 | 44% | 100.8d | 2000-05-15 | 2001-01-19 | 180d | 662d | finish no earlier than 2001-01-19 | WG SA2 | 1440h | 633.6h |  | Loc |  | 544 |  |  |  |  |  |
| 339 | 19.10 | **LCS interoperability aspects to GERAN** | 245.14d | 2000-08-28 A | 2001-08-06 | 94% | 14.14d | 2000-08-28 | 2001-08-06 | 245.14d | 521.86d |  | TSG GERAN | 4601.14h | 3696h | LCS-GERAN |  |  | 2434 |  |  |  | TSG | Paolo |
| 340 | 19.10.1 | Co-ordinated development of GSM LCS Phase 2 and UMTS LCS, S2 and GERAN | 245.14d | 2000-08-28 A | 2001-08-06 | 94% | 14.14d | 2000-08-28 | 2001-08-06 | 245.14d | 521.86d | finish no earlier than 2001-11-30 | TSG GERAN; WG SA2; WG SA5; WG RAN2; WG RAN3; WG GERAN2; WG GERAN1 | 2640h | 1848h | LCS-GERAN |  |  | 2435 |  |  |  | TSG |  |
| 341 | 19.11 | **GERAN MS Conformance test for LCS** | 216d | 2001-08-31 | 2002-06-28 |  |  | 2001-08-31 | 2002-06-28 | 216d | 287d |  | WG GERAN4 | 3456h |  | LCS-GERAN |  |  | 2450 |  |  |  | TSG | Paolo |
| 342 | 19.11.1 | MS test | 216d | 2001-08-31 | 2002-06-28 |  |  | 2001-08-31 | 2002-06-28 | 216d | 287d | finish no earlier than 2002-06-28 | WG GERAN4 | 1728h |  | LCS-GERAN |  |  | 2451 |  |  |  | TSG |  |

Notes:
- 320: Evaluate Event based and Periodic LCS to be included in R00, corresponding Stage 1 description
- 322: Possible impact on UTRAN of LCS quality level request

| ID | WBS | Task | Duration | Start | Finish | Complete | Remaining | Baseline start | Baseline finish | Baseline duration | Total slack | Constraint | Resources | Work | Actual work | Text1 | Text7 | Text8 | Text9 | Text2 | Text3 | Text5 | Text6 |
| --- | --- | --- | --- | --- | --- | --- | --- | --- | --- | --- | --- | --- | --- | --- | --- | --- | --- | --- | --- | --- | --- | --- | --- |
| 343 | 19.12 | **GERAN BTS Conformance test for LCS** | 216d | 2001-08-31 | 2002-06-28 |  |  | 2001-08-31 | 2002-06-28 | 216d | 287d | start no earlier than 2001-08-31 | WG GERAN3 | 3456h |  | LCS-GERAN | TSG | Paolo | 2452 |  |  |  |  |
| 344 | 19.12.1 | BTS test | 216d | 2001-08-31 | 2002-06-28 |  |  | 2001-08-31 | 2002-06-28 | 216d | 287d | finish no earlier than 2002-06-28 | WG GERAN3 | 1728h |  | LCS-GERAN | TSG |  | 2453 |  |  |  |  |
| 345 | 19.13 | (Copy) LCS application interfaces (LCS-OSA) | 186d | 2000-09-11 | 2001-05-28 |  |  | 2000-09-11 | 2001-05-28 | 186d | 571d | start no earlier than 2000-09-11 | WG SA1 | 1488h |  |  |  |  | 1796 | Loc |  |  |  |
| 346 | 19.14 | FS on LCS support in the IMS | 90d | 2001-02-12 A | 2002-01-18 | 28% | 65d | 2001-02-12 | 2002-01-18 | 90d | 402d | start no earlier than 2001-02-12 | WG SA1 | 720h | 200h |  |  |  | 1183 | Loc |  |  |  |
| 347 | 19.15 | (copy) Charging and OAM&P | 136d | 2001-09-21 A | 2002-03-29 | 45% | 74.8d | 2001-01-01 | 2001-06-29 | 130d | 352d | finish no earlier than 2002-03-29 | WG SA5 | 1088h | 489.6h | LCS1-OAM | TSG |  | 519 | Loc | 32-series | Albert.Yuhan@voicestream.com; Michael.Truss@MOTOROLA.COM | Rel5 |
| 348 | 19.16 | New security aspects of LCS (not identified) | 446d | 2000-04-14 A | 2001-12-28 | 15% | 379.1d | 2000-04-14 | 2001-12-28 | 446d | 417d | finish no earlier than 2001-12-28 | WG SA3 | 3568h | 535.2h | LCS1-SEC |  |  | 521 | Loc |  | valtteri.niemi@nokia.com | Rel5 |
| 349 | 20 | **UICC/(U)SIM enhancements and interworking** | 430d | 2000-07-24 A | 2002-03-15 | 69% | 132.7d | 2000-07-24 | 2002-03-15 | 430d | 362d |  | WG T3 | 6432h | 4447.02h | UICC1 |  | MichaelS | 1560 | Ter |  |  | NA |
| 350 | 20.1 | Common PCN Handset Specification (CPHS) | 175d | 2000-07-24 A | 2001-03-23 A | 100% |  | 2000-07-24 | 2001-03-23 | 175d |  | finish no earlier than 2001-03-23 | WG T3 | 1400h | 1400h | UICC1-CPHS | TSG |  | 1799 | Ter | 27.103 |  | Rel4 |
| 351 | 20.2 | UICC/USIM Transport Protocol | 199d | 2001-06-12 A | 2002-03-15 | 42% | 115.42d | 2001-06-12 | 2002-03-15 | 199d | 362d | finish no earlier than 2002-03-15 | WG T3 | 1592h | 668.64h | UICC1-Protocl | TSG |  | 1799 | Ter |  |  | Rel5 |
| 352 | 21 | **(U)SIM toolkit enhancements** | 470d | 2000-06-05 A | 2002-03-22 | 48% | 242.62d | 2000-06-05 | 2002-03-14 | 464d | 357d |  | WG T3 | 23384h | 10321.9h | USAT1 |  | MichaelS | 1800 | Ter |  |  | NA |
| 353 | 21.1 | USAT local link | 210d | 2000-06-05 A | 2001-03-23 A | 100% |  | 2000-06-05 | 2001-03-23 | 210d |  | finish no earlier than 2001-03-23 | WG T3 | 1680h | 1680h | USAT1-LocLnk | TSG |  | 2034 |  |  |  | Rel4 |
| 354 | 21.2 | Enhancements to (U)SIM toolkit secure messaging | 250d | 2001-04-02 A | 2002-03-15 | 20% | 200d | 2001-04-02 | 2001-07-27 | 85d | 362d | finish no earlier than 2002-03-15 | WG T3 | 2000h | 400h | USAT1-SM | TSG |  | 1566 | Ter | 27.103 |  | Rel5 |
| 355 | 21.3 | **Protocol Standardisation of a SIM Toolkit Interpreter** | 470d | 2000-06-05 A | 2002-03-22 | 69% | 144.52d | 2000-06-05 | 2002-03-14 | 464d | 357d |  | WG T3 | 8584h | 5944.45h | USAT1-Interpr | TSG |  | 1801 | Ter | 27.103 |  | Rel5 |
| 356 | 21.3.1 | Stage 1 | 205d | 2000-06-05 A | 2001-03-16 A | 100% |  | 2000-06-05 | 2001-03-16 | 205d |  | finish no earlier than 2001-03-16 | WG T3 | 1640h | 1640h |  | TSG |  |  |  |  |  | Rel5 |
| 357 | 21.3.2 | Stage 2 and 3 | 253d | 2001-01-03 A | 2001-12-21 | 76% | 60.72d | 2001-01-03 | 2001-09-21 | 188d | 422d | finish no earlier than 2001-12-21 | WG T3 | 2024h | 1538.24h |  | TSG |  |  |  |  |  | Rel5 |
| 358 | 21.3.3 | Test specification | 145d | 2001-09-03 A | 2002-03-22 | 14% | 124.7d | 2001-06-01 | 2002-03-14 | 205d | 357d | finish no earlier than 2002-03-22 | WG T3 | 1160h | 162.4h |  | TSG |  |  |  |  |  | Rel5 |
| 359 | 21.4 | **UICC API** | 265d | 2000-09-25 A | 2001-09-28 | 7% | 247.78d | 2000-09-25 | 2001-09-28 | 265d | 482d |  | WG T3 | 7360h | 478.4h | USAT1-API |  |  | 1802 | Ter |  |  | NA |
| 360 | 21.4.1 | **C SIM API** | 265d | 2000-09-25 A | 2001-09-28 | 7% | 247.78d | 2000-09-25 | 2001-09-28 | 265d | 482d |  | WG T3 | 5240h | 340.6h | USAT1-API-MULTOS | TSG |  | 2031 | Ter |  |  | Rel5 |
| 361 | 21.4.1.1 | Specification | 195d | 2000-09-25 A | 2001-06-22 | 13% | 169.65d | 2000-09-25 | 2001-06-22 | 195d | 552d | finish no earlier than 2001-06-22 | WG T3 | 1560h | 202.8h | USAT1-API-MULTOS | TSG |  | 2032 | Ter |  |  |  |
| 362 | 21.4.1.2 | Test specification | 195d | 2001-01-01 | 2001-09-28 |  |  | 2001-01-01 | 2001-09-28 | 195d | 482d | finish no earlier than 2001-09-28 | WG T3 | 1560h |  | USAT1-API-MULTOS | TSG |  | 2033 | Ter |  |  |  |
| 363 | 22 | **Security enhancements** | 650d | 2000-01-03 A | 2002-06-28 | 33% | 437.67d | 2000-01-03 | 2002-06-28 | 650d | 287d |  | WG SA3 | 65368h | 21089.3h | SEC1 | TSG | Maurice |  |  |  | Peter.Howard@vf.vodafone.co.uk | NA |
| 364 | 22.1 | Evolution of GSM CS algorithms (e.g. A5/3 development and deployment) | 271d | 2000-01-03 A | 2001-01-15 | 34% | 178.86d | 2000-01-03 | 2001-01-15 | 271d | 666d | finish no earlier than 2001-01-15 | WG SA3 | 2168h | 737.12h | SEC1-CSALGO1 | TSG |  | 1587 | Sec |  |  | Rel4 |
| 365 | 22.2 | **Evolution of GSM PS algorithms (e.g. GEA 2 deployment)** | 219d | 2000-02-22 A | 2000-12-22 A | 100% |  | 2000-02-22 | 2000-12-22 | 219d |  |  | WG SA3 | 6024h | 6024h | SEC1-PSALGO1 | TSG |  | 1588 | Sec |  |  | Rel4 |
| 366 | 22.2.1 | Main aspects | 199d | 2000-02-22 A | 2000-11-24 A | 100% |  | 2000-02-22 | 2000-11-24 | 199d |  | finish no earlier than 2000-11-24 | WG SA3 | 1592h | 1592h | SEC1-PSALGO1 |  |  | 1589 | Sec |  |  |  |
| 367 | 22.2.2 | Impact on GTP | 200d | 2000-03-20 A | 2000-12-22 A | 100% |  | 2000-03-20 | 2000-12-22 | 200d |  | finish no earlier than 2000-12-22 | WG CN4 | 1600h | 1600h | SEC1-PSALGO1 | WG |  | 1618 |  |  |  |  |
| 368 | 22.2.3 | GEA capability indication in MS CM | 135d | 2000-06-19 A | 2000-12-22 A | 100% |  | 2000-06-19 | 2000-12-22 | 135d |  | finish no earlier than 2000-12-22 | WG CN1 | 1080h | 1080h | SEC1-PSALGO1-GEACAP |  |  | 1661 | Sec |  |  |  |

Notes:
- 345: (LCS-OSA)...
- 347: az: WID appr.SA#13. / Text4: Albert YUHAN (VoiceStream Wireless), Michael TRUSS (Motorola)
- 348: Evaluate possible impact of new LCS features on security, Evaluate privacy options in call related LCS for specific Client, separate for MT and MO LR; 14/09/00: End date 28/12/01 WI may need to be split to improve on this date. S3#17 15% complete / Text4: Valtteri Niemi, Nokia
- 350: 28/5/2001: CRs approved at TP-11. WI complete. / Text4: ?, One2One
- 351: 5/10/2001: completion % updated / Text4: Sonia Compans (Gemplus)
- 353: 25/5/2001:CR was approved at TP-11. WI is complete / Text4: Jean-Francois Rubon (Gemplus)
- 354: 8/3/2001: Work not started as of T3-18, therefore changed to rel-5. / Text4: Daniel Erricson, Across Wireless
- 355: 28/5/2001: T3-19 proposed that since the stage 2 and 3 will not be presented to TP-12 for approval as expected, the WI will be moved to rel-5, with completion expected at TP-13. / Text4: Michael Meyer, G & D
- 356: 5/10/2001: Stage one comepeted at TP-12.
- 357: 5/10/2001: TS 31.112 and 31.113 approved at TP-13. TS 31.114 to be presented to TP-14.
- 358: 5/10/2001: Work started on test specification / Text4: Gérald MAUNIER (Gemplus)
- 359: 8/3/2001: test spec is based on R99 core spec, so deleted from Workplan
- 361: 30/12/2000: completion amount updated / Text4: Neil Livingston – Aspects Software
- 362: Text4: Neil Livingston – Aspects Software
- 363: Added BB UE authentication and rapporteur added / Text4: Peter Howard, Vodafone
- 364: May 01, Integration of sec archi, Feb 01, Complete CRs with S3 review, Apr 01, CRs to be approved at TSG, May 01. S3#17: No supporting companies
- 365: Complete TSG#09 (09/2000). S3#17: No supporting companies
- 366: Complete TSG#09 (09/2000). S3#17: Proposed for deletion
- 368: Text4: Duncan Mills / Vodafone Airtouch

| ID | WBS | Task | Duration | Start | Finish | Complete | Remaining | Baseline start | Baseline finish | Baseline duration | Total slack | Constraint | Resources | Work | Actual work | Text1 | Text2 | Text6 | Text7 | Text9 | Text4 | Text5 | Text3 | Text8 |
| --- | --- | --- | --- | --- | --- | --- | --- | --- | --- | --- | --- | --- | --- | --- | --- | --- | --- | --- | --- | --- | --- | --- | --- | --- |
| 369 | 22.3 | **MAP application layer security** | 380d | 2000-01-03 A | 2001-06-15 | 51% | 185.6d | 2000-01-03 | 2001-06-15 | 380d | 557d |  | WG SA3 | 8232h | 4211.23h | SEC1-MAPAL | Sec | Rel4 | TSG |  |  |  |  |  |
| 370 | 22.3.1 | Main aspects | 199d | 2000-02-21 A | 2001-03-29 A | 100% |  | 2000-02-21 | 2001-03-29 | 199d |  | start no earlier than 2000-02-21 | WG SA3 | 1592h | 1592h | SEC1-MAPAL | Sec |  | WG | 1584 |  |  |  |  |
| 371 | 22.3.2 | Other stage 3 aspects | 199d | 2000-02-22 A | 2000-11-24 A | 100% |  | 2000-02-22 | 2000-11-24 | 199d |  | finish no earlier than 2000-11-24 | WG CN4 | 1592h | 1592h | SEC1-MAPAL | Sec |  | TSG | 2025 |  |  |  |  |
| 372 | 22.3.3 | Visibility and Configurability of security | 380d | 2000-01-03 | 2001-06-15 |  |  | 2000-01-03 | 2001-06-15 | 380d | 557d | finish no earlier than 2001-06-15 | WG SA3 | 3040h |  | SEC1-VCS | Sec | Rel4 | TSG | 1594 | Sébastien Nguyen Ngoc, France Telecom | Sebastien.nguyenngoc@francetelecom.fr |  |  |
| 373 | 22.4 | **Network domain security** | 650d | 2000-01-03 A | 2002-06-28 | 24% | 495.19d | 2000-01-03 | 2002-06-28 | 650d | 287d |  | WG SA3 | 34256h | 8418.34h | SEC1-NDS | Sec | Rel5 | TSG | 1576 | Geir M. Køien, Telenor | Geir-myrdahl.koien@telenor.com |  |  |
| 374 | 22.4.1 | **Control plane protection in core network (e.g., GTP, CAP, MAP/IP, provided by IPsec)** | 460d | 2000-02-21 A | 2001-11-23 | 27% | 335.49d | 2000-02-21 | 2001-11-23 | 460d | 442d |  | WG SA3 | 9680h | 2620.05h | SEC1-NDS | Sec |  |  | 1577 |  |  |  |  |
| 375 | 22.4.1.1 | Main aspects | 290d | 2000-05-12 | 2001-06-21 |  |  | 2000-05-12 | 2001-06-21 | 290d | 553d | finish no earlier than 2001-06-21 | WG SA3 | 2320h |  | SEC1-NDS | Sec |  |  | 1578 |  |  |  |  |
| 376 | 22.4.1.2 | Integration of GTP signalling security architecture | 460d | 2000-02-21 A | 2001-11-23 | 44% | 257d | 2000-02-21 | 2001-11-23 | 460d | 442d | finish no earlier than 2001-03-30 | WG CN4 | 3680h | 1624h | SEC1-NDS | Sec |  |  | 1579 |  |  |  |  |
| 377 | 22.4.2 | **User plane protection in core network (e.g., provided by IPsec)** | 460d | 2000-02-21 A | 2001-11-23 | 28% | 332.91d | 2000-02-21 | 2001-11-23 | 460d | 442d |  | WG SA3 | 10144h | 2802.53h | SEC1-NDS | Sec |  |  | 1580 |  |  |  |  |
| 378 | 22.4.2.1 | Main aspects | 349d | 2000-02-21 A | 2001-06-21 | 7% | 324.57d | 2000-02-21 | 2001-06-21 | 349d | 553d | finish no earlier than 2001-06-21 | WG SA3 | 2792h | 195.44h | SEC1-NDS | Sec |  |  | 1581 |  |  |  |  |
| 379 | 22.4.2.2 | Integration of GTP signalling security architecture | 459d | 2000-02-22 A | 2001-11-23 | 43% | 260.2d | 2000-02-22 | 2001-11-23 | 459d | 442d | finish no earlier than 2001-03-23 | WG CN4 | 3672h | 1590.4h | SEC1-NDS | Sec |  |  | 1582 |  |  |  |  |
| 380 | 22.4.3 | IP network layer security (NDS/IP) | 532d | 2000-06-15 A | 2002-06-28 | 43% | 304d | 2000-06-15 | 2002-06-28 | 532d | 287d | finish no earlier than 2001-12-21 | WG SA3 | 4256h | 1824h | SEC1-NDS-IP |  |  | WG |  | Geir M. Køien, Telenor | Geir-myrdahl.koien@telenor.com | TS 33.210 |  |
| 381 | 22.4.4 | Key management for core network security | 385d | 2000-01-03 | 2001-06-22 |  |  | 2000-01-03 | 2001-06-22 | 385d | 552d | finish no earlier than 2001-06-22 | WG SA3 | 3080h |  | SEC1-KMCN | Sec |  | TSG | 1586 | Peter Howard, Vodafone | Peter.Howard@vf.vodafone.co.uk |  |  |
| 382 | 22.4.5 | Study of network-based denial of service | 272d | 2000-09-14 | 2001-09-28 |  |  | 2000-09-14 | 2001-09-28 | 272d | 482d | finish no earlier than 2001-09-28 | WG SA3 | 2176h |  | SEC1-NDS |  |  | TSG | 2098 | Rong Shi / Dan Brown, Motorola |  |  |  |
| 383 | 22.5 | FIGS | 385d | 2000-01-03 | 2001-06-22 |  |  | 2000-01-03 | 2001-06-22 | 385d | 552d | finish no earlier than 2001-06-22 | WG SA3 | 3080h |  | SEC1-FIGS | Sec | Rel5 |  | 1595 | SP-000628 |  |  |  |
| 384 | 22.6 | **Enhanced HE control of security (including positive authentication reporting)** | 378d | 2001-01-03 | 2002-06-14 |  |  | 2001-01-03 | 2002-06-14 | 378d | 297d |  | WG SA3 | 6408h |  |  |  | Rel6 |  | 2026 | Peter Howard, Vodafone | Peter.Howard@vf.vodafone.co.uk |  |  |
| 385 | 22.6.1 | Stage 2 | 378d | 2001-01-03 | 2002-06-14 |  |  | 2001-01-03 | 2002-06-14 | 378d | 297d | finish no earlier than 2002-06-14 | WG SA3 | 3024h |  |  |  |  |  | 2027 |  |  |  |  |
| 386 | 22.6.2 | FS on Network impacts | 45d | 2001-09-10 | 2001-11-09 |  |  | 2001-09-10 | 2001-11-09 | 45d | 452d | start no earlier than 2001-09-10 | WG CN4 | 360h |  |  |  |  |  | 2028 |  |  |  |  |
| 387 | 23 | **Miscelleneous UE Conformance Testing Activities** | 520d | 2001-01-01 A | 2002-12-27 | 1% | 513.61d | 2001-01-01 | 2002-12-27 | 520d | 157d |  | WG T1 | 17184h | 211.1h | MISTST1 |  | NA |  | 1861 |  |  |  | Lidia |
| 388 | 23.1 | Optimisation of Test Time, RF Aspects (FDD) | 325d | 2001-09-24 A | 2002-12-20 | 3% | 315d | 2001-01-01 | 2002-03-29 | 325d | 162d | start no earlier than 2001-09-24 | WG T1 | 2600h | 80h | MISTST1-OpFDD |  |  | TSG | 1862 |  |  | 34.121 |  |
| 389 | 23.2 | Optimisation of Test Time, RF Aspects (TDD) | 325d | 2001-09-24 A | 2002-12-20 | 3% | 315d | 2001-01-01 | 2002-03-29 | 325d | 162d | start no earlier than 2001-09-24 | WG T1 | 2600h | 80h | MISTST1-OpTDD |  |  | TSG | 1863 |  |  | 34.122 |  |
| 390 | 23.3 | Extensions to R99 Test cases | 52w | 2001-04-02 | 2002-03-29 |  |  | 2001-04-02 | 2002-03-29 | 52w | 352d | finish no earlier than 2002-03-29 | WG T1 | 2080h |  | MISTST1-Ext |  |  | TSG | 1907 |  |  | 34.123 pts 1,2 |  |
| 391 | 23.4 | Extension to R99 Test cases - TTCN | 66d | 2002-06-28 | 2002-09-27 |  |  | 2002-09-27 | 2002-09-27 | 1d | 222d | finish no earlier than 2002-09-27 | WG T1 | 528h |  | MISTST1-Ext |  |  | TSG |  |  |  |  |  |
| 392 | 23.5 | Creation of R99 TCs for TDD - prose | 66d | 2002-03-29 | 2002-06-28 |  |  | 2002-06-28 | 2002-06-28 | 1d | 287d | finish no earlier than 2002-06-28 | WG T1 | 528h |  | MISTST1-TDD |  |  | TSG |  |  |  | 34.123-1 |  |
| 393 | 23.6 | Creation of R99 TCs for TDD - TTCN | 196d | 2002-03-29 | 2002-12-27 |  |  | 2002-12-27 | 2002-12-27 | 1d | 157d | finish no earlier than 2002-12-27 | WG T1 | 1568h |  | MISTST1-TDD |  |  | TSG |  |  |  |  |  |
| 394 | 23.7 | Review all other work items for impact on new or exiting 34 series specs. | 39w | 2001-07-02 | 2002-03-29 |  |  | 2001-07-02 | 2002-03-29 | 39w | 352d | start no earlier than 2001-07-02 | WG T1 | 1560h |  | MISTST1 |  |  |  | 1908 |  |  | 34.121,122,123,125 |  |
| 395 | 23.8 | Additional signalling tests to cover VHE, OSA, MExE, W/B Telephony AMR & TrFO | 39w | 2001-01-01 | 2001-09-28 |  |  | 2001-01-01 | 2001-09-28 | 39w | 482d | start no earlier than 2001-01-01 | WG T1 | 1560h |  | MISTST1 |  |  |  | 1909 |  |  | 34.123 or 34.125 |  |

Notes:
- 369: TO DELETE: REPLACED BY NDS-MAP and NDS-IP
- 370: Integration of security architecture ,Jun, CRs approved at TSG level, Jun , Definition of security architecture, CRs approved at TSG level Sep
- 372: Requirements capture, Aug , Definition of security architecture, CRs approved at TSG level, Dec. S3#17 behind schedule, Release to be determined S3#18
- 373: S3#17: All due in Rel5. (WI Update at S3#18)
- 375: Specif of protocol stacks for CN interfaces, Aug, Req capture, S3#14, Aug , Def of GTP sig security archi, CRs, S3#15 Sep , Security feature specification, S3#15, Sep , Def of sec archi, Mar 01, Integration of sec archi Feb 01, CRs approved at TSG Jun 01
- 377: S3#17: Not started
- 380: S3#18: Replaces Key Management WI 1586. Related to SEC1-NDS-MAP
- 381: TO DELETE: REPLACED BY NDS-MAP and NDS-IP
- 382: Approved TSG SA#09
- 383: 14/9/00: work behind schedule - WID modification agreed at SA#10
- 384: Added by P-000575 without any dates. 18/10/00: Change of WI title, added hyperlink rapporteur new end date 03/01. New end date and correct Release to be decided S3#18
- 385: New end date and correct Release to be decided S3#18
- 388: It is believed that the current R99 test spec. can be optimised for faster overall test times
- 389: It is believed that the current R99 test spec. can be optimised for faster overall test times
- 390: Further test coverage of the R99 specification to cover supplementry services
- 394: Can't start until most core specs are stable
- 395: Changes to signalling required for new applications layers

| ID | WBS | Task | Duration | Start | Finish | Predecessors | Complete | Remaining | Baseline start | Baseline finish | Baseline duration | Total slack | Constraint | Resources | Work | Actual work | Text1 | Text2 | Text6 | Text7 | Text8 | Text9 | Text3 | Text5 |
| --- | --- | --- | --- | --- | --- | --- | --- | --- | --- | --- | --- | --- | --- | --- | --- | --- | --- | --- | --- | --- | --- | --- | --- | --- |
| 396 | 24 | **Support of Push Services** | 258d | 2001-01-03 A | 2001-12-28 |  | 58% | 109.47d | 2001-01-03 | 2002-03-22 | 318d | 417d |  | WG SA2; WG SA1 | 7032h | 3196.22h | PUSH | CCaR | Rel5 | TSG | Alain | 1365 |  |  |
| 397 | 24.1 | Stage 1 | 258d | 2001-01-03 A | 2001-12-28 |  | 28% | 185d | 2001-01-03 | 2001-12-28 | 258d | 417d | finish no earlier than 2001-12-28 | WG SA1 | 2064h | 584h |  |  |  |  |  |  |  |  |
| 398 | 24.2 | TR on feasibility study | 178d | 2001-01-03 A | 2001-09-07 A |  | 100% |  | 2001-01-03 | 2002-03-22 | 318d |  | finish no earlier than 2001-09-07 | WG SA2 | 1424h | 1424h |  |  |  |  |  |  |  |  |
| 399 | 25 | **Charging and OAM&P (Master)** | 351d | 2000-12-01 A | 2002-04-05 |  | 71% | 101.98d | 2000-12-01 | 2002-03-29 | 346d | 347d |  | WG SA5 | 16080h | 11408.2h | OAM | BCaM | NA | TSG | Adrian |  | 32-series | Albert.Yuhan@voicestream.com; Michael.Truss@MOTOROLA.COM |
| 400 | 25.1 | Rel4 Principles, high level Requirements and Architecture | 145d | 2000-12-01 A | 2001-06-21 A |  | 100% |  | 2000-12-01 | 2001-06-21 | 145d |  | finish no earlier than 2001-06-21 | WG SA5 | 1160h | 1160h | OAM-AR/PR | BCaM | Rel4 | TSG |  | 2089 | 32.101, 32.102 | Michael.Truss@MOTOROLA.COM; Tommy.R.Berggren@TELIA.SE |
| 401 | 25.2 | Rel5 Principles, high level Requirements and Architecture | 145d | 2001-09-17 A | 2002-04-05 |  | 14% | 125d | 2000-12-01 | 2001-06-21 | 145d | 347d | start no earlier than 2001-09-17 | WG SA5 | 1160h | 160h | OAM-AR/PR | BCaM | Rel5 | TSG |  | 2089 | 32.101, 32.102 | Michael.Truss@MOTOROLA.COM; Tommy.R.Berggren@TELIA.SE |
| 402 | 25.3 | Rel4 Performance Management | 216d | 2000-12-01 A | 2001-09-28 A |  | 100% |  | 2000-12-01 | 2001-06-21 | 145d |  | finish no earlier than 2001-06-21 | WG SA5 | 1728h | 1728h | OAM-PM | BCaM | Rel4 | TSG |  | 2088 | 32.4xy | Karl-Heinz.Nenner@T-MOBIL.DE |
| 403 | 25.4 | Rel5 Performance Management | 145d | 2001-09-17 A | 2002-04-05 |  | 10% | 130d | 2000-12-01 | 2001-06-21 | 145d | 347d | start no earlier than 2001-09-17 | WG SA5 | 1160h | 120h | OAM-PM | BCaM | Rel5 | TSG |  | 2088 | 32.4xy | Karl-Heinz.Nenner@T-MOBIL.DE |
| 404 | 25.5 | Fault Management | 221d | 2000-12-01 A | 2001-10-05 A |  | 100% |  | 2000-12-01 | 2001-06-21 | 145d |  | finish no earlier than 2001-06-21 | WG SA5 | 1768h | 1768h | OAM-FM | BCaM | Rel4 | TSG |  | 2081 | 32.111-1/4 | pjure@LUCENT.COM |
| 405 | 25.6 | Configuration Management | 145d | 2000-12-01 A | 2001-06-21 A |  | 100% |  | 2000-12-01 | 2001-06-21 | 145d |  | finish no earlier than 2001-06-21 | WG SA5 | 1160h | 1160h | OAM-CM | BCaM | Rel4 | TSG |  | 2082 | 32.106-1/8 | Thomas.Tovinger@emw.ericsson.se |
| 406 | 25.7 | Rel4 Charging Management | 216d | 2000-12-01 A | 2001-09-28 A |  | 100% |  | 2000-12-01 | 2001-06-21 | 145d |  | finish no earlier than 2001-06-21 | WG SA5 | 1728h | 1728h | OAM-CH | BCaM | Rel4 | TSG |  | 2083 | 32.2xy (Charging) | Karl-Heinz.Nenner@T-MOBIL.DE |
| 407 | 25.8 | Rel5 Charging Management | 145d | 2001-09-10 A | 2002-03-29 |  | 14% | 125d | 2000-12-01 | 2001-06-21 | 145d | 352d | start no earlier than 2001-09-10 | WG SA5 | 1160h | 160h | OAM-CH | BCaM | Rel5 | TSG |  | 2083 | 32.2xy (Charging) | Karl-Heinz.Nenner@T-MOBIL.DE |
| 408 | 25.9 | UTRAN Operations and Maintenance procedures | 145d | 2000-12-01 A | 2001-06-21 A |  | 100% |  | 2000-12-01 | 2001-06-21 | 145d |  | finish no earlier than 2001-06-21 | WG SA5 | 1160h | 1160h | UOAM |  | Rel4 | TSG | Adrian | 2071 | 32.800 | bert.boden@d2mannesmann.de |
| 409 | 25.10 | Network Infrastructure Management | 136d | 2001-09-21 A | 2002-03-29 |  | 25% | 102d |  |  |  | 352d | finish no earlier than 2002-03-29 | WG SA5 | 1088h | 272h | OAM-NIM |  | Rel5 | TSG |  |  | 32.6xy/32.3xy | Thomas.Tovinger@emw.ericsson.se |
| 410 | 26 | Subscription Management | 391d | 2000-12-29 A | 2002-06-28 |  | 42% | 228d | 2000-12-29 | 2001-06-21 | 125d | 287d | finish no earlier than 2002-03-29 | WG SA5 | 3128h | 1304h | SM |  | Rel5 | TSG | Adrian |  | 32.140, 22.057 (S1), 23.057 (T2), 32.101, 32.6xy | Geoff.Caryer@BTINTERNET.COM |
| 411 | 27 | **Intra Domain Connection of RAN Nodes to Multiple CN Nodes** | 580d | 2000-01-03 A | 2002-03-22 |  | 21% | 456.91d | 2000-10-02 | 2002-03-22 | 385d | 357d |  | WG SA2 | 11776h | 2499.17h | IUFLEX |  | Rel5 | TSG | Alain |  | 23.236 |  |
| 412 | 27.1 | Overall System Architecture | 188d | 2001-01-03 A | 2001-09-21 A |  | 100% |  | 2001-01-03 | 2001-09-21 | 188d |  | finish no earlier than 2001-06-01 | WG SA2 | 1504h | 1504h | IUFLEX |  |  | TSG |  | 2244 |  |  |
| 413 | 27.2 | Stage 3: RAN node selecting CN node | 130d | 2001-09-24 | 2002-03-22 | 412 |  |  | 2001-09-24 | 2002-03-22 | 130d | 357d | start no earlier than 2001-09-17 | WG RAN3 | 1040h |  | IUFLEX |  |  |  |  |  |  |  |
| 414 | 27.3 | GERAN work | 210d | 2001-03-12 | 2001-12-28 |  |  |  | 2001-03-12 | 2001-12-28 | 210d | 417d | start no earlier than 2001-03-12 | WG GERAN2 | 1680h |  | IUFLEX |  |  | TSG |  | 2246 | 43.051, 48.008, 48.018 and possibly 44.018 |  |
| 415 | 27.4 | N1 work | 313d | 2000-01-03 | 2001-03-14 |  |  |  | 2001-02-13 | 2001-12-12 | 217d | 624d |  | WG CN1 | 2504h |  | IUFLEX |  |  | TSG |  | 2248 | 24.008 and check 29.018 |  |
| 416 | 27.5 | N4 work | 313d | 2000-10-02 A | 2001-12-12 |  | 18% | 256.09d | 2000-10-02 | 2001-12-12 | 313d | 429d |  | WG CN4 | 2504h | 455.27h | IUFLEX |  |  | TSG |  | 2249 |  |  |
| 417 | 28 | **GERAN improvements 3 (new transport layer on interface A)** | 355d | 2000-11-06 | 2002-03-15 |  |  |  | 2000-11-06 | 2002-03-15 | 355d | 362d |  | TSG GERAN | 11360h |  | GEIMP3 |  | Rel5 | TSG | Paolo | 2320 |  |  |
| 418 | 28.1 | **Evolution of the transport for A** | 355d | 2000-11-06 | 2002-03-15 |  |  |  | 2000-11-06 | 2002-03-15 | 355d | 362d |  | TSG GERAN | 8520h |  | EtA |  |  | TSG | Paolo | 2321 |  |  |
| 419 | 28.1.1 | Definition of a new A/Ater interface Transport Layer option based on the Iu Interface Transport Layer | 355d | 2000-11-06 | 2002-03-15 |  |  |  | 2000-11-06 | 2002-03-15 | 355d | 362d | finish no earlier than 2002-03-15 | TSG GERAN | 2840h |  |  |  |  | TSG |  | 2322 |  |  |
| 420 | 28.1.2 | Adaptation of the Layer 3 BSSMAP procedures as required | 355d | 2000-11-06 | 2002-03-15 |  |  |  | 2000-11-06 | 2002-03-15 | 355d | 362d | finish no earlier than 2002-03-15 | TSG GERAN | 2840h |  |  |  |  | TSG |  | 2323 |  |  |

Notes:
- 396: AS: Changed from FS to actual support of Push / Text4: Yoshinori Kitada, NTT Comware
- 398: Stage 2 on hold, waiting for requirements.
- 399: az: WID appr.SA#10. / Text4: Albert YUHAN (VoiceStream Wireless), Michael TRUSS (Motorola)
- 400: az: WID appr.SA#13. / Text4: Michael TRUSS (Motorola), Tommy BERGGREN (Telia AB)
- 401: az: WID appr.SA#13. / Text4: Michael TRUSS (Motorola), Tommy BERGGREN (Telia AB)
- 402: az: WID appr.SA#12. / Text4: Karl-Heinz NENNER (T-Mobil)
- 403: az: WID appr.SA#12. / Text4: Karl-Heinz NENNER (T-Mobil)
- 404: az: WID appr.SA#10. / Text4: Patrick JURÉ (Lucent Technologies)
- 405: az: WID appr.SA#10. / Text4: Thomas TOVINGER (Ericsson)
- 406: az: WID appr.SA#10. / Text4: Karl-Heinz NENNER (T-Mobil)
- 407: az: WID appr.SA#10. / Text4: Karl-Heinz NENNER (T-Mobil)
- 408: az: WID appr.SA#10. / Text4: Bert Boden (Mannesmann Mobilfunk)
- 409: az: WID appr.SA#13. / Text4: Thomas TOVINGER (Ericsson)
- 410: az: WID appr.SA#10. / Text4: Geoffrey CARYER (BT)
- 411: No clear indication on the end date. Put to Rel5 by AS. / Text4: Stephen Terrill, Ericsson
- 413: Not identified
- 415: Per 30/5: SA2 directions are needed before CN1 can progress.
- 417: BellSouth, Vodafone, Mannesmann, Telia, T-Mobil / Text4: Alain Ohana, BellSouth
- 418: BellSouth, Vodafone, Mannesmann, Telia, T-Mobil / Text4: Alain Ohana, BellSouth

| ID | WBS | Task | Duration | Start | Finish | Complete | Remaining | Baseline start | Baseline finish | Baseline duration | Total slack | Constraint | Resources | Work | Actual work | Text4 | Text6 | Text7 | Text8 | Text9 |
| --- | --- | --- | --- | --- | --- | --- | --- | --- | --- | --- | --- | --- | --- | --- | --- | --- | --- | --- | --- | --- |
| 421 | 29 | **GERAN support for IMS** | 690d | 2000-05-01 A | 2002-12-20 | 32% | 468.97d | 2000-05-01 | 2002-12-20 | 690d | 162d |  | TSG GERAN | 54339.5h | 11975.2h | Shkumbin Hamiti, Nokia | Rel5 | TSG | Paolo |  |
| 422 | 29.1 | **GERAN Header adaptation** | 490d | 2000-05-01 A | 2002-03-15 | 74% | 126.73d | 2000-05-01 | 2002-03-15 | 490d | 362d |  | TSG GERAN; WG SA2; TSG RAN | 13555.1h | 5216.4h | Shkumbin Hamiti, Nokia |  | TSG | Paolo |  |
| 423 | 29.1.1 | Definition of compression and removal modes for PDCP protocol | 22.1d | 2000-05-01 A | 2000-11-10 A | 100% |  | 2000-05-01 | 2000-11-10 | 22.1d |  | finish no earlier than 2000-09-01 | TSG GERAN; WG SA2; TSG RAN | 248.4h | 248.4h |  |  | TSG |  | 2332 |
| 424 | 29.1.2 | Conceptual description in stage 2 | 244.42d | 2000-05-01 A | 2001-04-06 | 88% | 29.29d | 2000-05-01 | 2001-04-06 | 244.42d | 607.58d | finish no earlier than 2001-06-27 | TSG GERAN; WG SA2; TSG RAN | 2424h | 1721.04h |  |  | TSG |  | 2333 |
| 425 | 29.1.3 | Necessary changes on stage 3 regarding header removal | 110.93d | 2000-11-06 A | 2002-03-15 | 38% | 68.33d | 2000-11-06 | 2002-03-15 | 146.73d | 362d | finish no earlier than 2002-03-15 | TSG GERAN; WG SA2; TSG RAN | 1362.67h | 340.8h |  |  | TSG |  |  |
| 426 | 29.2 | **GERAN Radio access bearer design for IMS** | 430d | 2000-11-06 A | 2002-06-28 | 64% | 155.26d | 2000-11-06 | 2002-06-28 | 430d | 287d |  | TSG GERAN; WG SA2; TSG RAN | 18352.4h | 3393.09h | Shkumbin Hamiti, Nokia |  | TSG | Paolo | 2335 |
| 427 | 29.2.1 | **MuM control signalling for conversational multimedia services** | 430d | 2000-11-06 A | 2002-06-28 | 64% | 155.26d | 2000-11-06 | 2002-06-28 | 430d | 287d |  | TSG GERAN; WG SA2; TSG RAN | 9152.4h | 1195.2h |  |  | TSG |  | 2422 |
| 428 | 29.2.1.1 | Identification of requirements | 192.27d | 2000-11-06 A | 2001-08-01 | 77% | 43.87d | 2000-11-06 | 2001-08-01 | 192.27d | 524.73d | finish no earlier than 2001-11-30 | TSG GERAN; WG SA2; TSG RAN | 2240h | 1187.2h |  |  | TSG |  | 2431 |
| 429 | 29.2.1.2 | Necessary modifications due to SIP | 40d | 2002-05-06 | 2002-06-28 |  |  | 2002-05-06 | 2002-06-28 | 40d | 287d | finish no earlier than 2002-06-28 | TSG GERAN; WG SA2; TSG RAN | 960h |  |  |  | TSG |  | 2337 |
| 430 | 29.3 | **Physical layer multiplexing** | 201d | 2000-09-01 A | 2001-06-08 | 38% | 124.94d | 2000-09-01 | 2001-06-08 | 201d | 562d |  | TSG GERAN | 4824h | 1825.56h | Shkumbin Hamiti, Nokia |  | TSG | Paolo | 2338 |
| 431 | 29.3.1 | Stage 2 | 201d | 2000-09-01 A | 2001-06-08 | 38% | 125.25d | 2000-09-01 | 2001-06-08 | 201d | 562d | finish no earlier than 2001-06-08 | TSG GERAN | 1608h | 606h |  |  | TSG |  | 2339 |
| 432 | 29.3.2 | Stage 3 | 201d | 2000-09-01 A | 2001-06-08 | 38% | 124.62d | 2000-09-01 | 2001-06-08 | 201d | 562d | finish no earlier than 2001-06-08 | TSG GERAN | 1608h | 611.04h |  |  | TSG |  | 2432 |
| 433 | 29.4 | **GERAN MS Conformance test for support of IMS** | 400d | 2001-06-11 | 2002-12-20 |  |  | 2001-06-11 | 2002-12-20 | 400d | 162d |  | TSG GERAN | 6400h |  | Shkumbin Hamiti, Nokia |  | TSG | Paolo | 2341 |
| 434 | 29.4.1 | MS test | 400d | 2001-06-11 | 2002-12-20 |  |  | 2001-06-11 | 2002-12-20 | 400d | 162d | finish no earlier than 2002-12-20 | WG GERAN4 | 3200h |  |  |  | TSG |  | 2342 |
| 435 | 29.5 | **GERAN BTS Conformance test for support of IMS** | 400d | 2001-06-11 | 2002-12-20 |  |  | 2001-06-11 | 2002-12-20 | 400d | 162d |  | TSG GERAN | 6400h |  | Shkumbin Hamiti, Nokia |  | TSG | Paolo | 2343 |
| 436 | 29.5.1 | BTS test | 400d | 2001-06-11 | 2002-12-20 |  |  | 2001-06-11 | 2002-12-20 | 400d | 162d | finish no earlier than 2002-12-20 | WG GERAN3 | 3200h |  |  |  | TSG |  | 2344 |
| 437 | 30 | **Alignment of 3G functional split and Iu** | 713.25d | 2000-06-08 A | 2003-03-04 | 16% | 600.92d | 2000-06-08 | 2003-03-04 | 713.25d | 110.75d |  | TSG GERAN | 172432h | 30385.4h | Frank Muller, Ericsson | Rel5 | TSG | Paolo | 2345 |
| 438 | 30.1 | **GERAN user / control plane** | 683.75d | 2000-07-19 A | 2003-03-04 | 7% | 633.07d | 2000-07-19 | 2003-03-04 | 683.75d | 110.75d |  | TSG GERAN | 54770h | 5853.99h | Frank Muller, Ericsson |  | TSG | Paolo | 2346 |
| 439 | 30.1.1 | **Alignment with UMTS bearer concept** | 683.75d | 2000-07-19 A | 2003-03-04 | 3% | 662.32d | 2000-07-19 | 2003-03-04 | 683.75d | 110.75d |  | TSG GERAN | 42440h | 2896h |  |  | TSG |  | 2347 |
| 440 | 30.1.1.1 | Enhanced power control | 1d | 2001-08-31 A | 2001-08-31 A | 100% |  | 2001-08-31 | 2001-08-31 | 1d |  | finish no earlier than 2001-08-31 | TSG GERAN | 8h | 8h |  |  | TSG |  |  |
| 441 | 30.1.1.2 | Stage 2 | 235d | 2000-08-07 A | 2001-06-29 | 60% | 94d | 2000-08-07 | 2001-06-29 | 235d | 547d | finish no earlier than 2001-06-29 | TSG GERAN | 1880h | 1128h |  |  | TSG |  | 2423 |
| 442 | 30.1.1.3 | Adoption of the UTRAN PDCP | 419d | 2000-11-06 | 2002-06-13 |  |  | 2000-11-06 | 2002-06-13 | 419d | 298d | finish no earlier than 2002-06-13 | TSG GERAN | 3352h |  |  |  | TSG |  | 2348 |
| 443 | 30.1.1.4 | Development of RLC / MAC | 464.5d | 2000-11-06 | 2002-08-16 |  |  | 2000-11-06 | 2002-08-16 | 464.5d | 252.5d | finish no earlier than 2002-08-16 | WG GERAN2 | 3716h |  |  |  | TSG |  | 2349 |
| 444 | 30.1.1.5 | Development of GERAN RRC | 606.25d | 2000-11-06 | 2003-03-04 |  |  | 2000-11-06 | 2003-03-04 | 606.25d | 110.75d | finish no earlier than 2003-03-04 | WG GERAN2 | 4850h |  |  |  | TSG |  | 2350 |
| 445 | 30.1.1.6 | Ciphering and integrity protection Concept paper | 335.5d | 2000-07-19 | 2001-10-31 |  |  | 2000-07-19 | 2001-10-31 | 335.5d | 459d | finish no earlier than 2001-10-31 | WG GERAN2 | 2684h |  |  |  | TSG |  | 2351 |
| 446 | 30.1.1.7 | Multiple TBF or equivalent Concept paper | 258d | 2000-11-06 | 2001-10-31 |  |  | 2000-11-06 | 2001-10-31 | 258d | 459d | finish no earlier than 2001-10-31 | WG GERAN2 | 2064h |  |  |  | TSG |  |  |
| 447 | 30.1.1.8 | Paging concept | 258d | 2000-11-06 | 2001-10-31 |  |  | 2000-11-06 | 2001-10-31 | 258d | 459d | finish no earlier than 2001-10-31 | WG GERAN2 | 2064h |  |  |  | TSG |  |  |
| 448 | 30.1.1.9 | Dedicated physical subchannels. Includes traffic and control channels | 103.25d | 2001-03-29 | 2001-08-21 |  |  | 2001-03-29 | 2001-08-21 | 103.25d | 510.5d | finish no earlier than 2001-08-21 | WG GERAN2; WG GERAN1 | 1652h |  |  |  | TSG |  | 2352 |
| 449 | 30.1.1.10 | Iu support and broadcast concept | 280d | 2000-11-06 | 2001-11-30 |  |  | 2000-11-06 | 2001-11-30 | 280d | 437d | finish no earlier than 2001-11-30 | WG GERAN1, WG GERAN2 | 2240h |  |  |  | TSG |  | 2353 |
| 450 | 30.1.1.11 | Impact of using RLC instead of LAPDm concept | 258d | 2000-11-06 | 2001-10-31 |  |  | 2000-11-06 | 2001-10-31 | 258d | 459d | finish no earlier than 2001-10-31 | WG GERAN1, WG GERAN2 | 2064h |  |  |  | TSG |  | 2354 |
| 451 | 30.1.1.12 | Contention resolution, mobile station identity, and access concept | 258d | 2000-11-06 | 2001-10-31 |  |  | 2000-11-06 | 2001-10-31 | 258d | 459d | finish no earlier than 2001-10-31 | WG GERAN2 | 2064h |  |  |  | TSG |  | 2355 |
| 452 | 30.1.1.13 | PDCP concept | 258d | 2000-11-06 | 2001-10-31 |  |  | 2000-11-06 | 2001-10-31 | 258d | 459d | finish no earlier than 2001-10-31 | WG GERAN1, WG GERAN2 | 2064h |  |  |  |  |  |  |
| 453 | 30.1.1.14 | Downlink delayedTBF release | 258d | 2000-11-06 | 2001-10-31 |  |  | 2000-11-06 | 2001-10-31 | 258d | 459d | finish no earlier than 2001-10-31 | WG GERAN2 | 2064h |  |  |  |  |  |  |
| 454 | 30.1.1.15 | Add transparent RLC Concept | 258d | 2000-11-06 | 2001-10-31 |  |  | 2000-11-06 | 2001-10-31 | 258d | 459d | finish no earlier than 2001-10-31 | WG GERAN2 | 2064h |  |  |  |  |  |  |
| 455 | 30.1.1.16 | Handover concept | 280d | 2000-11-06 | 2001-11-30 |  |  | 2000-11-06 | 2001-11-30 | 280d | 437d | finish no earlier than 2001-11-30 | WG GERAN2 | 2240h |  |  |  |  |  |  |

Notes:
- 421: AWS, Nokia, Ericsson, Nortel, Siemens, Motorola
- 422: AWS, Nokia, Ericsson, Nortel, Siemens, Motorola
- 426: AWS, Nokia, Ericsson, Nortel, Siemens, Motorola
- 430: AWS, Nokia, Ericsson, Nortel, Siemens, Motorola
- 433: AWS, Nokia, Ericsson, Nortel, Siemens, Motorola
- 435: AWS, Nokia, Ericsson, Nortel, Siemens, Motorola
- 437: AWS, Nokia, Ericsson, Nortel, Siemens, Vodafone
- 438: AWS, Nokia, Ericsson, Nortel, Siemens, Vodafone
- 442: Responsible is GERAN; RAN WG2 help may be needed.

| ID | WBS | Task | Duration | Start | Finish | Complete | Remaining | Baseline start | Baseline finish | Baseline duration | Total slack | Constraint | Resources | Work | Actual work | Text7 | Text9 | Text4 | Text8 |
| --- | --- | --- | --- | --- | --- | --- | --- | --- | --- | --- | --- | --- | --- | --- | --- | --- | --- | --- | --- |
| 456 | 30.1.2 | **Physical layer alignment with UMTS bearer concept** | 280d | 2000-11-06 A | 2001-11-30 | 40% | 167.29d | 2000-11-06 | 2001-11-30 | 280d | 437d |  | TSG GERAN | 6960h | 2560h | TSG | 2424 |  |  |
| 457 | 30.1.2.1 | PDTCH/TCH in 45.003 | 155d | 2000-11-06 A | 2001-06-08 | 53% | 72.5d | 2000-11-06 | 2001-06-08 | 155d | 562d | finish no earlier than 2001-06-08 | TSG GERAN | 1240h | 660h | TSG | 2356 |  |  |
| 458 | 30.1.2.2 | Control channels in 45.003 | 155d | 2000-11-06 A | 2001-06-08 A | 100% |  | 2000-11-06 | 2001-06-08 | 155d |  | finish no earlier than 2001-06-08 | TSG GERAN | 1240h | 1240h | TSG | 2357 |  |  |
| 459 | 30.1.2.3 | Receiver performance in 45.005 for PDTCH/TCH and control channels | 280d | 2000-11-06 | 2001-11-30 |  |  | 2000-11-06 | 2001-11-30 | 280d | 437d | finish no earlier than 2001-11-30 | TSG GERAN | 2240h |  | TSG | 2358 |  |  |
| 460 | 30.2 | **Iu rg interface** | 430d | 2000-11-06 A | 2002-06-28 | 34% | 283.28d | 2000-11-06 | 2002-06-28 | 430d | 287d |  | TSG GERAN | 46440h | 16037h | TSG | 2359 | Frank Muller, Ericsson | Paolo |
| 461 | 30.2.1 | **Inter BSS interface** | 430d | 2000-11-06 A | 2002-06-28 | 24% | 326.8d | 2000-11-06 | 2002-06-28 | 430d | 287d |  | TSG GERAN | 20640h | 4953.6h |  | 2425 |  |  |
| 462 | 30.2.1.1 | Identification of requirements | 430d | 2000-11-06 A | 2002-06-28 A | 100% |  | 2000-11-06 | 2002-06-28 | 430d |  | finish no earlier than 2001-01-19 | TSG GERAN | 3440h | 3440h |  | 2360 |  |  |
| 463 | 30.2.1.2 | Stage 2 | 430d | 2000-11-06 A | 2002-06-28 | 20% | 344d | 2000-11-06 | 2002-06-28 | 430d | 287d | finish no earlier than 2002-06-28 | TSG GERAN | 3440h | 688h |  | 2361 |  |  |
| 464 | 30.2.1.3 | Adoption of relevant parts from Iur | 430d | 2000-11-06 | 2002-06-28 |  |  | 2000-11-06 | 2002-06-28 | 430d | 287d | finish no earlier than 2002-06-28 | TSG GERAN | 3440h |  |  | 2362 |  |  |
| 465 | 30.2.1.4 | Complementation with GERAN specifics | 430d | 2000-11-06 | 2002-06-28 |  |  | 2000-11-06 | 2002-06-28 | 430d | 287d | finish no earlier than 2002-06-28 | TSG GERAN | 3440h |  |  | 2363 |  |  |
| 466 | 30.2.1.5 | New stage 3 | 430d | 2000-11-06 | 2002-06-28 |  |  | 2000-11-06 | 2002-06-28 | 430d | 287d | finish no earlier than 2002-06-28 | TSG GERAN | 3440h |  |  | 2364 |  |  |
| 467 | 30.2.2 | **Inter BSS-RNS interface** | 430d | 2000-11-06 A | 2002-06-28 | 55% | 193.19d | 2000-11-06 | 2002-06-28 | 430d | 287d |  | TSG GERAN; WG RAN3 | 22360h | 9909.69h |  | 2426 |  |  |
| 468 | 30.2.2.1 | Identification of requirements | 430d | 2000-11-06 A | 2002-06-28 A | 100% |  | 2000-11-06 | 2002-06-28 | 430d |  | start no earlier than 2000-11-06 | TSG GERAN; WG RAN3 | 6880h | 6880h |  | 2365 |  |  |
| 469 | 30.2.2.2 | Stage 2 | 285.95d | 2000-11-06 A | 2002-06-28 | 50% | 144.05d | 2000-11-06 | 2002-06-28 | 285.95d | 287d | finish no earlier than 2002-06-28 | TSG GERAN; WG RAN3 | 3440h | 1135.2h |  | 2366 |  |  |
| 470 | 30.2.2.3 | Adoption of relevant parts from Iur | 107.5d | 2002-01-30 | 2002-06-28 |  |  | 2002-01-30 | 2002-06-28 | 107.5d | 287d | finish no earlier than 2002-06-28 | TSG GERAN; WG RAN3 | 1720h |  |  | 2367 |  |  |
| 471 | 30.2.2.4 | Complementation with GERAN specifics | 107.5d | 2002-01-30 | 2002-06-28 |  |  | 2002-01-30 | 2002-06-28 | 107.5d | 287d | finish no earlier than 2002-06-28 | TSG GERAN; WG RAN3 | 1720h |  |  | 2368 |  |  |
| 472 | 30.2.2.5 | New stage 3 | 107.5d | 2002-01-30 | 2002-06-28 |  |  | 2002-01-30 | 2002-06-28 | 107.5d | 287d | finish no earlier than 2002-06-28 | TSG GERAN; WG RAN3 | 1720h |  |  | 2369 |  |  |
| 473 | 30.3 | **Voice over GERAN PS and CS concept** | 365d | 2000-11-06 A | 2002-03-29 | 32% | 246.84d | 2000-11-06 | 2002-03-29 | 365d | 352d |  | TSG GERAN; WG RAN3 | 18900h | 3734.11h |  | 2370 |  | Paolo |
| 474 | 30.3.1 | Architecture for A, Iu cs and Iu ps | 211.7d | 2000-11-06 A | 2002-03-29 | 28% | 153.3d | 2000-11-06 | 2002-03-29 | 211.7d | 352d | finish no earlier than 2002-03-29 | TSG GERAN; WG RAN3 | 2920h | 467.2h |  | 2371 |  |  |
| 475 | 30.3.2 | Transcoder position/operation | 115d | 2000-11-06 A | 2001-04-13 | 50% | 57.5d | 2000-11-06 | 2001-04-13 | 115d | 602d | finish no earlier than 2001-01-19 | TSG GERAN | 920h | 460h |  | 2372 |  |  |
| 476 | 30.3.3 | Handover | 211.7d | 2000-11-06 A | 2002-03-29 | 28% | 153.3d | 2000-11-06 | 2002-03-29 | 211.7d | 352d | finish no earlier than 2002-03-29 | TSG GERAN; WG RAN3 | 2920h | 467.2h |  | 2373 |  |  |
| 477 | 30.3.4 | RTP payload | 211.7d | 2000-11-06 A | 2002-03-29 | 28% | 153.3d | 2000-11-06 | 2002-03-29 | 211.7d | 352d | finish no earlier than 2002-03-29 | TSG GERAN; WG RAN3 | 2920h | 467.2h |  | 2374 |  |  |
| 478 | 30.3.5 | Codec renegotiation concept | 211.7d | 2000-11-06 A | 2002-03-29 | 28% | 153.3d | 2000-11-06 | 2002-03-29 | 211.7d | 352d | finish no earlier than 2002-03-29 | TSG GERAN; WG RAN3 | 2920h | 467.2h |  | 2375 |  |  |
| 479 | 30.3.6 | LA | 115d | 2000-11-06 A | 2001-04-13 | 50% | 57.5d | 2000-11-06 | 2001-04-13 | 115d | 602d | finish no earlier than 2001-01-19 | TSG GERAN | 920h | 460h |  | 2376 |  |  |

Notes:
- 460: AWS, Nokia, Ericsson, Nortel, Siemens, Vodafone

| ID | WBS | Task | Duration | Start | Finish | Complete | Remaining | Baseline start | Baseline finish | Baseline duration | Total slack | Constraint | Resources | Work | Actual work | Text8 | Text9 | Text6 | Text4 |
| --- | --- | --- | --- | --- | --- | --- | --- | --- | --- | --- | --- | --- | --- | --- | --- | --- | --- | --- | --- |
| 480 | 30.4 | **GERAN Narrowband speech realization** | 365d | 2000-11-06 A | 2002-03-29 | 8% | 334.33d | 2000-11-06 | 2002-03-29 | 365d | 352d |  | TSG GERAN | 30280h | 3914.54h | Paolo | 2377 |  |  |
| 481 | 30.4.1 | **8-PSK NB HR** | 365d | 2000-11-06 A | 2002-03-29 | 10% | 326.93d | 2000-11-06 | 2002-03-29 | 365d | 352d |  | TSG GERAN; WG GERAN1 | 20240h | 3024.54h |  | 2427 |  |  |
| 482 | 30.4.1.1 | Channel coding in 45.003 | 170d | 2000-11-06 A | 2001-06-29 A | 100% |  | 2000-11-06 | 2001-06-29 | 170d |  | finish no earlier than 2001-06-29 | TSG GERAN; WG GERAN1 | 2720h | 2720h |  | 2378 |  |  |
| 483 | 30.4.1.2 | Signallimg for A interface | 365d | 2000-11-06 | 2002-03-29 |  |  | 2000-11-06 | 2002-03-29 | 365d | 352d | finish no earlier than 2002-03-29 | WG GERAN1 | 2920h |  |  | 2379 |  |  |
| 484 | 30.4.1.3 | Signallimg for Iu | 365d | 2000-11-06 | 2002-03-29 |  |  | 2000-11-06 | 2002-03-29 | 365d | 352d | finish no earlier than 2002-03-29 | WG GERAN1 | 2920h |  |  | 2380 |  |  |
| 485 | 30.4.1.4 | Link adaptation in 45.009 | 365d | 2000-11-06 | 2002-03-29 |  |  | 2000-11-06 | 2002-03-29 | 365d | 352d | finish no earlier than 2002-03-29 | WG GERAN1 | 2920h |  |  | 2381 |  |  |
| 486 | 30.4.1.5 | Receiver performance in 45.005 | 365d | 2000-11-06 | 2002-03-29 |  |  | 2000-11-06 | 2002-03-29 | 365d | 352d | finish no earlier than 2002-03-29 | WG GERAN1 | 2920h |  |  | 2382 |  |  |
| 487 | 30.4.2 | **8-PSK NB QR** | 155d | 2000-11-06 A | 2001-06-08 | 4% | 148.94d | 2000-11-06 | 2001-06-08 | 155d | 562d |  | TSG GERAN | 7120h | 890h |  | 2428 |  |  |
| 488 | 30.4.2.1 | Channel coding in 45.003 | 115d | 2000-11-06 A | 2001-04-13 | 25% | 86.25d | 2000-11-06 | 2001-04-13 | 115d | 602d | finish no earlier than 2001-04-13 | TSG GERAN | 920h | 230h |  | 2383 |  |  |
| 489 | 30.4.2.2 | Signallimg for A interface | 155d | 2000-11-06 | 2001-06-08 |  |  | 2000-11-06 | 2001-06-08 | 155d | 562d | start no earlier than 2000-11-06 | TSG GERAN | 1240h |  |  | 2384 |  |  |
| 490 | 30.4.2.3 | Signallimg for Iu | 155d | 2000-11-06 | 2001-06-08 |  |  | 2000-11-06 | 2001-06-08 | 155d | 562d | start no earlier than 2000-11-06 | TSG GERAN | 1240h |  |  | 2385 |  |  |
| 491 | 30.4.2.4 | Link adaptation in 45.009 | 155d | 2000-11-06 | 2001-06-08 |  |  | 2000-11-06 | 2001-06-08 | 155d | 562d | start no earlier than 2000-11-06 | TSG GERAN | 1240h |  |  | 2386 |  |  |
| 492 | 30.4.2.5 | Receiver performance in 45.005 | 155d | 2000-11-06 | 2001-06-08 |  |  | 2000-11-06 | 2001-06-08 | 155d | 562d | start no earlier than 2000-11-06 | TSG GERAN | 1240h |  |  | 2387 |  |  |
| 493 | 30.5 | **GERAN MS Conformance test for GERAN interface evolution** | 390d | 2001-06-11 | 2002-12-06 |  |  | 2001-06-11 | 2002-12-06 | 390d | 172d |  | TSG GERAN | 6240h |  | Paolo | 2388 |  |  |
| 494 | 30.5.1 | MS test | 390d | 2001-06-11 | 2002-12-06 |  |  | 2001-06-11 | 2002-12-06 | 390d | 172d | finish no earlier than 2002-12-06 | TSG GERAN | 3120h |  |  | 2389 |  |  |
| 495 | 30.6 | **GERAN MS Conformance test for GERAN interface evolution** | 652d | 2000-06-08 | 2002-12-06 |  |  | 2000-06-08 | 2002-12-06 | 652d | 172d |  | TSG GERAN | 10432h |  | Paolo | 2390 |  |  |
| 496 | 30.6.1 | BSS test | 652d | 2000-06-08 | 2002-12-06 |  |  | 2000-06-08 | 2002-12-06 | 652d | 172d | finish no earlier than 2002-12-06 | TSG GERAN | 5216h |  |  | 2391 |  |  |
| 497 | 31 | **GERAN enhancements for streaming services 1** | 280d | 2000-11-06 A | 2001-11-30 | 21% | 221d | 2000-11-06 | 2001-11-30 | 280d | 437d |  | TSG GERAN | 8784h | 1850.84h | Paolo | 2392 | Rel5 |  |
| 498 | 31.1 | **GERAN enhancements for streaming services 1** | 280d | 2000-11-06 A | 2001-11-30 | 21% | 221d | 2000-11-06 | 2001-11-30 | 280d | 437d |  | TSG GERAN | 6544h | 1378.86h | Paolo | 2393 |  | Krishna Balachandran, Lucent |
| 499 | 31.1.1 | Concept | 258d | 2000-11-06 A | 2001-10-31 | 32% | 175.44d | 2000-11-06 | 2001-10-31 | 258d | 459d | finish no earlier than 2001-10-31 | TSG GERAN | 2064h | 660.48h |  | 2394 |  |  |
| 500 | 31.1.2 | RLC protocol enhancement (SDU Discard) | 280d | 2000-11-06 A | 2001-11-30 | 11% | 249.2d | 2000-11-06 | 2001-11-30 | 280d | 437d | finish no earlier than 2001-11-30 | TSG GERAN | 2240h | 246.4h |  | 2395 |  |  |
| 501 | 32 | **GERAN enhancements for streaming services 2** | 430d | 2000-11-06 A | 2002-06-28 | 9% | 389.58d | 2000-11-06 | 2002-06-28 | 430d | 287d |  | TSG GERAN | 24080h | 1616.8h | Paolo | 2396 | Rel5 | Frank Muller, Ericsson |
| 502 | 32.1 | **GERAN enhancements for streaming services 2** | 430d | 2000-11-06 A | 2002-06-28 | 9% | 389.58d | 2000-11-06 | 2002-06-28 | 430d | 287d |  | TSG GERAN | 20640h | 1616.8h | Paolo | 2397 |  | Frank Muller, Ericsson |
| 503 | 32.1.1 | Usage of ECSD Concept | 430d | 2000-11-06 A | 2002-06-28 | 19% | 348.3d | 2000-11-06 | 2002-06-28 | 430d | 287d | finish no earlier than 2002-06-28 | TSG GERAN | 3440h | 653.6h |  | 2398 |  |  |
| 504 | 32.1.2 | Stage 2 | 430d | 2000-11-06 A | 2002-06-28 | 7% | 399.9d | 2000-11-06 | 2002-06-28 | 430d | 287d | finish no earlier than 2002-06-28 | TSG GERAN | 3440h | 240.8h |  | 2399 |  |  |
| 505 | 32.1.3 | Stage 3 | 430d | 2000-11-06 A | 2002-06-28 | 7% | 399.9d | 2000-11-06 | 2002-06-28 | 430d | 287d | finish no earlier than 2002-06-28 | TSG GERAN | 3440h | 240.8h |  | 2400 |  |  |
| 506 | 32.1.4 | RLC PDU formats | 430d | 2000-11-06 A | 2002-06-28 | 7% | 399.9d | 2000-11-06 | 2002-06-28 | 430d | 287d | finish no earlier than 2002-06-28 | TSG GERAN | 3440h | 240.8h |  | 2401 |  |  |
| 507 | 32.1.5 | MAC header | 430d | 2000-11-06 A | 2002-06-28 | 7% | 399.9d | 2000-11-06 | 2002-06-28 | 430d | 287d | finish no earlier than 2002-06-28 | TSG GERAN | 3440h | 240.8h |  | 2402 |  |  |

Notes:
- 498: Lucent, Ericsson, AWS, Nortel
- 501: AWS, Nokia, Ericsson, Nortel, Siemens, Motorola, Vodafone
- 502: AWS, Nokia, Ericsson, Nortel, Siemens, Motorola, Vodafone

| ID | WBS | Task | Duration | Start | Finish | Predecessors | Complete | Remaining | Baseline start | Baseline finish | Baseline duration | Total slack | Free slack | Constraint | Resources | Work | Actual work | Text4 | Text6 | Text8 | Text9 | Text1 | Text7 | Text3 | Text5 |
| --- | --- | --- | --- | --- | --- | --- | --- | --- | --- | --- | --- | --- | --- | --- | --- | --- | --- | --- | --- | --- | --- | --- | --- | --- | --- |
| 508 | 33 | **GERAN/UTRAN interface evolution 1 (evolution of Iu PS)** | 355d | 2000-11-06 A | 2002-03-15 |  | 58% | 150.1d | 2000-11-06 | 2002-03-15 | 355d | 362d |  |  | TSG GERAN; WG RAN3 | 12580h | 4308.84h | Marc Grant , SBC | Rel5 | Paolo | 2412 |  |  |  |  |
| 509 | 33.1 | **Evolution of Iu ps** | 355d | 2000-11-06 A | 2002-03-15 |  | 58% | 150.1d | 2000-11-06 | 2002-03-15 | 355d | 362d |  |  | TSG GERAN; WG RAN3 | 7560h | 2669.62h |  |  |  | 2413 |  |  |  |  |
| 510 | 33.1.1 | Identification of GERAN requirements on Iu ps | 204.4d | 2000-11-06 A | 2001-08-17 |  | 63% | 75.6d | 2000-11-06 | 2001-08-17 | 204.4d | 493.85d | 131.85d | finish no earlier than 2001-11-30 | TSG GERAN; WG RAN3 | 2240h | 1030.4h |  |  |  | 2414 |  |  |  |  |
| 511 | 33.1.2 | Update of specifications | 18.75d | 2002-02-19 | 2002-03-15 | 510 |  |  | 2002-02-19 | 2002-03-15 | 18.75d | 362d |  | finish no earlier than 2002-03-15 | TSG GERAN; WG RAN3 | 300h |  |  |  |  | 2415 |  |  |  |  |
| 512 | 34 | **GERAN/UTRAN interface evolution 2 (evolution of Iu CS)** | 355d | 2000-11-06 A | 2002-03-15 |  | 48% | 182.88d | 2000-11-06 | 2002-03-15 | 355d | 362d |  |  | TSG GERAN; WG RAN3 | 11980h | 3163.73h |  | Rel5 | Paolo | 2416 |  |  |  |  |
| 513 | 34.1 | **Evolution of Iu cs** | 355d | 2000-11-06 A | 2002-03-15 |  | 48% | 182.88d | 2000-11-06 | 2002-03-15 | 355d | 362d |  |  | TSG GERAN; WG RAN3 | 7600h | 2097.07h | Krishna Balachandran, Lucent |  | Paolo | 2417 |  |  |  |  |
| 514 | 34.1.1 | Identification of GERAN requirements on Iu cs | 204.4d | 2000-11-06 A | 2001-08-17 |  | 63% | 75.6d | 2000-11-06 | 2001-08-17 | 204.4d | 512.6d |  | finish no earlier than 2001-11-30 | TSG GERAN; WG RAN3 | 2240h | 1030.4h |  |  |  | 2418 |  |  |  |  |
| 515 | 34.1.2 | Update of specifications | 61.25d | 2001-12-20 | 2002-03-15 |  |  |  | 2001-12-20 | 2002-03-15 | 61.25d | 362d |  | finish no earlier than 2002-03-15 | TSG GERAN; WG RAN3 | 980h |  |  |  |  | 2419 |  |  |  |  |
| 516 | 35 | **Support of Presence Capability** | 262d | 2001-03-19 A | 2002-03-19 |  | 17% | 216.66d | 2001-03-19 | 2002-03-19 | 262d | 360d |  |  | WG SA1 | 6408h | 999.5h | Mark Cataldo, Motorola | Rel5 | Micheal C | 11004 | PRESNC | TSG |  |  |
| 517 | 35.1 | Stage 1 | 88d | 2001-03-19 A | 2001-07-18 |  | 70% | 26.4d | 2001-03-19 | 2001-07-18 | 88d | 534d |  | finish no earlier than 2001-07-18 | WG SA1 | 704h | 492.8h |  |  |  | 11005 |  |  |  |  |
| 518 | 35.2 | Stage 2 | 135d | 2001-09-12 A | 2002-03-19 |  | 13% | 117d | 2001-09-12 | 2002-03-19 | 135d | 360d |  | finish no earlier than 2002-03-19 | WG SA2 | 1080h | 144h |  |  |  |  |  | TSG |  |  |
| 519 | 35.3 | **Stage 3** | 79d | 2001-09-03 | 2001-12-20 |  |  |  | 2001-09-03 | 2001-12-20 | 79d | 423d |  |  | TSG CN | 2528h |  |  |  |  |  |  |  |  |  |
| 520 | 35.3.1 | Security issues | 79d | 2001-09-03 | 2001-12-20 |  |  |  | 2001-09-03 | 2001-12-20 | 79d | 423d |  | finish no earlier than 2001-12-20 | WG SA3 | 632h |  |  |  |  |  |  |  |  |  |
| 521 | 35.3.2 | USIM issues | 79d | 2001-09-03 | 2001-12-20 |  |  |  | 2001-09-03 | 2001-12-20 | 79d | 423d |  | finish no earlier than 2001-12-20 | WG T3 | 632h |  |  |  |  |  |  |  |  |  |
| 522 | 35.3.3 | UE issues | 79d | 2001-09-03 | 2001-12-20 |  |  |  | 2001-09-03 | 2001-12-20 | 79d | 423d |  | finish no earlier than 2001-12-20 | WG T2 | 632h |  |  |  |  |  |  |  |  |  |
| 523 | 36 | **Display of Service Provider name on UE** | 351d | 2000-12-25 A | 2002-04-29 |  | 21% | 277.22d | 2000-12-25 | 2002-04-29 | 351d | 331d |  |  | WG SA1 | 6104h | 1150.27h | Michele Zarri, One to One | Rel5 | Micheal C | 11002 | SPNAME | TSG |  |  |
| 524 | 36.1 | Stage 1 | 88d | 2000-12-25 A | 2001-04-25 |  | 80% | 18d | 2000-12-25 | 2001-04-25 | 88d | 428d | 97d | start no earlier than 2000-12-25 | WG SA1 | 704h | 560h |  |  |  | 11003 |  |  | 22.101, 22.042 |  |
| 525 | 36.2 | del if not in WID - Stage 2 | 87d | 2001-09-10 | 2002-01-08 | 524 |  |  | 2001-09-10 | 2002-01-08 | 87d | 331d | 0d | finish no earlier than 2002-01-08 | WG SA2 | 696h |  |  |  |  |  |  |  |  |  |
| 526 | 36.3 | **Stage 3** | 79d | 2002-01-09 | 2002-04-29 | 525 |  |  | 2002-01-09 | 2002-04-29 | 79d | 331d |  |  | TSG CN | 1896h |  |  |  |  |  |  |  |  |  |
| 527 | 36.3.1 | Security issues | 79d | 2002-01-09 | 2002-04-29 |  |  |  | 2002-01-09 | 2002-04-29 | 79d | 331d |  | finish no earlier than 2001-12-20 | WG SA3 | 632h |  |  |  |  |  |  |  |  |  |
| 528 | 36.3.2 | USIM issues | 79d | 2002-01-09 | 2002-04-29 |  |  |  | 2002-01-09 | 2002-04-29 | 79d | 331d |  | finish no earlier than 2001-12-20 | WG T3 | 632h |  |  |  |  |  |  |  |  |  |
| 529 | 37 | **User Equipment Management** | 202d | 2001-06-21 A | 2002-03-29 |  | 36% | 130d | 2001-06-25 | 2002-06-28 | 265d | 352d |  |  | WG SA5 | 3232h | 1152h | John Mudge (Vodafone) | Rel5 | Adrian |  | UEM | TSG |  | john.mudge@vf.vodafone.co.uk |
| 530 | 37.1 | FS on User Equipment (UE) Management | 202d | 2001-06-21 A | 2002-03-29 |  | 36% | 130d | 2001-06-21 | 2002-03-29 | 202d | 352d |  | finish no earlier than 2002-03-29 | WG SA5 | 1616h | 576h | John Mudge (Vodafone) |  | Adrian |  | OAM-UEM | TSG | 32.802 | john.mudge@VF.VODAFONE.CO.UK |
| 531 | 38 | **Emergency calls without UICC/SIM in netw. with IMS** | 584d | 2000-01-03 | 2002-03-28 |  |  |  | 2001-05-30 | 2002-03-28 | 217d | 353d |  |  | WG SA2 | 5680h |  |  | Rel5 | Alain |  |  |  |  |  |
| 532 | 38.1 | Stage 2 | 1d | 2000-01-03 | 2000-01-03 |  |  |  |  |  |  | 936d |  |  | WG SA2 | 8h |  |  |  |  |  |  |  |  |  |
| 533 | 38.2 | Stage 3 work for CN1 | 217d | 2001-05-30 | 2002-03-28 |  |  |  | 2001-05-30 | 2002-03-28 | 217d | 353d |  | start no earlier than 2001-05-30 | WG CN1 | 1736h |  |  |  |  |  |  |  |  |  |

Notes:
- 508: SBC, Motorola, Nokia, Ericsson, Nortel
- 513: Lucent, Ericsson, AWS, Nortel
- 529: az: WID appr.SA#12.
- 530: az: WID appr.SA#12.
- 531: Per 30/5: This WID was approved in SA#11 as a feature. SA2 work on 23.221, 23.060 and 23.228 is targeted for TSG#13. The stage 3 work (mostly CN1?) is targeted for TSG#15 (March 2002)

| ID | WBS | Task | Duration | Start | Finish | Complete | Remaining | Baseline start | Baseline finish | Baseline duration | Total slack | Constraint | Resources | Work | Actual work | Text1 | Text6 | Text8 | Text9 | Text7 | Text5 | Text2 |
| --- | --- | --- | --- | --- | --- | --- | --- | --- | --- | --- | --- | --- | --- | --- | --- | --- | --- | --- | --- | --- | --- | --- |
| 534 | 39 | **Multimedia Broadcast and Multimedia Service** | 296d | 2001-05-11 A | 2002-06-28 | 29% | 211.25d | 2001-05-11 | 2002-06-28 | 296d | 287d |  | WG SA1 | 7353.6h | 1507.2h | MBMS | Rel6 | Michael C. |  |  |  |  |
| 535 | 39.1 | Stage 1 | 232d | 2001-05-11 A | 2002-04-01 | 70% | 69.6d | 2001-05-11 | 2002-04-01 | 232d | 351d | finish no earlier than 2002-04-01 | WG SA1 | 1856h | 1299.2h |  |  | Micheal C | 11003 |  |  |  |
| 536 | 39.2 | Stage 2 | 171d | 2001-08-31 A | 2002-04-26 | 15% | 145d | 2001-08-31 | 2002-04-26 | 171d | 332d | finish no earlier than 2002-04-26 | WG SA2 | 1368h | 208h |  |  |  |  | TSG |  |  |
| 537 | 39.3 | Enhancement of Broadcast and Introduction of Multicast Capabilities in RAN | 255d | 2001-07-09 | 2002-06-28 |  |  | 2001-07-09 | 2002-06-28 | 255d | 287d | finish no earlier than 2002-06-28 | WG RAN2 | 2040h |  |  |  |  | 2481 | TSG |  |  |
| 538 | 40 | **End to End QoS for PS Domain including IMS** | 323d | 2001-01-03 A | 2002-03-29 | 54% | 149.87d | 2001-01-03 | 2002-03-08 | 308d | 352d |  | WG SA2 | 6784h | 3636.22h | E2EQoS | Rel5 | Alain |  | TSG | Johnson.oyama@era.ericcson.se |  |
| 539 | 40.1 | E2E QoSConcept and Architecture | 178d | 2001-01-03 A | 2001-09-07 A | 100% |  | 2001-01-03 | 2001-12-21 | 253d |  | finish no earlier than 2001-09-07 | WG SA2 | 1424h | 1424h |  |  |  |  | TSG |  |  |
| 540 | 40.2 | E2E QoS interworking | 211d | 2001-05-18 A | 2002-03-08 | 20% | 168.8d | 2001-05-18 | 2002-03-08 | 211d | 367d | finish no earlier than 2002-03-08 | WG CN3 | 1688h | 337.6h | E2EQoS-IW |  |  |  | TSG | yokota@lucent.com |  |
| 541 | 40.3 | QoS Management (Provisioning and Monitoring) | 136d | 2001-09-21 A | 2002-03-29 | 45% | 74.8d | 2001-03-05 | 2001-12-18 | 207d | 352d | finish no earlier than 2002-03-29 | WG SA5 | 1088h | 489.6h | E2EQoS-OAM |  |  |  | TSG | Albert.Yuhan@voicestream.com; Michael.Truss@MOTOROLA.COM |  |
| 542 | 41 | **Messaging enhancements Rel-5** | 131d | 2001-06-15 A | 2001-12-14 | 27% | 96.06d | 2001-06-15 | 2001-12-14 | 131d | 427d |  | WG T2 | 6288h | 1134.22h | MESS5 | Rel5 | Friedhelm | 1818 | TSG |  | Mes |
| 543 | 41.1 | **Multimedia Messaging (MMS) enhancements** | 131d | 2001-06-15 A | 2001-12-14 | 20% | 104.8d | 2001-06-15 | 2001-12-14 | 131d | 427d |  | WG T2 | 2624h | 323.2h | MESS5-MMS |  |  | 1819 | TSG | Josef.Laumen@SAL.SIEMENS.DE | Mes |
| 544 | 41.1.1 | Definition of service requirements | 66d | 2001-06-15 A | 2001-09-14 |  | 65.9d | 2001-06-15 | 2001-09-14 | 66d | 492d | finish no earlier than 2001-09-14 | WG SA1 | 528h | 0.8h |  |  |  |  |  | Josef.Laumen@SAL.SIEMENS.DE |  |
| 545 | 41.1.2 | Technical realization | 131d | 2001-06-15 A | 2001-12-14 | 30% | 91.7d | 2001-06-15 | 2001-12-14 | 131d | 427d | finish no earlier than 2001-12-14 | WG T2 | 1048h | 314.4h |  |  |  |  |  | Josef.Laumen@SAL.SIEMENS.DE |  |
| 546 | 41.2 | **Enhanced Messaging Service (EMS) enhancements** | 131d | 2001-06-15 A | 2001-12-14 | 33% | 87.31d | 2001-06-15 | 2001-12-14 | 131d | 427d |  | WG T2 | 2624h | 533.6h | MESS5-EMS |  |  | 1820 | TSG | Alan.Baldwin@EML.ERICSSON.SE | Mes |
| 547 | 41.2.1 | Definition of service requirements | 66d | 2001-06-15 A | 2001-09-14 |  | 65.8d | 2001-06-15 | 2001-09-14 | 66d | 492d | finish no earlier than 2001-09-14 | WG SA1 | 528h | 1.6h |  |  |  |  |  | Alan.Baldwin@EML.ERICSSON.SE |  |
| 548 | 41.2.2 | Technical realization | 131d | 2001-06-15 A | 2001-12-14 | 50% | 65.5d | 2001-06-15 | 2001-12-14 | 131d | 427d | finish no earlier than 2001-12-14 | WG T2 | 1048h | 524h |  |  |  |  |  | Alan.Baldwin@EML.ERICSSON.SE |  |
| 549 | 42 | **GERAN Inter BSC NACC improvements over the Gb Interface** | 140d | 2001-09-03 | 2002-03-15 |  |  | 2001-09-03 | 2002-03-15 | 140d | 362d |  | TSG GERAN | 9440h |  |  |  |  |  |  |  |  |
| 550 | 42.1 | **Modification of core network protocols for GERAN Inter BSC NACC over Gb Interface** | 129d | 2001-09-03 | 2002-02-28 |  |  | 2001-09-03 | 2002-02-28 | 129d | 373d |  | WG CN4; WG SA2 | 6080h |  |  |  |  |  |  |  |  |
| 551 | 42.1.1 | Stage 2 - Concept | 43d | 2001-09-03 | 2001-10-31 |  |  | 2001-09-03 | 2001-10-31 | 43d | 459d | finish no earlier than 2001-10-31 | WG CN4; WG SA2 | 688h |  |  |  |  |  |  |  |  |
| 552 | 42.1.2 | Stage 2 - 23.060 change - Definition of Inter BSC NACC | 79d | 2001-09-03 | 2001-12-20 |  |  | 2001-09-03 | 2001-12-20 | 79d | 423d | finish no earlier than 2001-12-20 | WG CN4; WG SA2 | 1264h |  |  |  |  |  |  |  |  |
| 553 | 42.1.3 | Stage 3 (changes to TS 29.060) | 129d | 2001-09-03 | 2002-02-28 |  |  | 2001-09-03 | 2002-02-28 | 129d | 373d | finish no earlier than 2002-02-28 | WG CN4; WG SA2 | 2064h |  |  |  |  |  |  |  |  |
| 554 | 42.2 | **Modification of Gb protocols for GERAN Inter BSC NACC over Gb Interface** | 140d | 2001-09-03 | 2002-03-15 |  |  | 2001-09-03 | 2002-03-15 | 140d | 362d |  | TSG GERAN | 2240h |  |  |  |  |  |  |  |  |
| 555 | 42.2.1 | Stage 3 (changes to TS 48.018) | 140d | 2001-09-03 | 2002-03-15 |  |  | 2001-09-03 | 2002-03-15 | 140d | 362d | finish no earlier than 2002-03-15 | TSG GERAN | 1120h |  |  |  |  |  |  |  |  |
| 556 | 43 | Service Change and UDI Fallback | 110d | 2001-10-08 A | 2002-03-08 | 80% | 22d | 2001-07-13 | 2001-12-14 | 111d | 367d | finish no earlier than 2002-03-08 | WG CN3 | 880h | 704h | SCUDIF | Rel5 |  |  | TSG | Rune.Werner.Wiik@ericsson.no |  |
| 557 | 44 | **Speech Recognition and Speech Enabled Services** | 190d | 2001-10-08 A | 2002-06-28 | 1% | 188.84d |  |  |  | 287d |  | WG SA1 | 4872h | 29.65h | SRSES |  |  |  | TSG |  |  |
| 558 | 44.1 | Speech Enabled Services Based on Distributed Speech Recognition (DSR) | 115d | 2001-10-08 A | 2002-03-15 | 2% | 112.45d |  |  |  | 362d | finish no earlier than 2002-03-15 | WG SA1 | 920h | 20.4h | DSR |  |  |  | TSG | Dwilliams@qualcomm.com |  |
| 559 | 44.2 | Stage 2 of DSR | 152d | 2001-11-29 | 2002-06-28 |  |  |  |  |  | 287d | finish no earlier than 2002-06-28 | WG SA2 | 1216h |  | DSR |  |  |  |  |  |  |
| 560 | 44.3 | SDP protocols extension to include DSR | 152d | 2001-11-29 | 2002-06-28 |  |  |  |  |  | 287d | start no earlier than 2001-11-29 | TSG CN | 1216h |  | DSR |  |  |  |  |  |  |

Notes:
- 534: Title renamed at SA#13
- 535: This may or may not be a separate stage 1. In the meantime, CRs are proposed for 22.101 / Text3: 22.101
- 537: Work in SA2 needs to be done; therefore start and finish dates have no meaning yet / Text4: Dimitris Koulakiotis, Nokia
- 538: Text4: Johnson Oyama, Ericsson
- 539: Text3: 23.207
- 540: [DAB - 01/11/01] - End date pushed back to March updated WID details / Text3: New 29.208, 29.207, 27.060, 29.061, 24.008, 24.228, , 24.229, 29.060, 29.163 / Text4: Daisuke Yokota, Lucent
- 541: az: WID appr.SA#13. / Text3: 32-series / Text4: Albert YUHAN (VoiceStream Wireless), Michael TRUSS (Motorola)
- 542: support of UAProf, so this in my opinion is 100% complete
- 543: Text4: Josef Laumen, Siemens
- 544: Text3: 22.140 / Text4: Josef Laumen, Siemens
- 545: Text3: 23.140 / Text4: Josef Laumen, Siemens
- 546: Text3: 23.040 / Text4: Alan Baldwin, Ericsson
- 547: Text4: Alan Baldwin, Ericsson
- 548: Text3: 23.040 / Text4: Alan Baldwin, Ericsson
- 556: [DAB - 01/11/01] - End date pushed back to March updated WID details / Text3: 29.007, 27.001, 24.008 / Text4: Rune Werner Wiik, Ericsson AS
- 558: Text3: 22.941, 23.207 / Text4: D Williams, QUALCOMM, Inc.

| ID | WBS | Task | Type | Duration | Start | Finish | Predecessors | Complete | Remaining | Baseline start | Baseline finish | Baseline duration | Total slack | Free slack | Constraint | Resources | Work | Actual work | Text1 | Text6 | Text7 | Text4 | Text5 | Text8 | Text9 | Text2 | Text3 |
| --- | --- | --- | --- | --- | --- | --- | --- | --- | --- | --- | --- | --- | --- | --- | --- | --- | --- | --- | --- | --- | --- | --- | --- | --- | --- | --- | --- |
| 561 | 45 | **Generic User Profile** |  | 176d | 2001-10-08 A | 2002-06-10 |  | 1% | 175d |  |  |  | 301d |  |  | WG SA1 | 5000h | 28.39h | GUP | Rel6 | TSG |  |  |  |  |  |  |
| 562 | 45.1 | Stage 1 - Requirements |  | 51d | 2001-10-08 A | 2001-12-17 |  | 5% | 48.45d |  |  |  | 426d |  | finish no earlier than 2001-12-17 | WG SA1 | 408h | 20.4h | GUP |  |  |  |  |  |  |  |  |
| 563 | 45.2 | Data description framework |  | 111d | 2001-10-08 | 2002-03-11 |  |  |  |  |  |  | 366d |  | finish no earlier than 2002-03-11 | WG T2 | 888h |  | GUP |  |  |  |  |  |  |  |  |
| 564 | 45.3 | Stage 2 - Architecture |  | 111d | 2001-10-08 | 2002-03-11 |  |  |  |  |  |  | 366d |  | finish no earlier than 2002-03-11 | WG SA2 | 888h |  | GUP |  |  |  |  |  |  |  |  |
| 565 | 45.4 | Stage 3 - Common objects |  | 176d | 2001-10-08 | 2002-06-10 |  |  |  |  |  |  | 301d |  | finish no earlier than 2002-06-10 | WG T2 | 1408h |  | GUP |  |  |  |  |  |  |  |  |
| 566 | 46 | **Digital Rights Management** |  | 249d | 2001-10-08 | 2002-09-19 |  |  |  |  |  |  | 228d |  |  | WG SA1 | 8728h |  | DRM | Rel6 | TSG |  |  |  |  |  |  |
| 567 | 46.1 | Requirements |  | 98d | 2001-10-08 | 2002-02-20 |  |  |  |  |  |  | 379d |  | start no earlier than 2001-10-08 | WG SA1 | 784h |  | DRM |  |  |  |  |  |  |  |  |
| 568 | 46.2 | Architecture |  | 186d | 2002-01-03 | 2002-09-19 |  |  |  |  |  |  | 228d |  | finish no earlier than 2002-09-19 | WG SA2 | 1488h |  | DRM |  |  |  |  |  |  |  |  |
| 569 | 46.3 | Security |  | 186d | 2002-01-03 | 2002-09-19 |  |  |  |  |  |  | 228d |  | start no earlier than 2002-01-03 | WG SA3 | 1488h |  | DRM |  |  |  |  |  |  |  |  |
| 570 | 46.4 | Codec Aspects |  | 186d | 2002-01-03 | 2002-09-19 |  |  |  |  |  |  | 228d |  | start no earlier than 2002-01-03 | WG SA4 | 1488h |  | DRM |  |  |  |  |  |  |  |  |
| 571 | 46.5 | Terminal Aspects |  | 186d | 2002-01-03 | 2002-09-19 |  |  |  |  |  |  | 228d |  | start no earlier than 2002-01-03 | WG T2 | 1488h |  | DRM |  |  |  |  |  |  |  |  |
| 572 | 47 | FS on WLAN-UMTS Interworking |  | 185d | 2001-10-08 | 2002-06-21 |  |  |  |  |  |  | 292d |  | finish no earlier than 2002-06-21 | WG SA1 | 1480h |  | WLAN | Rel6 | TSG | Fredric Paint, Telenor |  |  |  |  |  |
| 573 | 48 | FS on Priority Service |  | 185d | 2001-10-08 | 2002-06-21 |  |  |  |  |  |  | 292d |  | start no earlier than 2001-10-08 | TSG SA | 1480h |  | AxsClas | Rel6 | TSG | Biplab K. Pramanik, Telcordia Technologies | bpramani@telcordia.com |  |  |  |  |
| 574 | 49 | **UE Functionality Split** |  | 86d | 2001-11-29 | 2002-03-28 |  |  |  |  |  |  | 353d |  |  | WG SA1 | 1376h |  | UESPLIT | Rel6 | TSG | Sanjay Gupta, Motorola | sanjay.gupta@motorola.com |  |  |  |  |
| 575 | 49.1 | Stage 2 |  | 86d | 2001-11-29 | 2002-03-28 |  |  |  |  |  |  | 353d |  | finish no earlier than 2002-03-28 | WG SA2 | 688h |  |  |  |  |  |  |  |  |  |  |
| 576 | 50 | **Facsimile** |  | 219d | 2000-02-22 A | 2000-12-22 |  | 74% | 57.05d | 2000-02-22 | 2000-12-22 | 219d | 682d |  |  | WG SA1 | 6456h | 4959.57h | FAX | Rel4 | TSG |  |  | Alain | 1340 |  |  |
| 577 | 50.1 | **Real Time Fax** |  | 89d | 2000-02-22 A | 2000-06-23 A |  | 100% |  | 2000-02-22 | 2000-06-23 | 89d |  |  |  | WG SA2 | 3664h | 3664h | FAX-RT |  |  |  |  |  | 1341 | CCaR |  |
| 578 | 50.1.1 | Terminal capabilities, AT commands |  | 89d | 2000-02-22 A | 2000-06-23 A |  | 100% |  | 2000-02-22 | 2000-06-23 | 89d |  |  | finish no earlier than 2000-06-23 | WG T2 | 712h | 712h | FAX-RT |  |  |  |  |  | 1808 | CCaR | 21.904, 27.007 |
| 579 | 50.1.2 | Signalling aspects (e.g. ICM) |  | 89d | 2000-02-22 A | 2000-06-23 A |  | 100% |  | 2000-02-22 | 2000-06-23 | 89d |  |  | start no earlier than 2000-02-22 | WG CN1 | 712h | 712h | FAX-RT |  |  |  |  |  | 1343 | CCaR |  |
| 580 | 50.1.3 | Service provision |  | 89d | 2000-02-22 A | 2000-06-23 A |  | 100% |  | 2000-02-22 | 2000-06-23 | 89d |  |  | finish no earlier than 2000-06-23 | WG CN3 | 712h | 712h | FAX-RT |  |  |  |  |  | 1648 | CCaR | 23.146 |
| 581 | 50.1.4 | Review whether service/stage 1 aspects need to be aligned |  | 51d | 2000-04-14 A | 2000-06-23 A |  | 100% |  | 2000-04-14 | 2000-06-23 | 51d |  |  | finish no earlier than 2000-12-14 | WG SA1 | 408h | 408h | FAX-RT |  |  |  |  |  | 1345 | CCaR |  |
| 582 | 50.1.5 | Review whether architecture/stage 2 aspects need to be aligned |  | 51d | 2000-04-14 A | 2000-06-23 A |  | 100% |  | 2000-04-14 | 2000-06-23 | 51d |  |  | finish no earlier than 2000-12-14 | WG SA2 | 408h | 408h | FAX-RT |  |  |  |  |  | 1346 | CCaR |  |
| 583 | 50.2 | Start Testing | milestone | 0d | 2000-06-26 | 2000-06-26 | 577 |  |  | 2000-06-26 | 2000-06-26 | 0d | 682d | 0d | finish no earlier than 2000-06-26 | MLST |  |  |  |  |  |  |  |  | 2041 |  |  |
| 584 | 50.3 | Conformance Test Aspects - Facsimile |  | 130d | 2000-06-26 | 2000-12-22 | 583 |  |  | 2000-06-26 | 2000-12-22 | 130d | 682d |  | finish no earlier than 2000-12-22 | WG T1 | 1040h |  |  |  |  |  |  |  | 1851 |  | 34.125 |
| 585 | 51 | Transparent End-to-End PS mobile streaming application |  | 253d | 2000-04-03 A | 2001-03-21 A |  | 100% |  | 2000-04-03 | 2001-03-21 | 253d |  |  | finish no earlier than 2000-12-29 | WG SA4 | 2024h | 2024h | PSTREAM | Rel4 | TSG |  |  | Paolo | 1539 |  | 26.233, 26.234 |

Notes:
- 566: Foreseen start and completion dates introduced by MCC (no indication at all on the WID)
- 577: postponed from R99 to R00, SP-000169
- 584: Bearer services, new spec document?

| ID | WBS | Task | Duration | Start | Finish | Predecessors | Complete | Remaining | Baseline start | Baseline finish | Baseline duration | Total slack | Constraint | Resources | Work | Actual work | Text1 | Text2 | Text3 | Text4 | Text5 | Text6 | Text7 | Text8 | Text9 |
| --- | --- | --- | --- | --- | --- | --- | --- | --- | --- | --- | --- | --- | --- | --- | --- | --- | --- | --- | --- | --- | --- | --- | --- | --- | --- |
| 586 | 52 | **Multimedia Messaging** | 277d | 2000-02-22 A | 2001-03-14 |  | 99% | 0d | 2000-02-22 | 2001-03-14 | 277d | 0d |  | WG T2 | 12208h | 10661.6h | MMS | Mes | 22.140, 23.140 | Josef Laumen, Siemens | Josef.Laumen@SAL.SIEMENS.DE | Rel4 | TSG | Friedhelm | 1818 |
| 587 | 52.1 | Definition of service requirements | 72d | 2000-02-22 A | 2000-05-31 A |  | 100% |  | 2000-02-22 | 2000-05-31 | 72d |  | start no earlier than 2000-02-22 | WG SA1 | 576h | 576h | MMS | Mes |  |  |  |  |  |  | 136 |
| 588 | 52.2 | Review of definition of service requirements | 205d | 2000-06-01 A | 2001-03-14 A | 587 | 100% |  | 2000-06-01 | 2001-03-14 | 205d |  | finish no earlier than 2000-09-08 | WG T2 | 1640h | 1640h |  | Mes | 22.140, 23.140 | Josef Laumen, Siemens |  |  | TSG |  | 1819 |
| 589 | 52.3 | **Technical Realisation** | 243d | 2000-04-10 A | 2001-03-14 A |  | 100% |  | 2000-04-10 | 2001-03-14 | 243d |  |  | WG T2 | 7776h | 7776h |  | Mes | 22.140, 23.140 | Josef Laumen, Siemens | Josef.Laumen@SAL.SIEMENS.DE |  | TSG |  | 1820 |
| 590 | 52.3.1 | Review of definition of reference Achitecture model | 243d | 2000-04-10 A | 2001-03-14 A |  | 100% |  | 2000-04-10 | 2001-03-14 | 243d |  | finish no earlier than 2001-03-14 | WG T2 | 1944h | 1944h |  | Mes | 22.140, 23.140 | Josef Laumen, Siemens | Josef.Laumen@SAL.SIEMENS.DE |  | TSG |  | 1821 |
| 591 | 52.3.2 | "Fulfill Requirements of Stage 1" | 243d | 2000-04-10 A | 2001-03-14 A |  | 100% |  | 2000-04-10 | 2001-03-14 | 243d |  | finish no earlier than 2001-03-14 | WG T2 | 1944h | 1944h |  | Mes | 22.140, 23.140 | Josef Laumen, Siemens | Josef.Laumen@SAL.SIEMENS.DE |  | TSG |  | 1822 |
| 592 | 52.3.3 | Definition of MMS primitives in Stage 2 | 243d | 2000-04-10 A | 2001-03-14 A |  | 100% |  | 2000-04-10 | 2001-03-14 | 243d |  | finish no earlier than 2001-03-14 | WG T2 | 1944h | 1944h |  | Mes | 22.140, 23.140 | Josef Laumen, Siemens | Josef.Laumen@SAL.SIEMENS.DE |  | TSG |  | 1823 |
| 593 | 53 | **Transcoder-Free Operation** | 325d | 2000-01-03 A | 2001-03-30 |  | 99% | 0d | 2000-01-03 | 2001-03-30 | 325d | 0d |  | WG CN4 | 14320h | 11720h | TrFO | Cod |  |  |  | Rel4 |  | Kimmo | 1541 |
| 594 | 53.1 | **OoBTC solution** | 325d | 2000-01-03 A | 2001-03-30 A |  | 100% |  | 2000-01-03 | 2001-03-30 | 325d |  |  | WG CN4 | 9720h | 9720h | TRFO-OOBTC | Cod |  | Tosshiyuki Tamura, NEC | tamurato@elsf.ncos.nec.co.jp |  | WG |  | 112 |
| 595 | 53.1.1 | implementation in UTRAN | 145d | 2000-09-11 A | 2001-03-30 A |  | 100% |  | 2000-09-11 | 2001-03-30 | 145d |  | finish no earlier than 2001-03-30 | WG RAN3 | 1160h | 1160h | TRFO-OOBTC-UTRAN |  | 25.401, 25.410, 25.413, 25.415, 23.153 | Alexander Vesely, Siemens | alexander.vesely@SIEMENS.AT |  | TSG |  | 1512 |
| 596 | 53.1.2 | Impact on architecture, Principles and Terminology | 210d | 2000-01-03 A | 2000-10-20 A |  | 100% |  | 2000-01-03 | 2000-10-20 | 210d |  | finish no earlier than 2000-10-20 | WG SA2 | 1680h | 1680h | TRFO-OOBTC | Cod |  |  |  |  |  |  | 896 |
| 597 | 53.1.3 | Codec Negotiation between UE and MSC | 125d | 2000-08-14 A | 2001-02-02 A |  | 100% |  | 2000-08-14 | 2001-02-02 | 125d |  | finish no earlier than 2001-02-02 | WG CN1 | 1000h | 1000h | TRFO-OOBTC | Cod | 24.008, 23.009, 23.108, (29.002) | Andrew Howell / Motorola |  |  | TSG |  | 1657 |
| 598 | 53.1.4 | Codec Negotiation inter MSC | 125d | 2000-07-03 A | 2000-12-22 A |  | 100% |  | 2000-07-03 | 2000-12-22 | 125d |  | finish no earlier than 2000-12-22 | WG CN4 | 1000h | 1000h | TRFO-OOBTC | Cod |  |  |  |  |  |  | 115 |
| 599 | 53.1.5 | Bearer establishment inter MSC | 125d | 2000-07-03 A | 2000-12-22 A |  | 100% |  | 2000-07-03 | 2000-12-22 | 125d |  | finish no earlier than 2000-12-22 | WG CN4 | 1000h | 1000h | TRFO-OOBTC | Cod | 23.153 |  |  |  | TSG |  | 894 |
| 600 | 53.1.6 | Prevention of user fraud | 160d | 2000-08-21 A | 2001-03-30 A |  | 100% |  | 2000-08-21 | 2001-03-30 | 160d |  | finish no earlier than 2001-03-30 | WG SA3 | 1280h | 1280h | TRFO-OOBTC |  |  |  |  |  |  |  | 1617 |
| 601 | 53.2 | **Speech Transcoder: Location and Control at the UMTS Core Network Border** | 125d | 2000-04-10 A | 2000-09-29 A |  | 100% |  | 2000-04-10 | 2000-09-29 | 125d |  |  | WG SA2 | 2000h | 2000h | TRFO-STLC | Cod |  |  |  |  | WG |  | 905 |
| 602 | 53.2.1 | Transcoder at Edge | 125d | 2000-04-10 A | 2000-09-29 A |  | 100% |  | 2000-04-10 | 2000-09-29 | 125d |  | finish no earlier than 2000-09-29 | TSG CN | 1000h | 1000h | TRFO-STLC | Cod |  |  |  |  |  |  | 124 |
| 603 | 54 | **GERAN improvements 1 (Gb over IP)** | 225d | 2000-05-09 A | 2001-03-19 A |  | 100% |  | 2000-05-09 | 2001-03-19 | 225d |  |  | TSG GERAN | 6472h | 6472h | GEIMP1 |  |  |  |  | Rel4 | TSG | Paolo | 2310 |
| 604 | 54.1 | **Gb over IP (Ip-fication of Gb)** | 225d | 2000-05-09 A | 2001-03-19 A |  | 100% |  | 2000-05-09 | 2001-03-19 | 225d |  |  | TSG GERAN | 4672h | 4672h | GbIP |  |  |  |  |  | TSG | Paolo | 2311 |
| 605 | 54.1.1 | Concept | 134d | 2000-05-09 A | 2000-11-10 A |  | 100% |  | 2000-05-09 | 2000-11-10 | 134d |  |  | TSG GERAN | 1072h | 1072h |  |  |  |  |  |  | TSG |  | 2312 |
| 606 | 54.1.2 | Changes to 08.16, 08.18 | 225d | 2000-05-09 A | 2001-03-19 A |  | 100% |  | 2000-05-09 | 2001-03-19 | 225d |  |  | TSG GERAN | 1800h | 1800h |  |  |  |  |  |  | TSG |  | 2313 |
| 607 | 55 | **GERAN improvements 2 (NACC)** | 155d | 2000-11-06 A | 2001-06-08 |  | 99% | 0d | 2000-11-06 | 2001-06-08 | 155d | 0d |  | TSG GERAN | 8680h | 7064h | GEIMP2 |  |  |  |  | Rel4 | TSG | Paolo | 2314 |
| 608 | 55.1 | **Gb enhancements** | 155d | 2000-11-06 A | 2001-06-08 |  | 99% | 0d | 2000-11-06 | 2001-06-08 | 155d | 0d |  | TSG GERAN | 7440h | 6216h | Gben |  |  |  |  |  | TSG | Paolo | 2315 |
| 609 | 55.1.1 | **NACC (Network Assisted Cell Change)** | 155d | 2000-11-06 A | 2001-06-08 |  | 99% | 0d | 2000-11-06 | 2001-06-08 | 155d | 0d |  | TSG GERAN | 6200h | 5368h |  |  |  |  |  |  | TSG |  | 2316 |
| 610 | 55.1.1.1 | Concept | 155d | 2000-11-06 A | 2001-06-08 A |  | 100% |  | 2000-11-06 | 2001-06-08 | 155d |  | finish no earlier than 2001-06-08 | TSG GERAN | 1240h | 1240h |  |  |  |  |  |  | TSG |  | 2420 |
| 611 | 55.1.1.2 | Changes in 03.64 | 155d | 2000-11-06 A | 2001-06-08 A |  | 100% |  | 2000-11-06 | 2001-06-08 | 155d |  | finish no earlier than 2001-06-08 | TSG GERAN | 1240h | 1240h |  |  |  |  |  |  | TSG |  | 2317 |
| 612 | 55.1.1.3 | Changes in 04.60 | 155d | 2000-11-06 A | 2001-06-08 A |  | 100% |  | 2000-11-06 | 2001-06-08 | 155d |  | finish no earlier than 2001-06-08 | TSG GERAN | 1240h | 1240h |  |  |  |  |  |  | TSG |  | 2318 |
| 613 | 55.1.1.4 | Changes in 44.008 | 155d | 2000-11-06 A | 2001-06-08 A |  | 100% |  | 2000-11-06 | 2001-06-08 | 155d |  | finish no earlier than 2001-06-08 | TSG GERAN | 1240h | 1240h |  |  |  |  |  |  | TSG |  | 2319 |

Notes:
- 591: e.g. minimum set of media formats, media format conversion, personalization of MMS.
- 593: Lead given to CN4 from CN / [DAB 28/11/00]
- 595: moved according to NP-000575
- 596: e.g. study cascading TrFO/TFO/TrFO
- 597: the link to NP-000085has been deleted because refering to a R99 status sheet / One common set of codec negotiation procedures will be specified as in ID1656.
- 598: Bearer establishment inter MSC. TS 23.153 R99 part complete. capabilities moved to annex + list of open issues
- 599: Bearer establishment inter MSC. TS 23.153 R99 part complete. capabilities moved to annex. / See NP-000127 / Open issues: / Handling of Conference Calls; / Handling of Multi Party Supplementary Services; / Handling of Handover UMTS to GSM; / Handling of Sending a ...
- 600: S3 awaiting liaison on any security issues from N4. S3#17: N4 replied that they had not identified any issues: WI considered complete.
- 601: WI description and Tdoc S2-99352 / Speech Transcoder: Location and Control at the UMTS Core Network Border
- 602: WI description and Tdoc S2-99352...

| ID | WBS | Task | Type | Duration | Start | Finish | Predecessors | Complete | Remaining | Baseline start | Baseline finish | Baseline duration | Total slack | Free slack | Constraint | Resources | Work | Actual work | Text6 | Text7 | Text8 | Text9 | Text1 | Text4 | Text2 | Text3 | Text5 |
| --- | --- | --- | --- | --- | --- | --- | --- | --- | --- | --- | --- | --- | --- | --- | --- | --- | --- | --- | --- | --- | --- | --- | --- | --- | --- | --- | --- |
| 614 | 56 | **GERAN improvements 4 (Delayed TBF)** |  | 105d | 2001-01-15 A | 2001-06-08 |  | 37% | 66.32d | 2001-01-15 | 2001-06-08 | 105d | 562d |  |  | TSG GERAN | 3960h | 1989.47h | Rel4 | TSG | Paolo | 2324 |  |  |  |  |  |
| 615 | 56.1 | **Gb enhancements 2** |  | 105d | 2001-01-15 A | 2001-06-08 |  | 37% | 66.32d | 2001-01-15 | 2001-06-08 | 105d | 562d |  |  | TSG GERAN | 3120h | 1149.47h |  | TSG | Paolo | 2325 |  |  |  |  |  |
| 616 | 56.1.1 | stage 2 |  | 105d | 2001-01-15 A | 2001-06-08 A |  | 100% |  | 2001-01-15 | 2001-06-08 | 105d |  |  | finish no earlier than 2001-06-08 | TSG GERAN | 840h | 840h |  |  | Gert | 2429 |  |  |  |  |  |
| 617 | 56.1.2 | **Stage 3 (changes in 44.060)** |  | 60d | 2001-01-15 A | 2001-04-06 |  |  | 60d | 2001-01-15 | 2001-04-06 | 60d | 607d |  |  | WG GERAN2 | 1440h |  |  | TSG | Gert | 2421 |  |  |  |  |  |
| 618 | 56.1.2.1 | Definition of enhanced countdown procedure |  | 60d | 2001-01-15 A | 2001-04-06 |  |  | 60d | 2001-01-15 | 2001-04-06 | 60d | 607d |  | finish no earlier than 2001-04-06 | WG GERAN2 | 480h |  |  | TSG | Gert | 2327 |  |  |  |  |  |
| 619 | 56.1.2.2 | Definition of enhanced TBF release procedure |  | 60d | 2001-01-15 A | 2001-04-06 |  |  | 60d | 2001-01-15 | 2001-04-06 | 60d | 607d |  | finish no earlier than 2001-04-06 | WG GERAN2 | 480h |  |  | TSG | Gert | 2328 |  |  |  |  |  |
| 620 | 56.1.2.3 | Definition of USF=FREE type polling mechanism on PDCH |  | 60d | 2001-01-15 A | 2001-04-06 |  |  | 60d | 2001-01-15 | 2001-04-06 | 60d | 607d |  | finish no earlier than 2001-04-06 | WG GERAN2 | 480h |  |  | TSG | Gert | 2329 |  |  |  |  |  |
| 621 | 57 | **Low Chip Rate TDD option** |  | 539d | 2000-07-19 A | 2002-08-12 |  | 59% | 221.3d | 2000-07-19 | 2003-06-27 | 768d | 256d |  |  | WG RAN1 | 18712h | 9663.27h | Rel4 | TSG | Shinobu | 1222 | LCRTDD | G. Yang, CWTS |  |  |  |
| 622 | 57.1 | Physical layer |  | 183d | 2000-07-19 A | 2001-03-30 A |  | 100% |  | 2000-07-19 | 2001-03-30 | 183d |  |  | finish no earlier than 2001-03-30 | WG RAN1 | 1464h | 1464h |  | TSG |  | 1223 | LCRTDD-Phys | G. Yang, CWTS |  |  |  |
| 623 | 57.2 | Layer 2 and layer 3 protocol aspects |  | 183d | 2000-07-19 A | 2001-03-30 A |  | 100% |  | 2000-07-19 | 2001-03-30 | 183d |  |  | finish no earlier than 2001-03-30 | WG RAN2 | 1464h | 1464h |  | TSG |  | 1224 | LCRTDD-L23 | Y. Liu, CWTS | BaAS |  |  |
| 624 | 57.3 | RF radio transmission/reception, system performance requirements and conformance testing |  | 165d | 2000-08-14 A | 2001-03-30 A |  | 100% |  | 2000-08-14 | 2001-03-30 | 165d |  |  | finish no earlier than 2001-03-30 | WG RAN4 | 1320h | 1320h |  | TSG |  | 1225 | LCRTDD-RF | D. Zhang, CWTS | BaAS |  |  |
| 625 | 57.4 | UE radio access capability |  | 165d | 2000-08-14 A | 2001-03-30 A |  | 100% |  | 2000-08-14 | 2001-03-30 | 165d |  |  | finish no earlier than 2001-03-30 | WG RAN2 | 1320h | 1320h |  | TSG |  | 1227 | LCRTDD-UErac | Y. Liu, CWTS | BaAS |  |  |
| 626 | 57.5 | Iub/Iur protocol aspects |  | 165d | 2000-08-14 A | 2001-03-30 A |  | 100% |  | 2000-08-14 | 2001-03-30 | 165d |  |  | finish no earlier than 2001-03-30 | WG RAN3 | 1320h | 1320h |  | TSG |  | 1228 | LCRTDD-IubIur | Y. Liu, CWTS | BaAS |  |  |
| 627 | 57.6 | **Low chiprate TDD interworking with GERAN** |  | 101d | 2000-09-01 A | 2001-01-19 A | 626 | 100% |  | 2000-09-01 | 2001-01-19 | 101d |  |  |  |  |  |  |  |  | Paolo | 2262 |  |  |  |  |  |
| 628 | 57.6.1 | Handover and Cell Selection / Reselection to UTRA 1.28 Mcps TDD |  | 101d | 2000-09-01 A | 2001-01-19 A |  | 100% |  | 2000-09-01 | 2001-01-19 | 101d |  |  | finish no earlier than 2001-01-19 |  |  |  |  |  |  | 2263 |  |  |  |  |  |
| 629 | 57.7 | Start Testing | milestone | 0d | 2001-09-03 | 2001-09-03 | 627 |  |  | 2001-03-19 | 2001-03-19 | 0d | 275.82d | 10d | start no earlier than 2001-09-03 | MLST |  |  |  |  |  | 1911 |  |  |  |  |  |
| 630 | 57.8 | **Conformance Test Aspects - Low Chip Rate TDD** |  | 236d | 2001-09-17 A | 2002-08-12 | 629 | 4% | 226.18d | 2001-03-19 | 2003-06-27 | 595d | 256d |  |  | WG T1 | 7656h | 318.56h |  |  |  | 2103 |  |  |  | 0% |  |
| 631 | 57.8.1 | Testing Physical Layer |  | 140d | 2001-10-08 | 2002-04-19 |  |  |  | 2001-03-19 | 2001-09-28 | 140d | 337d |  | start no earlier than 2001-10-08 | WG T1 | 1120h |  |  |  |  | 2216 |  |  |  |  |  |
| 632 | 57.8.2 | Testing Layer 2 and layer 3 protocol aspects |  | 140d | 2001-09-17 A | 2002-03-29 |  | 11% | 125d | 2001-09-17 | 2002-03-29 | 140d | 352d |  | finish no earlier than 2002-03-29 | WG T1 | 1120h | 120h |  | TSG |  | 2217 | LCRTDD-L23 |  |  | 34.123-1, 34.123-2 |  |
| 633 | 57.8.3 | Testing Layer 2 and layer 3 protocol aspects - TTCN |  | 161d | 2001-12-31 | 2002-08-12 |  |  |  | 2003-06-27 | 2003-06-27 | 1d | 256d |  | start no earlier than 2001-12-31 | WG T1 | 1288h |  |  | TSG |  |  | LCRTDD-L23 |  |  | 34.123-3 |  |
| 634 | 57.8.4 | Testing RF Radio Transmission and Reception |  | 140d | 2001-09-17 A | 2002-03-29 |  | 11% | 125d | 2001-06-18 | 2001-12-28 | 140d | 352d |  | start no earlier than 2001-09-17 | WG T1 | 1120h | 120h |  | TSG |  | 2218 | LCRTDD-RF |  |  |  |  |
| 635 | 57.8.5 | Testing UE radio access capability |  | 140d | 2001-10-15 | 2002-04-26 |  |  |  | 2001-03-19 | 2001-09-28 | 140d | 332d |  | start no earlier than 2001-10-15 | WG T1 | 1120h |  |  |  |  | 2219 |  |  |  |  |  |
| 636 | 58 | **Enable bearer independent CS architecture** |  | 720d | 2000-01-03 A | 2002-10-04 |  | 68% | 232.89d | 2000-01-03 | 2002-03-15 | 575d | 217d |  |  | WG SA2 | 23496h | 12840.9h | Rel4 | TSG | Kimmo | 1322 | CSSPLIT | Alexander Milinski, Siemens | CCaR |  |  |
| 637 | 58.1 | **Enable bearer-independent call control** |  | 424d | 2000-01-03 A | 2001-08-16 |  | 99% | 0d | 2000-01-03 | 2001-08-16 | 424d | 0d |  |  | WG CN4 | 12336h | 8944h |  | WG |  | 1323 | CSSPLIT | Heinz-Peter Keutman, Ericsson | CCaR |  | Heinz-Peter.Keutmann@eed.ericsson.se |
| 638 | 58.1.1 | Architecture and Stage 2 description |  | 180d | 2000-01-03 A | 2000-09-08 A |  | 100% |  | 2000-01-03 | 2000-09-08 | 180d |  |  | finish no earlier than 2000-09-08 | WG SA2 | 1440h | 1440h |  |  |  | 1516 | CSSPLIT |  | CCaR | 23.002 |  |
| 639 | 58.1.2 | Standardisation of protocols (control & user planes) over Nb interface |  | 64d | 2001-01-02 A | 2001-03-30 A |  | 100% |  | 2001-01-02 | 2001-03-30 | 64d |  |  | finish no earlier than 2001-03-30 | WG CN3 | 512h | 512h |  | TSG |  | 1325 | CSSPLIT |  | CCaR |  |  |
| 640 | 58.1.3 | Standardisation of protocols over reference points between MSC server and Gateway MSC server |  | 130d | 2000-09-25 A | 2001-03-23 A |  | 100% |  | 2000-09-25 | 2001-03-23 | 130d |  |  | finish no earlier than 2001-03-23 | WG CN4 | 1040h | 1040h |  | TSG |  | 1326 | CSSPLIT |  | CCaR |  |  |
| 641 | 58.1.4 | Standardisation of detailed stage 2 description |  | 180d | 2000-07-17 A | 2001-03-23 A |  | 100% |  | 2000-07-17 | 2001-03-23 | 180d |  |  | finish no earlier than 2001-03-23 | WG CN4 | 1440h | 1440h |  | TSG |  | 1616 | CSSPLIT |  |  |  |  |

Notes:
- 631: duration set to 6 months (was 0)
- 632: duration set to 6 months (was 0)
- 634: duration set to 6 months (was 0), finish date set
- 635: duration set to 6 months (was 0)
- 638: R00 stage 2 at least 80 % complete in TSGS #8 21.-23.6.2000

| ID | WBS | Task | Type | Duration | Start | Finish | Predecessors | Complete | Remaining | Baseline start | Baseline finish | Baseline duration | Total slack | Free slack | Constraint | Resources | Work | Actual work | Text1 | Text2 | Text7 | Text9 | Text3 | Text6 | Text8 | Text4 | Text5 |
| --- | --- | --- | --- | --- | --- | --- | --- | --- | --- | --- | --- | --- | --- | --- | --- | --- | --- | --- | --- | --- | --- | --- | --- | --- | --- | --- | --- |
| 642 | 58.1.5 | **Bearer control between MSC server and MGW** |  | 250d | 2000-09-01 A | 2001-08-16 A |  | 100% |  | 2000-09-01 | 2001-08-16 | 250d |  |  |  | WG CN4 | 4512h | 4512h | CSSPLIT | CCaR | TSG | 1327 |  |  |  |  |  |
| 643 | 58.1.5.1 | stage 3 - protocol issues |  | 250d | 2000-09-01 A | 2001-08-16 A |  | 100% |  | 2000-09-01 | 2001-08-16 | 250d |  |  | finish no earlier than 2001-08-16 | WG CN4 | 2000h | 2000h | CSSPLIT | CCaR | TSG | 1328 |  |  |  |  |  |
| 644 | 58.1.5.2 | stage 3 - parameter value issues |  | 64d | 2001-01-02 A | 2001-03-30 A |  | 100% |  | 2001-01-02 | 2001-03-30 | 64d |  |  | finish no earlier than 2001-03-30 | WG CN3 | 512h | 512h | CSSPLIT | CCaR |  | 1329 |  |  |  |  |  |
| 645 | 58.2 | Lawful interception |  | 155d | 2000-08-21 | 2001-03-23 |  |  |  | 2000-08-21 | 2001-03-23 | 155d | 617d |  | start no earlier than 2000-08-21 | WG SA3 | 1240h |  | CSSPLIT | CCaR |  | 1331 |  |  |  |  |  |
| 646 | 58.3 | Start Testing | milestone | 0d | 2001-03-05 | 2001-03-05 |  |  |  | 2001-03-12 | 2001-03-12 | 0d | 372d | 155d | start no earlier than 2001-03-05 | MLST |  |  |  |  |  | 1918 |  |  |  |  |  |
| 647 | 58.4 | **Conformance Test Aspects - Enable bearer independent CS architecture** |  | 260d | 2001-10-08 | 2002-10-04 | 646 |  |  | 2001-03-19 | 2002-03-15 | 260d | 217d |  |  | WG T1 | 4160h |  | CSSPLIT-TEST |  |  | 2052 | 0% |  |  |  |  |
| 648 | 58.4.1 | UE Conformance test spec., Bearer independent CS, Protocol |  | 130d | 2001-10-08 | 2002-04-05 |  |  |  | 2001-03-19 | 2001-09-14 | 130d | 217d | 0d | start no earlier than 2001-10-08 | WG T1 | 1040h |  | CSSPLIT-TEST |  |  | 1847 | 34.123 pts 1,2 |  |  |  |  |
| 649 | 58.4.2 | UE Conformance test spec., Bearer independent CS, TTCN |  | 130d | 2002-04-08 | 2002-10-04 | 648 |  |  | 2001-09-17 | 2002-03-15 | 130d | 217d |  | finish no earlier than 2002-03-08 | WG T1 | 1040h |  | CSSPLIT-TEST |  |  | 1848 | 34.123 pt 3 |  |  |  |  |
| 650 | 59 | **MExE enhancements Rel-4** |  | 510d | 2000-01-03 A | 2001-12-14 |  | 89% | 57.32d | 2000-01-03 | 2001-12-14 | 510d | 427d |  |  | WG T2 | 19024h | 16314.1h | MEXE | Ter | TSG | 1445 |  | Rel4 | Friedhelm |  |  |
| 651 | 59.1 | **MExE Security Analysis Activity** |  | 474d | 2000-02-22 A | 2001-12-14 |  | 75% | 117.12d | 2000-02-22 | 2001-12-14 | 474d | 427d |  |  | WG SA3 | 8464h | 6372.64h | MEXE-SEC | Ter | TSG | 1447 |  |  |  | Colin Blanchard, BT | colin.blanchard@bt.com |
| 652 | 59.1.1 | Stage 3 |  | 370d | 2000-07-17 A | 2001-12-14 |  | 61% | 144.3d | 2000-07-17 | 2001-12-14 | 370d | 427d |  | finish no earlier than 2001-12-14 | WG SA3 | 2960h | 1805.6h | MEXE1-SEC | Ter |  | 2045 |  |  |  |  |  |
| 653 | 59.1.2 | Terminal aspects |  | 214d | 2000-02-22 A | 2000-12-15 A |  | 100% |  | 2000-02-22 | 2000-12-15 | 214d |  |  | finish no earlier than 2000-12-15 | WG T2 | 1712h | 1712h |  | Ter |  | 1448 |  |  |  |  |  |
| 654 | 59.2 | **MExE Rel4 Improvements and Investigations** |  | 250d | 2000-01-03 A | 2000-12-15 |  | 99% | 0d | 2000-01-03 | 2000-12-15 | 250d | 0d |  |  | WG T2 | 6480h | 6320h | MEXE-ENHANC | Ter | TSG | 1810 | 22.057, 23.057 |  |  | Mark CATALDO, Motorola | mcatald1@MOTOROLA.COM |
| 655 | 59.2.1 | 3rd MExE classmark |  | 250d | 2000-01-03 A | 2000-12-15 A |  | 100% |  | 2000-01-03 | 2000-12-15 | 250d |  |  | finish no earlier than 2000-12-15 | WG T2 | 2000h | 2000h |  | Ter | TSG | 1812 | 22.057, 23.057 |  |  | Mark CATALDO, Motorola | mcatald1@MOTOROLA.COM |
| 656 | 59.2.2 | FS on Secure download mechanism and capabilities to support SDR concepts |  | 225d | 2000-02-07 A | 2000-12-15 A |  | 100% |  | 2000-02-07 | 2000-12-15 | 225d |  |  | finish no earlier than 2000-12-15 | WG T2 | 1800h | 1800h |  | Ter | TSG | 1814 | 22.057, 23.057 |  |  | Mark CATALDO, Motorola | mcatald1@MOTOROLA.COM |
| 657 | 59.2.3 | FS on Support of MP3/MPEG4 content |  | 225d | 2000-02-07 A | 2000-12-15 A |  | 100% |  | 2000-02-07 | 2000-12-15 | 225d |  |  | finish no earlier than 2000-12-15 | WG T2 | 1800h | 1800h |  | Ter | TSG | 1815 | 22.057, 23.057 |  |  | Mark CATALDO, Motorola | mcatald1@MOTOROLA.COM |
| 658 | 60 | **Tandem Free aspects for 3G and between 2G and 3G systems** |  | 344d | 2000-02-22 A | 2001-06-15 |  | 84% | 54.67d | 2000-02-22 | 2001-06-15 | 344d | 557d |  |  | WG SA4 | 9696h | 8260.24h | TFO | Cod |  | 1631 |  | Rel4 | Paolo |  |  |
| 659 | 60.1 | **Tandem Free AMR** |  | 344d | 2000-02-22 A | 2001-06-15 |  | 84% | 54.67d | 2000-02-22 | 2001-06-15 | 344d | 557d |  |  | WG SA4 | 6944h | 5508.24h | TFO-AMR | Cod |  | 1632 |  |  |  |  |  |
| 660 | 60.1.1 | Specification |  | 284d | 2000-02-22 A | 2001-03-23 A |  | 100% |  | 2000-02-22 | 2001-03-23 | 284d |  |  | start no earlier than 2000-02-22 | WG SA4 | 2272h | 2272h | TFO-AMR | Cod |  | 130 | 28.062 |  |  |  |  |
| 661 | 60.1.2 | **Impact on:** |  | 115d | 2001-01-08 A | 2001-06-15 |  | 48% | 59.8d | 2001-01-08 | 2001-06-15 | 115d | 557d |  |  | TSG CN | 1920h | 921.6h | TFO-AMR | Cod |  | 907 |  |  |  |  |  |
| 662 | 60.1.2.1 | CN |  | 60d | 2001-03-26 A | 2001-06-15 A |  | 100% |  | 2001-03-26 | 2001-06-15 | 60d |  |  | finish no earlier than 2001-06-15 | TSG CN | 480h | 480h | TFO-AMR | Cod |  | 131 |  |  |  |  |  |
| 663 | 60.1.2.2 | GERAN |  | 65d | 2001-01-08 | 2001-04-06 |  |  |  | 2001-01-08 | 2001-04-06 | 65d | 607d |  | start no earlier than 2001-01-08 | TSG GERAN | 520h |  | TFO-AMR | Cod |  | 132 |  |  |  |  |  |
| 664 | 61 | **Advanced Speech Call Items enhancements_REL-4** |  | 334d | 2000-12-03 A | 2002-03-14 A |  | 100% |  | 2000-12-03 | 2002-03-14 | 334d |  |  |  | WG CN1 | 5925.6h | 5925.6h | ASCI |  | TSG | 2230 |  | Rel4 | Per | Sonia Garapaty | sonia.garapaty@nortelnetworks.com |
| 665 | 61.1 | Stage 2 |  | 326.7d | 2000-12-03 A | 2002-03-14 A |  | 100% |  | 2000-12-03 | 2002-03-14 | 326.7d |  |  | finish no earlier than 2002-03-14 | WG CN4 | 2613.6h | 2613.6h | ASCI |  | WG | 2232 | 23.067, 24.067 |  | Kimmo | Vivien Perlic, Sagem |  |
| 666 | 61.2 | Stages 2 and 3 on A interface |  | 80d | 2000-12-03 A | 2001-03-23 A |  | 100% |  | 2000-12-03 | 2001-03-23 | 80d |  |  | finish no earlier than 2001-03-23 | WG CN1 | 640h | 640h | ASCI |  | WG | 2231 | 44.068, 44.069, 24.008 |  | Per | Sonia Garapaty | sonia.garapaty@nortelnetworks.com |

Notes:
- 645: Requirements capture: S3#14 (Aug 00), Feature specification: S3#15 (Sep 00), Definition of architecture
- 648: Changes to call control
- 651: Presentation to S3 of threats and countermeasures analysis: S3#15, Feature specification: S3#16. S3#18: WID updated
- 655: Additional features for MExE R2000
- 658: RAN and CN to verify no problems for GSM terminals roaming in 3G R99
- 659: RAN and CN to verify UMTS_AMR_2 support
- 661: "Implementation" changed to "Impact on:" by A. Sultan (for better wording)
- 662: RAN and CN to verify UMTS_AMR_2 support
- 663: End date Modified from June to March to have it in Rel4
- 664: Approved in TSGN_10

| ID | WBS | Task | Duration | Start | Finish | Complete | Remaining | Baseline start | Baseline finish | Baseline duration | Total slack | Constraint | Resources | Work | Actual work | Text6 | Text8 | Text9 | Text1 | Text5 | Text7 | Text3 | Text2 |
| --- | --- | --- | --- | --- | --- | --- | --- | --- | --- | --- | --- | --- | --- | --- | --- | --- | --- | --- | --- | --- | --- | --- | --- |
| 667 | 62 | **700 MHz spectrum support** | 500d | 2000-01-03 A | 2001-11-30 | 74% | 129.57d | 2000-01-03 | 2001-11-30 | 500d | 437d |  | TSG GERAN | 18400h | 9528h | Rel4 | Paolo | 2403 |  |  |  |  |  |
| 668 | 62.1 | **GERAN support for the 700 MHz band** | 275d | 2000-01-03 A | 2001-01-19 A | 100% |  | 2000-01-03 | 2001-01-19 | 275d |  |  | TSG GERAN | 8800h | 8800h |  |  | 2404 |  |  |  |  |  |
| 669 | 62.1.1 | Signalling support | 275d | 2000-01-03 A | 2001-01-19 A | 100% |  | 2000-01-03 | 2001-01-19 | 275d |  | finish no earlier than 2001-01-19 | TSG GERAN | 2200h | 2200h |  |  | 2405 |  |  |  |  |  |
| 670 | 62.1.2 | Physical layer definitions | 275d | 2000-01-03 A | 2001-01-19 A | 100% |  | 2000-01-03 | 2001-01-19 | 275d |  | finish no earlier than 2001-01-19 | TSG GERAN | 2200h | 2200h |  |  | 2406 |  |  |  |  |  |
| 671 | 62.1.3 | Receiver performance and RF budget | 275d | 2000-01-03 A | 2001-01-19 A | 100% |  | 2000-01-03 | 2001-01-19 | 275d |  | finish no earlier than 2001-01-19 | TSG GERAN | 2200h | 2200h |  |  | 2407 |  |  |  |  |  |
| 672 | 62.2 | **GERAN MS Conformance test for 700 MHz band** | 175d | 2001-04-02 A | 2001-11-30 | 26% | 129.5d | 2001-04-02 | 2001-11-30 | 175d | 437d |  | TSG GERAN | 2800h | 728h |  |  | 2408 |  |  |  |  |  |
| 673 | 62.2.1 | MS test | 175d | 2001-04-02 A | 2001-11-30 | 26% | 129.5d | 2001-04-02 | 2001-11-30 | 175d | 437d | finish no earlier than 2001-11-30 | TSG GERAN | 1400h | 364h |  |  | 2409 |  |  |  |  |  |
| 674 | 62.3 | **GERAN BTS Conformance test for 700 MHz band** | 175d | 2001-04-02 | 2001-11-30 |  |  | 2001-04-02 | 2001-11-30 | 175d | 437d |  | TSG GERAN | 2800h |  |  | Paolo | 2410 |  |  |  |  |  |
| 675 | 62.3.1 | BTS test | 175d | 2001-04-02 | 2001-11-30 |  |  | 2001-04-02 | 2001-11-30 | 175d | 437d | finish no earlier than 2001-11-30 | TSG GERAN | 1400h |  |  |  | 2411 |  |  |  |  |  |
| 676 | 63 | Operator Determined Barring for Packet Oriented Services | 208d | 2000-06-01 A | 2001-03-19 A | 100% |  | 2000-06-01 | 2001-03-19 | 208d |  | finish no earlier than 2001-03-19 | TSG CN | 1664h | 1664h | Rel4 |  | 2463 | ODB | tamurato@nsf.ncos.nec.co.jp | TSG |  |  |
| 677 | 64 | **UMTS QoS Architecture for PS Domain** | 758d | 2000-01-03 A | 2002-11-27 | 33% | 504.24d | 2000-01-03 | 2002-11-27 | 758d | 179d |  | WG SA2 | 56400h | 11427h | Rel4 |  |  | QoSPS | Ina.widegren@era.ericsson.se | TSG |  |  |
| 678 | 64.1 | Requirements | 66d | 2000-03-03 | 2000-06-02 |  |  | 2000-03-03 | 2000-06-02 | 66d | 827d | finish no earlier than 2000-06-02 | WG SA1 | 528h |  |  |  |  |  |  | TSG |  |  |
| 679 | 64.2 | Architecture | 153d | 2000-06-05 A | 2001-01-03 A | 100% |  | 2000-06-05 | 2001-01-03 | 153d |  | finish no earlier than 2001-01-03 | WG SA2 | 1224h | 1224h |  |  |  |  |  | TSG | 23.107 |  |
| 680 | 64.3 | Security aspects | 151d | 2000-06-02 | 2000-12-29 |  |  | 2000-06-02 | 2000-12-29 | 151d | 677d | finish no earlier than 2000-12-29 | WG SA3 | 1208h |  |  |  | 1624 |  |  | TSG |  | QoS |
| 681 | 64.4 | Charging and QoS Management | 136d | 2001-09-21 A | 2002-03-29 | 45% | 74.8d | 2001-01-03 | 2001-03-23 | 58d | 352d | finish no earlier than 2002-03-29 | WG SA5 | 1088h | 489.6h |  |  |  | QoSPS-OAM | Albert.Yuhan@voicestream.com; Michael.Truss@MOTOROLA.COM | TSG | 32-series |  |
| 682 | 64.5 | IE for QoS PS Domain | 58d | 2001-01-03 | 2001-03-23 |  |  | 2001-01-03 | 2001-03-23 | 58d | 617d | finish no earlier than 2001-03-23 | WG CN1 | 464h |  |  |  |  |  |  | TSG | 24.008 |  |
| 683 | 64.6 | Interwork with External Networks | 58d | 2001-01-03 | 2001-03-23 |  |  | 2001-01-03 | 2001-03-23 | 58d | 617d | finish no earlier than 2001-03-23 | WG CN3 | 464h |  |  |  |  |  |  | TSG | 29.060, 29.061 |  |
| 684 | 64.7 | **RAB Quality of Service (re)Negotiation over Iu** | 155d | 2000-08-21 A | 2001-03-23 | 99% | 0d | 2000-08-21 | 2001-03-23 | 155d | 0d |  | WG RAN3 | 3648h | 2501.6h |  |  | 1681 | QoSPS-MAPEND-RABQoS |  | TSG | 25.413 |  |
| 685 | 64.7.1 | RAB Quality of Service Negotiation over Iu | 155d | 2000-08-21 A | 2001-03-23 A | 100% |  | 2000-08-21 | 2001-03-23 | 155d |  | finish no earlier than 2001-03-23 | WG RAN3 | 1240h | 1240h |  |  | 1991 | QoSPS-MAPEND-RABQoS-Negot |  | TSG |  |  |
| 686 | 64.7.2 | RAB Quality of Service Negotiation over Iu during relocation | 16d | 2001-03-02 A | 2001-03-23 A | 100% |  | 2001-03-02 | 2001-03-23 | 16d |  | start no earlier than 2001-03-02 | WG RAN3 | 128h | 128h |  |  | 2456 | QoSPS-MAPEND-RABQoS-NegotReloc |  | TSG |  |  |
| 687 | 64.7.3 | RAB Quality of Service Re-Negotiation over Iu | 130d | 2000-09-25 A | 2001-03-23 A | 100% |  | 2000-09-25 | 2001-03-23 | 130d |  | finish no earlier than 2001-03-23 | WG RAN3 | 1040h | 1040h |  |  | 1992 | QoSPS-MAPEND-RABQoS-ReNegot |  | TSG |  |  |
| 688 | 64.8 | **GERAN QoS Aspects - Handovers: maintenance of real-time QoS while moving between cells in the PLMN including inter-SGSN and SRNS relocation or possibly other mechanisms** | 500d | 2000-01-03 A | 2001-11-30 | 38% | 310.56d | 2000-01-03 | 2001-11-30 | 500d | 437d |  | TSG GERAN | 14440h | 4059.53h |  | Paolo | 1553 | GERQoS |  | TSG |  | QoS |
| 689 | 64.8.1 | **Handover Concept for the PS domain** | 500d | 2000-01-03 A | 2001-11-30 | 38% | 310.56d | 2000-01-03 | 2001-11-30 | 500d | 437d |  | TSG GERAN | 10440h | 2544h |  |  | 2306 |  |  | TSG |  |  |
| 690 | 64.8.1.1 | Stable RT handover report 25.936 including header removal | 13d | 2000-01-03 A | 2000-01-19 A | 100% |  | 2000-01-03 | 2000-01-19 | 13d |  | start no earlier than 2000-01-03 | TSG GERAN | 104h | 104h |  |  | 2309 |  |  | TSG |  |  |
| 691 | 64.8.1.2 | Update of stage 2 | 292d | 2000-01-03 A | 2001-02-13 A | 100% |  | 2000-01-03 | 2001-02-13 | 292d |  | finish no earlier than 2001-02-13 | TSG GERAN | 2336h | 2336h |  |  | 2307 |  |  | TSG |  |  |
| 692 | 64.8.1.3 | Update of relevant stage 3 specs -> RRC | 500d | 2000-01-03 | 2001-11-30 |  |  | 2000-01-03 | 2001-11-30 | 500d | 437d | finish no earlier than 2001-11-30 | WG GERAN2 | 4000h |  |  |  | 2308 |  |  | TSG |  |  |

Notes:
- 676: Completed WI missing from the P-plan Added for tracking / Text4: oshiyuki Tamura
- 677: Text4: Ina Widegren, Ericsson
- 680: 14/09/00: End date modified to end December 00. S3 awaiting liaison on any security issues from S2. S3#17: Still awaiting input (Feb 2001)
- 681: az: WID appr.SA#13. / Text4: Albert YUHAN (VoiceStream Wireless), Michael TRUSS (Motorola)
- 684: Text4: A. Molander, Ericsson
- 685: Text4: A. Molander, Ericsson
- 687: Text4: S. Irwin, Motorola

| ID | WBS | Task | Duration | Start | Finish | Complete | Baseline start | Baseline finish | Baseline duration | Total slack | Constraint | Resources | Work | Actual work | Text1 | Text7 | Text2 | Text4 | Text9 | Text3 | Text6 |
| --- | --- | --- | --- | --- | --- | --- | --- | --- | --- | --- | --- | --- | --- | --- | --- | --- | --- | --- | --- | --- | --- |
| 693 | 64.9 | **GERAN MS Conformance test for inter-system and intra-system Packet data real-time Handover** | 324d | 2001-08-31 | 2002-11-27 |  | 2001-08-31 | 2002-11-27 | 324d | 179d |  | WG GERAN4; RAN3 | 25920h |  | GERQoS-Mstest | TSG |  |  |  |  |  |
| 694 | 64.9.1 | **Handover for the PS domain** | 324d | 2001-08-31 | 2002-11-27 |  | 2001-08-31 | 2002-11-27 | 324d | 179d |  | WG GERAN4; RAN3 | 20736h |  |  | TSG |  |  |  |  |  |
| 695 | 64.9.1.1 | Stable RT handover report 25.936 including header removal | 324d | 2001-08-31 | 2002-11-27 |  | 2001-08-31 | 2002-11-27 | 324d | 179d | finish no earlier than 2002-11-27 | WG GERAN4; RAN3 | 5184h |  |  | TSG |  |  |  |  |  |
| 696 | 64.9.1.2 | Update of stage 2 | 324d | 2001-08-31 | 2002-11-27 |  | 2001-08-31 | 2002-11-27 | 324d | 179d | finish no earlier than 2002-11-27 | WG GERAN4; RAN3 | 5184h |  |  | TSG |  |  |  |  |  |
| 697 | 64.9.1.3 | Update of relevant stage 3 specs | 324d | 2001-08-31 | 2002-11-27 |  | 2001-08-31 | 2002-11-27 | 324d | 179d | finish no earlier than 2002-11-27 | WG GERAN4; RAN3 | 5184h |  |  | TSG |  |  |  |  |  |
| 698 | 64.10 | PS-domain handover for real-time services | 155d | 2000-08-28 A | 2001-03-30 A | 100% | 2000-08-28 | 2001-03-30 | 155d |  | finish no earlier than 2001-03-30 | WG RAN3 | 1240h | 1240h | QoSPS-PSdoRTS | TSG | QoS | A. Lansisalmi, Nokia | 1685 |  |  |
| 699 | 64.11 | RAB QoS Renegotiation at Relocation | 58d | 2001-01-03 | 2001-03-23 |  | 2001-01-03 | 2001-03-23 | 58d | 617d | finish no earlier than 2001-03-23 | WG RAN3 | 464h |  |  | TSG |  |  |  | 25.851, 25.946 |  |
| 700 | 65 | small Technical Enhancements and Improvements for Rel4 | 325d | 2000-01-03 | 2001-03-30 |  | 2000-01-03 | 2001-03-30 | 325d | 612d | finish no earlier than 2001-03-30 | Generic | 2600h |  | TEI4 | TSG |  |  | 1993 |  | Rel4 |

Notes:
- 700: "Joker" WI, to be used for a Rel 4 CR not related to any feature and with very limited impact on the system
